# b1ap

Schedule from Primavera P6, 2006-03-01 to 2007-10-30, data date 2006-03-01.

## Calendars

- Cal1: Mon-Fri 00:00-08:00; Sat-Sun off.
- Standard: Mon-Fri 00:00-08:00; Sat-Sun off.
- 7 Day: Mon-Sun 00:00-08:00.

## Resources

| Resource | Group |
| --- | --- |
| Carpenters | labor |
| Iron Workers | labor |
| Roofers | labor |
| Plumbers | labor |
| Subcontract Work | labor |
| HVAC Sheet Metal | labor |
| Electricians | labor |

## Schedule

| ID | Activity | Type | Duration | Start | Finish | Predecessors | Planned start | Planned finish | Constraint | Resources | PL-1 | ADur | Opened Ended Tasks | AFinish | ActDur | AStart | LOC3 Segment | LOC1 Tower | LOC2 Floor | WTYP | Constraints | MEF | P3 Task Type | PESS | Imported Late Start | MOD | Imported Early Finish | Imported Late Finish | MOST | Imported Early Start | OPTD | CRTY | Duration Risk Validation |
| --- | --- | --- | --- | --- | --- | --- | --- | --- | --- | --- | --- | --- | --- | --- | --- | --- | --- | --- | --- | --- | --- | --- | --- | --- | --- | --- | --- | --- | --- | --- | --- | --- | --- |
| 10 | Site G0 Notice to Proceed | milestone | 0d | 2006-03-01 | 2006-03-01 |  | 2006-03-01 | 2006-02-28 |  |  | 01 | 0 | No predecessors | 2006-02-28 | 0 | 2006-03-01 | GS | S |  |  |  |  |  |  |  |  |  |  |  |  |  |  |  |
| 101 | Window Wall Frames - Submit |  | 25d | 2006-03-01 | 2006-04-04 | 10 |  |  |  |  | 10 | 21 |  | 2006-03-29 | 21 | 2006-03-01 |  | S | GF | Frame |  |  |  |  |  |  |  |  |  |  |  |  |  |
| 1000 | Site G0 Mobilize |  | 10d | 2006-03-01 | 2006-03-14 | E001, 10 |  |  |  |  | 20 | 12 |  | 2006-03-30 | 12 | 2006-03-15 |  | S | GF |  |  |  |  |  |  |  |  |  |  |  |  |  |  |
| E001 | Event 001 - Delay to Mobilize |  | 1d | 2006-03-01 | 2006-03-01 |  |  |  | start on or before 2006-03-01 |  | 15 | 10 | No predecessors | 2006-03-14 | 10 | 2006-03-01 |  |  |  |  | (Type)Finish on or after (Date)3/14/2006 9:00:00 AM |  |  |  |  |  |  |  |  |  |  |  |  |
| 1100 | SiteGS Clear & Rough Grade at Elev 0+00 |  | 10d | 2006-03-15 | 2006-03-28 | 1000 |  |  |  |  | 20 | 9 |  | 2006-04-12 | 9 | 2006-03-31 | GS | S |  | Site |  | 2005-06-29 | Task | 13 | 2005-06-13 | 13 | 2005-06-24 | 2005-06-24 | 10 | 2005-06-13 | 8 |  |  |
| 1105 | SiteGS Survey & Layout at Elev 0+00 |  | 10d | 2006-03-29 | 2006-04-11 | 1100 |  |  |  | Carpenters [320 h] | 20 | 9 |  | 2006-04-25 | 9 | 2006-04-13 | GS | S |  | Site |  | 2005-07-18 | Task | 13 | 2005-06-27 | 13 | 2005-07-08 | 2005-07-08 | 10 | 2005-06-27 | 8 | CP |  |
| E002 | Event 002 - Window Frame Approval Takes 35 Days |  | 1d | 2006-03-30 | 2006-03-30 |  |  |  | start on or after 2006-03-30 |  | 15 | 35 | No predecessors | 2006-05-17 | 35 | 2006-03-30 |  |  |  |  | (Type)Finish on or after (Date)5/17/2006 9:00:00 AM |  |  |  |  |  |  |  |  |  |  |  |  |
| 201 | Window Wall Frames - Approve |  | 22d | 2006-04-05 | 2006-05-04 | E002 FF, 101 |  |  |  |  | 10 | 35 |  | 2006-05-17 | 35 | 2006-03-30 |  | S | GF | Frame |  |  |  |  |  |  |  |  |  |  |  |  |  |
| 1110 | WestGS Form/Pour Footers |  | 10d | 2006-04-12 | 2006-04-25 | 1105 |  |  |  | Carpenters [800 h] | 20 | 9 |  | 2006-05-08 | 9 | 2006-04-26 | 10 | W |  | Site |  | 2005-08-04 | Task | 13 | 2005-07-11 | 13 | 2005-07-22 | 2005-07-22 | 10 | 2005-07-11 | 8 | CP |  |
| 2105 | EastGS Underground Utilities |  | 7d | 2006-04-12 | 2006-04-20 | 1105 |  |  |  |  |  | 7 |  | 2006-05-04 | 7 | 2006-04-26 |  |  |  |  |  |  |  |  |  |  |  |  |  |  |  |  |  |
| 1115 | WestGS Erect, Bolt, Plumb Steel to Elev 77 |  | 20d | 2006-04-26 | 2006-05-23 | 1110 |  |  |  | Iron Workers [1920 h] | 22 | 18 |  | 2006-06-01 | 18 | 2006-05-09 | GS | W | 12 | Steel |  | 2005-09-09 | Task | 26 | 2005-08-22 | 26 | 2005-08-19 | 2005-09-16 | 20 | 2005-07-25 | 17 | IW |  |
| 2110 | EastGS Form/Pour Footers |  | 10d | 2006-04-26 | 2006-05-09 | 1110, 2105, 1105 |  |  |  | Carpenters [800 h] |  | 8 |  | 2006-05-18 | 8 | 2006-05-09 | 10 | E |  | Site |  | 2005-08-23 | Task | 13 | 2005-07-25 | 13 | 2005-08-05 | 2005-08-05 | 10 | 2005-07-25 | 8 | CP |  |
| 301 | Window Wall Frames - Fabricate |  | 70d | 2006-05-05 | 2006-08-10 | 201 |  |  |  |  | 10 | 82 |  | 2006-09-08 | 82 | 2006-05-18 |  | S | GF | Frame |  |  |  |  |  |  |  |  |  |  |  |  | (ID)301 (Distribution)Triangle(60;70;100) |
| 1120 | WestCL Form/Pour Slab @ Pool Level |  | 10d | 2006-05-24 | 2006-06-06 | 1115 |  |  |  | Carpenters [800 h] |  | 11 |  | 2006-06-16 | 11 | 2006-06-02 | 10 | W | CL | Slab |  | 2005-09-28 | Task | 13 | 2005-09-19 | 13 | 2005-09-02 | 2005-09-30 | 10 | 2005-08-22 | 8 | CP |  |
| 2115 | EastGS Erect, Bolt, Plumb Steel to Elev 77 |  | 20d | 2006-05-24 | 2006-06-20 | 1115, 2110 |  |  |  | Iron Workers [1920 h] | 22 | 25 |  | 2006-07-06 | 25 | 2006-06-02 | GS | E | 12 | Steel |  | 2005-09-28 | Task | 26 | 2005-08-08 | 26 | 2005-09-02 | 2005-09-02 | 20 | 2005-08-08 | 17 | IW |  |
| 1125 | WestCL Erect, Bolt, Plumb Steel to Elev 227 |  | 20d | 2006-06-21 | 2006-07-18 | 2115, 1120 |  |  |  | Iron Workers [1920 h] | 22 | 20 |  | 2006-08-03 | 20 | 2006-07-07 |  | W | 12 | Steel |  | 2005-11-03 | Task | 26 | 2005-10-03 | 26 | 2005-09-30 | 2005-10-28 | 20 | 2005-09-05 | 17 | IW |  |
| 2120 | EastCL Form/Pour Slab @ Pool Level |  | 10d | 2006-06-21 | 2006-07-04 | 2115 |  |  |  | Carpenters [800 h] | 30 | 8 |  | 2006-07-18 | 8 | 2006-07-07 | 10 | E | CL | Slab |  | 2005-10-17 | Task | 13 | 2005-09-05 | 13 | 2005-09-16 | 2005-09-16 | 10 | 2005-09-05 | 8 | CP |  |
| 1200 | SiteG5 Form/Pour Slab |  | 6d | 2006-07-05 | 2006-07-12 | 2120, 2115, 1120, 1115 |  |  |  | Carpenters [480 h] | 30 | 5 |  | 2006-07-25 | 5 | 2006-07-19 | 10 | S | G5 | Slab |  | 2005-10-27 | Task | 8 | 2006-07-17 | 8 | 2005-09-26 | 2006-07-24 | 6 | 2005-09-19 | 5 | CP |  |
| 1205 | SiteG4 Form/Pour Slab |  | 6d | 2006-07-13 | 2006-07-20 | 1200, 1115 |  |  |  | Carpenters [480 h] | 30 | 7 |  | 2006-08-03 | 7 | 2006-07-26 | 10 | S | G4 | Slab |  | 2005-11-08 | Task | 8 | 2006-07-25 | 8 | 2005-10-04 | 2006-08-01 | 6 | 2005-09-27 | 5 | CP |  |
| 1130 | West10 Form/Pour Slab @ Elev 227 |  | 10d | 2006-07-19 | 2006-08-01 | 1125 |  |  |  | Carpenters [800 h] |  | 11 |  | 2006-08-18 | 11 | 2006-08-04 | 10 | W |  | Slab |  | 2005-11-22 | Task | 13 | 2005-10-31 | 13 | 2005-10-14 | 2005-11-11 | 10 | 2005-10-03 | 8 | CP |  |
| 2125 | EastCL Erect, Bolt, Plumb Steel to Elev 227 |  | 20d | 2006-07-19 | 2006-08-15 | 1125, 2120 |  |  |  | Iron Workers [1920 h] | 22 | 22 |  | 2006-09-04 | 22 | 2006-08-04 |  | E | 12 | Steel |  | 2005-11-22 | Task | 26 | 2005-09-19 | 26 | 2005-10-14 | 2005-10-14 | 20 | 2005-09-19 | 17 | IW |  |
| 1210 | SiteG3 Form/Pour Slab |  | 6d | 2006-07-21 | 2006-07-28 | 1205, 1115 |  |  |  | Carpenters [480 h] | 30 | 5 |  | 2006-08-10 | 5 | 2006-08-04 | 10 | S | G3 | Slab |  | 2005-11-18 | Task | 8 | 2006-08-02 | 8 | 2005-10-12 | 2006-08-09 | 6 | 2005-10-05 | 5 | CP |  |
| 1215 | SiteG2 Form/Pour Slab |  | 6d | 2006-07-31 | 2006-08-07 | 1210, 1115 |  |  |  | Carpenters [480 h] | 30 | 7 |  | 2006-08-21 | 7 | 2006-08-11 | 10 | S | G2 | Slab |  | 2005-11-30 | Task | 8 | 2006-08-10 | 8 | 2005-10-20 | 2006-08-17 | 6 | 2005-10-13 | 5 | CP |  |
| 1235 | SiteG3 Fit Out Garage Levels |  | 20d | 2006-07-31 | 2006-08-25 | 1210, 1205, 1200 |  |  |  |  |  | 16 |  | 2006-09-01 | 16 | 2006-08-11 | GS | S |  |  |  |  |  |  |  |  |  |  |  |  |  |  |  |
| 1300 | West09 Form/Pour Slab |  | 4d | 2006-08-02 | 2006-08-07 | 1130, 1125 |  |  |  | Carpenters [320 h] |  | 4 |  | 2006-08-24 | 4 | 2006-08-21 | 10 | W | 09 | Slab |  | 2005-11-29 | Task | 5 | 2006-02-16 | 5 | 2005-10-20 | 2006-02-21 | 4 | 2005-10-17 | 3 | CP |  |
| 1340 | West10 Form/Pour Stair Tower Floors 1-10 |  | 10d | 2006-08-02 | 2006-08-15 | 1130, 1120 |  |  |  | Carpenters [800 h] |  | 10 |  | 2006-09-01 | 10 | 2006-08-21 | 10 | W |  | Stair |  | 2005-12-09 | Task | 13 | 2006-07-20 | 13 | 2005-10-28 | 2006-08-02 | 10 | 2005-10-17 | 8 | CP |  |
| 1220 | SiteGS Form/Pour Slab |  | 6d | 2006-08-08 | 2006-08-15 | 1215, 1115 |  |  |  | Carpenters [480 h] | 30 | 5 |  | 2006-08-28 | 5 | 2006-08-22 | 10 | S |  | Slab |  | 2005-12-12 | Task | 8 | 2006-08-18 | 8 | 2005-10-28 | 2006-08-25 | 6 | 2005-10-21 | 5 | CP |  |
| 1305 | West08 Form/Pour Slab |  | 4d | 2006-08-08 | 2006-08-11 | 1300, 1125 |  |  |  | Carpenters [320 h] |  | 5 |  | 2006-08-31 | 5 | 2006-08-25 | 10 | W | 08 | Slab |  | 2005-12-06 | Task | 5 | 2006-02-22 | 5 | 2005-10-26 | 2006-02-27 | 4 | 2005-10-21 | 3 | CP |  |
| 401 | Window Wall Frames - Deliver |  | 10d | 2006-08-11 | 2006-08-24 | E003 FF, 301 |  |  |  |  | 10 | 92 |  | 2007-01-25 | 92 | 2006-09-11 |  | S | GF | Frame |  |  |  |  |  |  |  |  |  |  |  |  |  |
| 1310 | West07 Form/Pour Slab |  | 4d | 2006-08-14 | 2006-08-17 | 1305, 1125 |  |  |  | Carpenters [320 h] |  | 4 |  | 2006-09-06 | 4 | 2006-09-01 | 10 | W | 07 | Slab |  | 2005-12-13 | Task | 5 | 2006-02-28 | 5 | 2005-11-01 | 2006-03-03 | 4 | 2005-10-27 | 3 | CP |  |
| 1135 | West10 Erect, Bolt, Plumb Steel to Elev 417 |  | 20d | 2006-08-16 | 2006-09-12 | 2125, 1130 |  |  |  | Iron Workers [1920 h] | 22 | 24 |  | 2006-10-06 | 24 | 2006-09-05 | 10 | W | 12 | Steel |  | 2005-12-28 | Task | 26 | 2005-11-14 | 26 | 2005-11-11 | 2005-12-09 | 20 | 2005-10-17 | 17 | IW |  |
| 1225 | SiteGS Form/Pour Stair Towers GS-CL |  | 10d | 2006-08-16 | 2006-08-29 | 2120, 1220, 1215, 1210, 1205, 1200, 1120 |  |  |  | Carpenters [800 h] |  | 12 |  | 2006-09-13 | 12 | 2006-08-29 | 10 | S |  | Stair |  | 2005-12-29 | Task | 13 | 2006-08-28 | 13 | 2005-11-11 | 2006-09-08 | 10 | 2005-10-31 | 8 | CP |  |
| 1240 | SiteGS Casino Layout Floor |  | 10d | 2006-08-16 | 2006-08-29 | 1220, 1215 |  |  |  |  | 50 | 9 |  | 2006-09-08 | 9 | 2006-08-29 | GS | S |  | Layout |  |  |  |  |  |  |  |  |  |  |  |  |  |
| 2130 | East10 Form/Pour Slab @ Elev 227 |  | 10d | 2006-08-16 | 2006-08-29 | 2125 |  |  |  | Carpenters [800 h] |  | 10 |  | 2006-09-18 | 10 | 2006-09-05 | 10 | E |  | Slab |  | 2005-12-09 | Task | 13 | 2005-10-17 | 13 | 2005-10-28 | 2005-10-28 | 10 | 2005-10-17 | 8 | CP |  |
| 1315 | West06 Form/Pour Slab |  | 4d | 2006-08-18 | 2006-08-23 | 1310, 1125 |  |  |  | Carpenters [320 h] |  | 5 |  | 2006-09-13 | 5 | 2006-09-07 | 10 | W | 06 | Slab |  | 2005-12-20 | Task | 5 | 2006-03-06 | 5 | 2005-11-07 | 2006-03-09 | 4 | 2005-11-02 | 3 | CP |  |
| 1320 | West05 Form/Pour Slab |  | 4d | 2006-08-24 | 2006-08-29 | 1315, 1125 |  |  |  | Carpenters [320 h] |  | 5 |  | 2006-09-20 | 5 | 2006-09-14 | 10 | W | 05 | Slab |  | 2005-12-27 | Task | 5 | 2006-03-10 | 5 | 2005-11-11 | 2006-03-15 | 4 | 2005-11-08 | 3 | CP |  |
| 1245 | SiteGS Casino Studs & Drywall/1 |  | 20d | 2006-08-30 | 2006-09-26 | 1240 |  |  |  | Carpenters [960 h] | 51 | 21 |  | 2006-10-09 | 21 | 2006-09-11 | GS | C |  | Stud |  | 2006-07-05 | Task | 3 | 2006-06-29 | 3 | 2006-03-22 | 2006-06-30 | 2 | 2006-03-21 | 2 | CP |  |
| 1250 | SiteGS Casino R/I Plumbing |  | 15d | 2006-08-30 | 2006-09-19 | 1240 |  |  |  | Plumbers [640 h] |  | 17 |  | 2006-10-03 | 17 | 2006-09-11 | GS | C |  | R/I PB |  | 2006-07-05 | Task | 3 | 2006-06-30 | 3 | 2006-03-22 | 2006-07-03 | 2 | 2006-03-21 | 2 | PB |  |
| 1255 | SiteGS Casino HVAC Ductwork |  | 20d | 2006-08-30 | 2006-09-26 | 1240 |  |  |  | HVAC Sheet Metal [640 h] |  | 23 |  | 2006-10-11 | 23 | 2006-09-11 | GS | C |  | HVAC |  | 2006-07-05 | Task | 3 | 2006-07-03 | 3 | 2006-03-22 | 2006-07-04 | 2 | 2006-03-21 | 2 | HV |  |
| 1325 | West04 Form/Pour Slab |  | 4d | 2006-08-30 | 2006-09-04 | 1320, 1125 |  |  |  | Carpenters [320 h] |  | 5 |  | 2006-09-27 | 5 | 2006-09-21 | 10 | W | 04 | Slab |  | 2006-01-03 | Task | 5 | 2006-03-16 | 5 | 2005-11-17 | 2006-03-21 | 4 | 2005-11-14 | 3 | CP |  |
| 2300 | East09 Form/Pour Slab |  | 4d | 2006-08-30 | 2006-09-04 | 2130, 2125 |  |  |  | Carpenters [320 h] |  | 4 |  | 2006-09-22 | 4 | 2006-09-19 | 10 | E | 09 | Slab |  | 2005-12-16 | Task | 5 | 2006-03-06 | 5 | 2005-11-03 | 2006-03-09 | 4 | 2005-10-31 | 3 | CP |  |
| 2340 | East10 Form/Pour Stair Tower Floors 1-10 |  | 10d | 2006-08-30 | 2006-09-12 | 2130, 2120 |  |  |  | Carpenters [800 h] |  | 9 |  | 2006-09-29 | 9 | 2006-09-19 | 10 | E |  | Stair |  | 2005-12-28 | Task | 13 | 2006-07-20 | 13 | 2005-11-11 | 2006-08-02 | 10 | 2005-10-31 | 8 | CP |  |
| 1330 | West03 Form/Pour Slab |  | 4d | 2006-09-05 | 2006-09-08 | 1325, 1125 |  |  |  | Carpenters [320 h] |  | 5 |  | 2006-10-04 | 5 | 2006-09-28 | 10 | W | 03 | Slab |  | 2006-01-10 | Task | 5 | 2006-03-22 | 5 | 2005-11-23 | 2006-03-27 | 4 | 2005-11-18 | 3 | CP |  |
| 2305 | East08 Form/Pour Slab |  | 4d | 2006-09-05 | 2006-09-08 | 2300, 2125 |  |  |  | Carpenters [320 h] |  | 5 |  | 2006-09-29 | 5 | 2006-09-25 | 10 | E | 08 | Slab |  | 2005-12-23 | Task | 5 | 2006-03-10 | 5 | 2005-11-09 | 2006-03-15 | 4 | 2005-11-04 | 3 | CP |  |
| 1335 | West02 Form/Pour Slab |  | 4d | 2006-09-11 | 2006-09-14 | 1330, 1125 |  |  |  | Carpenters [320 h] |  | 4 |  | 2006-10-10 | 4 | 2006-10-05 | 10 | W | 02 | Slab |  | 2006-01-17 | Task | 5 | 2006-03-28 | 5 | 2005-11-29 | 2006-03-31 | 4 | 2005-11-24 | 3 | CP |  |
| 2310 | East07 Form/Pour Slab |  | 4d | 2006-09-11 | 2006-09-14 | 2305, 2125 |  |  |  | Carpenters [320 h] |  | 5 |  | 2006-10-06 | 5 | 2006-10-02 | 10 | E | 07 | Slab |  | 2005-12-30 | Task | 5 | 2006-03-16 | 5 | 2005-11-15 | 2006-03-21 | 4 | 2005-11-10 | 3 | CP |  |
| 1140 | West22 Form/Pour Slab @ Elev 417 |  | 10d | 2006-09-13 | 2006-09-26 | 1135 |  |  |  | Carpenters [800 h] |  | 8 |  | 2006-10-18 | 8 | 2006-10-09 | 10 | W | 22 | Slab |  | 2006-01-16 | Task | 13 | 2006-02-06 | 13 | 2005-11-25 | 2006-02-17 | 10 | 2005-11-14 | 8 | CP |  |
| 2135 | East10 Erect, Bolt, Plumb Steel to Elev 417 |  | 20d | 2006-09-13 | 2006-10-10 | 1135, 2130 |  |  |  | Iron Workers [1920 h] | 22 | 16 |  | 2006-10-30 | 16 | 2006-10-09 | 10 | E | 12 | Steel |  | 2006-01-16 | Task | 26 | 2005-10-31 | 26 | 2005-11-25 | 2005-11-25 | 20 | 2005-10-31 | 17 | IW |  |
| 1360 | West03 Affix Window Wall Frames Floors 1-3 |  | 6d | 2006-09-15 | 2006-09-22 | 1335, 1330, 1325, 1120, 401 |  |  |  | Iron Workers [288 h] | 84 | 7 |  | 2007-02-05 | 7 | 2007-01-26 |  | W | 03 | Frame |  | 2006-02-10 | Task | 8 | 2006-04-17 | 8 | 2005-12-21 | 2006-04-24 | 6 | 2005-12-14 | 5 | IW |  |
| 2315 | East06 Form/Pour Slab |  | 4d | 2006-09-15 | 2006-09-20 | 2310, 2125 |  |  |  | Carpenters [320 h] |  | 5 |  | 2006-10-13 | 5 | 2006-10-09 | 10 | E | 06 | Slab |  | 2006-01-06 | Task | 5 | 2006-03-22 | 5 | 2005-11-21 | 2006-03-27 | 4 | 2005-11-16 | 3 | CP |  |
| 1265 | SiteGS Casino Plumbing Test |  | 10d | 2006-09-20 | 2006-10-03 | 1250 |  |  |  | Plumbers [160 h] |  | 10 |  | 2006-10-17 | 10 | 2006-10-04 | GS | C |  | PB Test |  | 2006-07-07 | Task | 1 | 2006-08-31 | 2 | 2006-03-23 | 2006-08-31 | 1 | 2006-03-23 | 1 | PB |  |
| E003 | Event 003 - Ship Hijacked by Pirates |  | 1d | 2006-09-20 | 2006-09-20 |  |  |  | start on or after 2006-09-20 |  | 15 | 92 | No predecessors | 2007-01-25 | 92 | 2006-09-20 |  |  |  |  | (Type)Start on or after (Date)9/20/2006 9:00:00 AM |  |  |  |  |  |  |  |  |  |  |  |  |
| 2320 | East05 Form/Pour Slab |  | 4d | 2006-09-21 | 2006-09-26 | 2315, 2125 |  |  |  | Carpenters [320 h] |  | 4 |  | 2006-10-19 | 4 | 2006-10-16 | 10 | E | 05 | Slab |  | 2006-01-13 | Task | 5 | 2006-03-28 | 5 | 2005-11-25 | 2006-03-31 | 4 | 2005-11-22 | 3 | CP |  |
| 1362 | West06 Affix Window Wall Frames Floors 4-6 |  | 6d | 2006-09-25 | 2006-10-02 | 1360, 1325, 1320, 1315, 1310, 401 |  |  |  | Iron Workers [288 h] | 84 | 6 |  | 2007-02-13 | 6 | 2007-02-06 |  | W | 06 | Frame |  | 2006-02-22 | Task | 8 | 2006-04-25 | 8 | 2005-12-29 | 2006-05-02 | 6 | 2005-12-22 | 5 | IW |  |
| 1260 | SiteGS Casino R/I Electric |  | 40d | 2006-09-27 | 2006-11-21 | 1245 |  |  |  | Electricians [640 h] | 51 | 40 |  | 2006-12-04 | 40 | 2006-10-10 | GS | C |  | R/I Elec |  | 2006-07-10 | Task | 3 | 2006-08-30 | 3 | 2006-03-24 | 2006-08-31 | 2 | 2006-03-23 | 2 | EL |  |
| 1350 | West22 Form/Pour Stair Tower Floors 10-22 |  | 10d | 2006-09-27 | 2006-10-10 | 1140, 1130 |  |  |  | Carpenters [800 h] |  | 12 |  | 2006-11-03 | 12 | 2006-10-19 | 10 | W | 22 | Stair |  | 2006-02-09 | Task | 13 | 2006-06-14 | 13 | 2005-12-09 | 2006-06-27 | 10 | 2005-11-28 | 8 | CP |  |
| 1400 | West21 Form/Pour Slab |  | 4d | 2006-09-27 | 2006-10-02 | 1140, 1135 |  |  |  | Carpenters [320 h] |  | 4 |  | 2006-10-24 | 4 | 2006-10-19 | 10 | W | 21 | Slab |  | 2006-01-30 | Task | 5 | 2006-03-10 | 5 | 2005-12-01 | 2006-03-15 | 4 | 2005-11-28 | 3 | CP |  |
| 2325 | East04 Form/Pour Slab |  | 4d | 2006-09-27 | 2006-10-02 | 2320, 2125 |  |  |  | Carpenters [320 h] |  | 5 |  | 2006-10-26 | 5 | 2006-10-20 | 10 | E | 04 | Slab |  | 2006-01-20 | Task | 5 | 2006-04-03 | 5 | 2005-12-01 | 2006-04-06 | 4 | 2005-11-28 | 3 | CP |  |
| 1364 | West09 Affix Window Wall Frames Floors 7-9 |  | 6d | 2006-10-03 | 2006-10-10 | 1362, 1310, 1305, 1300, 1130, 401 |  |  |  | Iron Workers [288 h] | 84 | 5 |  | 2007-02-20 | 5 | 2007-02-14 |  | W | 09 | Frame |  | 2006-03-06 | Task | 8 | 2006-05-03 | 8 | 2006-01-06 | 2006-05-10 | 6 | 2005-12-30 | 5 | IW |  |
| 1405 | West20 Form/Pour Slab |  | 4d | 2006-10-03 | 2006-10-06 | 1400, 1135 |  |  |  | Carpenters [320 h] |  | 4 |  | 2006-10-30 | 4 | 2006-10-25 | 10 | W | 20 | Slab |  | 2006-02-06 | Task | 5 | 2006-03-16 | 5 | 2005-12-07 | 2006-03-21 | 4 | 2005-12-02 | 3 | CP |  |
| 2330 | East03 Form/Pour Slab |  | 4d | 2006-10-03 | 2006-10-06 | 2325, 2125 |  |  |  | Carpenters [320 h] |  | 4 |  | 2006-11-01 | 4 | 2006-10-27 | 10 | E | 03 | Slab |  | 2006-01-27 | Task | 5 | 2006-04-07 | 5 | 2005-12-07 | 2006-04-12 | 4 | 2005-12-02 | 3 | CP |  |
| 1410 | West19 Form/Pour Slab |  | 4d | 2006-10-09 | 2006-10-12 | 1405, 1135 |  |  |  | Carpenters [320 h] |  | 5 |  | 2006-11-06 | 5 | 2006-10-31 | 10 | W | 19 | Slab |  | 2006-02-13 | Task | 5 | 2006-03-22 | 5 | 2005-12-13 | 2006-03-27 | 4 | 2005-12-08 | 3 | CP |  |
| 2335 | East02 Form/Pour Slab |  | 4d | 2006-10-09 | 2006-10-12 | 2330, 2125 |  |  |  | Carpenters [320 h] |  | 5 |  | 2006-11-08 | 5 | 2006-11-02 | 10 | E | 02 | Slab |  | 2006-02-03 | Task | 5 | 2006-04-13 | 5 | 2005-12-13 | 2006-04-18 | 4 | 2005-12-08 | 3 | CP |  |
| 2140 | East22 Form/Pour Slab @ Elev 417 |  | 10d | 2006-10-11 | 2006-10-24 | 2135 |  |  |  | Carpenters [800 h] | 81 | 10 |  | 2006-11-13 | 10 | 2006-10-31 | 10 | E | 22 | Slab |  | 2006-02-02 | Task | 13 | 2005-11-28 | 13 | 2005-12-09 | 2005-12-09 | 10 | 2005-11-28 | 8 | CP |  |
| 2200 | Skybridge Erect, Bolt, Plumb Steel @ Elev 417 |  | 15d | 2006-10-11 | 2006-10-31 | 2135, 1135 |  |  |  | Iron Workers [1440 h] | 22 | 12 |  | 2006-11-15 | 12 | 2006-10-31 |  | E | 12 | Steel |  |  |  |  |  |  |  |  |  |  |  | IW |  |
| 1415 | West18 Form/Pour Slab |  | 4d | 2006-10-13 | 2006-10-18 | 1410, 1135 |  |  |  | Carpenters [320 h] |  | 4 |  | 2006-11-10 | 4 | 2006-11-07 | 10 | W | 18 | Slab |  | 2006-02-20 | Task | 5 | 2006-03-28 | 5 | 2005-12-19 | 2006-03-31 | 4 | 2005-12-14 | 3 | CP |  |
| 2360 | East03 Affix Window Wall Frames Floors 1-3 |  | 6d | 2006-10-13 | 2006-10-20 | 2335, 2330, 2325, 2120, 401 |  |  |  | Iron Workers [288 h] |  | 6 |  | 2007-02-02 | 6 | 2007-01-26 |  | E | 03 | Frame |  | 2006-03-16 | Task | 8 | 2006-04-19 | 8 | 2005-12-21 | 2006-04-26 | 6 | 2005-12-14 | 5 | IW |  |
| 302 | Window Wall Units - Fabricate 1-22 |  | 80d | 2006-10-19 | 2007-02-07 | 2466 FF+10d, 1466 FF+10d, 201, 301 |  |  |  |  | 10 | 80 |  | 2007-04-09 | 80 | 2006-09-11 |  | S | GF | Window |  |  |  |  |  |  |  |  |  |  |  |  | (ID)302 (Distribution)Triangle(70;80;120) |
| 1420 | West17 Form/Pour Slab |  | 4d | 2006-10-19 | 2006-10-24 | 1415, 1135 |  |  |  | Carpenters [320 h] |  | 5 |  | 2006-11-17 | 5 | 2006-11-13 | 10 | W | 17 | Slab |  | 2006-02-27 | Task | 5 | 2006-04-03 | 5 | 2005-12-23 | 2006-04-06 | 4 | 2005-12-20 | 3 | CP |  |
| 2362 | East06 Affix Window Wall Frames Floors 4-6 |  | 6d | 2006-10-23 | 2006-10-30 | 2360, 2325, 2320, 2315, 2310, 401 |  |  |  | Iron Workers [288 h] |  | 5 |  | 2007-02-09 | 5 | 2007-02-05 |  | E | 06 | Frame |  | 2006-03-28 | Task | 8 | 2006-04-27 | 8 | 2005-12-29 | 2006-05-04 | 6 | 2005-12-22 | 5 | IW |  |

| ID | Activity | Duration | Start | Finish | Predecessors | Resources | MEF | P3 Task Type | ADur | PESS | AFinish | Imported Late Start | MOD | Imported Early Finish | Imported Late Finish | MOST | ActDur | Imported Early Start | OPTD | AStart | LOC2 Floor | LOC3 Segment | WTYP | LOC1 Tower | CRTY | PL-1 | Links with Lags longer than ? units | Negative Lags | Duration Risk Validation | SF Links |
| --- | --- | --- | --- | --- | --- | --- | --- | --- | --- | --- | --- | --- | --- | --- | --- | --- | --- | --- | --- | --- | --- | --- | --- | --- | --- | --- | --- | --- | --- | --- |
| 1425 | West16 Form/Pour Slab | 4d | 2006-10-25 | 2006-10-30 | 1420, 1135 SS | Carpenters [320 h] | 2006-03-06 | Task | 5 | 5 | 2006-11-24 | 2006-04-07 | 5 | 2005-12-29 | 2006-04-12 | 4 | 5 | 2005-12-26 | 3 | 2006-11-20 | 16 | 10 | Slab | W | CP |  |  |  |  |  |
| 2345 | East22 Form/Pour Stair Tower Floors 10-22 | 10d | 2006-10-25 | 2006-11-07 | 2140, 2130 | Carpenters [800 h] | 2006-02-02 | Task | 12 | 13 | 2006-11-29 | 2006-06-14 | 13 | 2005-12-23 | 2006-06-27 | 10 | 12 | 2005-12-12 | 8 | 2006-11-14 | 22 | 10 | Stair | E | CP |  |  |  |  |  |
| 2400 | East21 Form/Pour Slab | 4d | 2006-10-25 | 2006-10-30 | 2140 | Carpenters [320 h] | 2006-02-16 | Task | 5 | 5 | 2006-11-20 | 2006-03-14 | 5 | 2005-12-15 | 2006-03-17 | 4 | 5 | 2005-12-12 | 3 | 2006-11-14 | 21 | 10 | Slab | E | CP | 81 |  |  |  |  |
| 1430 | West15 Form/Pour Slab | 4d | 2006-10-31 | 2006-11-03 | 1425, 1135 | Carpenters [320 h] | 2006-03-13 | Task | 5 | 5 | 2006-12-01 | 2006-04-13 | 5 | 2006-01-04 | 2006-04-18 | 4 | 5 | 2005-12-30 | 3 | 2006-11-27 | 15 | 10 | Slab | W | CP |  |  |  |  |  |
| 2364 | East09 Affix Window Wall Frames Floors 7-9 | 6d | 2006-10-31 | 2006-11-07 | 2362, 2310, 2305, 2300, 2130, 401 | Iron Workers [288 h] | 2006-04-07 | Task | 6 | 8 | 2007-02-19 | 2006-05-05 | 8 | 2006-01-06 | 2006-05-12 | 6 | 6 | 2005-12-30 | 5 | 2007-02-12 | 09 |  | Frame | E | IW |  |  |  |  |  |
| 2405 | East20 Form/Pour Slab | 4d | 2006-10-31 | 2006-11-03 | 2400 | Carpenters [320 h] | 2006-02-23 | Task | 4 | 5 | 2006-11-24 | 2006-03-20 | 5 | 2005-12-21 | 2006-03-23 | 4 | 4 | 2005-12-16 | 3 | 2006-11-21 | 20 | 10 | Slab | E | CP | 81 |  |  |  |  |
| 1145 | West22 Erect, Bolt, Plumb Steel to Elev 567 | 20d | 2006-11-01 | 2006-11-28 | 2200, 1140 | Iron Workers [1920 h] |  | Task | 23 | 0 | 2006-12-18 | 2005-12-12 | 26 | 2005-12-09 | 2006-01-06 | 0 | 23 | 2005-11-14 | 0 | 2006-11-16 | 12 |  | Steel | W | IW | 22 |  |  |  |  |
| 2220 | Skybridge Form/Pour Slab @ Elev 417 | 5d | 2006-11-01 | 2006-11-07 | 2200 | Carpenters [400 h] |  |  | 6 |  | 2006-11-23 |  |  |  |  |  | 6 |  |  | 2006-11-16 | 22 | 10 | Slab | E | CP | 70 |  |  |  |  |
| 1435 | West14 Form/Pour Slab | 4d | 2006-11-06 | 2006-11-09 | 1430, 1135 | Carpenters [320 h] | 2006-03-20 | Task | 5 | 5 | 2006-12-08 | 2006-04-19 | 5 | 2006-01-10 | 2006-04-24 | 4 | 5 | 2006-01-05 | 3 | 2006-12-04 | 14 | 10 | Slab | W | CP |  |  |  |  |  |
| 2410 | East19 Form/Pour Slab | 4d | 2006-11-06 | 2006-11-09 | 2405 | Carpenters [320 h] | 2006-03-02 | Task | 5 | 5 | 2006-12-01 | 2006-03-24 | 5 | 2005-12-27 | 2006-03-29 | 4 | 5 | 2005-12-22 | 3 | 2006-11-27 | 19 | 10 | Slab | E | CP | 81 |  |  |  |  |
| 1440 | West13 Form/Pour Slab | 4d | 2006-11-10 | 2006-11-15 | 1435, 1135 | Carpenters [320 h] | 2006-03-27 | Task | 4 | 5 | 2006-12-14 | 2006-04-25 | 5 | 2006-01-16 | 2006-04-28 | 4 | 4 | 2006-01-11 | 3 | 2006-12-11 | 13 | 10 | Slab | W | CP |  |  |  |  |  |
| 2415 | East18 Form/Pour Slab | 4d | 2006-11-10 | 2006-11-15 | 2410 | Carpenters [320 h] | 2006-03-09 | Task | 4 | 5 | 2006-12-07 | 2006-03-30 | 5 | 2006-01-02 | 2006-04-04 | 4 | 4 | 2005-12-28 | 3 | 2006-12-04 | 18 | 10 | Slab | E | CP | 81 |  |  |  |  |
| 1445 | West12 Form/Pour Slab | 4d | 2006-11-16 | 2006-11-21 | 1440, 1135 | Carpenters [320 h] | 2006-04-03 | Task | 5 | 5 | 2006-12-21 | 2006-05-01 | 5 | 2006-01-20 | 2006-05-04 | 4 | 5 | 2006-01-17 | 3 | 2006-12-15 | 12 | 10 | Slab | W | CP |  |  |  |  |  |
| 2420 | East17 Form/Pour Slab | 4d | 2006-11-16 | 2006-11-21 | 2415 | Carpenters [320 h] | 2006-03-16 | Task | 5 | 5 | 2006-12-14 | 2006-04-05 | 5 | 2006-01-06 | 2006-04-10 | 4 | 5 | 2006-01-03 | 3 | 2006-12-08 | 17 | 10 | Slab | E | CP | 81 |  |  |  |  |
| 1270 | SiteGS Casino Drywall/2 & Finishes | 20d | 2006-11-22 | 2006-12-19 | 1265, 1260, 1255 | Carpenters [960 h] | 2006-07-13 | Task | 17 | 3 | 2006-12-27 | 2006-09-01 | 3 | 2006-03-28 | 2006-09-04 | 2 | 17 | 2006-03-27 | 2 | 2006-12-05 |  | GS | Drywall | C | CP | 51 |  |  |  |  |
| 1450 | West11 Form/Pour Slab | 4d | 2006-11-22 | 2006-11-27 | 1445, 1135 | Carpenters [320 h] | 2006-04-10 | Task | 4 | 5 | 2006-12-27 | 2006-05-05 | 5 | 2006-01-26 | 2006-05-10 | 4 | 4 | 2006-01-23 | 3 | 2006-12-22 | 11 | 10 | Slab | W | CP |  |  |  |  |  |
| 2425 | East16 Form/Pour Slab | 4d | 2006-11-22 | 2006-11-27 | 2420 | Carpenters [320 h] | 2006-03-23 | Task | 4 | 5 | 2006-12-20 | 2006-04-11 | 5 | 2006-01-12 | 2006-04-14 | 4 | 4 | 2006-01-09 | 3 | 2006-12-15 | 16 | 10 | Slab | E | CP | 81 |  |  |  |  |
| 1460 | West12 Affix Window Wall Frames Floors 10-12 | 6d | 2006-11-28 | 2006-12-05 | 1364, 1450, 1445, 1440, 401 | Iron Workers [288 h] | 2006-04-20 | Task | 6 | 8 | 2007-02-28 | 2006-05-11 | 8 | 2006-02-03 | 2006-05-18 | 6 | 6 | 2006-01-27 | 5 | 2007-02-21 | 13 |  | Frame | W | IW | 84 |  |  |  |  |
| 2430 | East15 Form/Pour Slab | 4d | 2006-11-28 | 2006-12-01 | 2425 | Carpenters [320 h] | 2006-03-30 | Task | 5 | 5 | 2006-12-27 | 2006-04-17 | 5 | 2006-01-18 | 2006-04-20 | 4 | 5 | 2006-01-13 | 3 | 2006-12-21 | 15 | 10 | Slab | E | CP | 81 |  |  |  |  |
| 1150 | West32 Form/Pour Slab @ Elev 567 | 10d | 2006-11-29 | 2006-12-12 | 1145 | Carpenters [800 h] |  | Task | 9 | 0 | 2006-12-29 | 2006-01-09 | 13 | 2005-12-23 | 2006-01-20 | 0 | 9 | 2005-12-12 | 0 | 2006-12-19 |  | 10 | Slab | W | CP |  |  |  |  |  |
| 2145 | East22 Erect, Bolt, Plumb Steel to Elev 567 | 20d | 2006-11-29 | 2006-12-26 | 1145, 2200, 2140 | Iron Workers [1920 h] |  | Task | 22 | 0 | 2007-01-17 | 2005-12-12 | 26 | 2006-01-06 | 2006-01-06 | 0 | 22 | 2005-12-12 | 0 | 2006-12-19 | 12 |  | Steel | E | IW | 22 |  |  |  |  |
| 2435 | East14 Form/Pour Slab | 4d | 2006-12-04 | 2006-12-07 | 2430 | Carpenters [320 h] | 2006-04-06 | Task | 5 | 5 | 2007-01-03 | 2006-04-21 | 5 | 2006-01-24 | 2006-04-26 | 4 | 5 | 2006-01-19 | 3 | 2006-12-28 | 14 | 10 | Slab | E | CP | 81 |  |  |  |  |
| 1462 | West15 Affix Window Wall Frames Floors 13-15 | 5d | 2006-12-06 | 2006-12-12 | 1460, 1440, 1435, 1430, 1425, 401 | Iron Workers [240 h] | 2006-04-28 | Task | 6 | 6 | 2007-03-08 | 2006-05-19 | 6 | 2006-02-10 | 2006-05-25 | 5 | 6 | 2006-02-06 | 4 | 2007-03-01 | 15 |  | Frame | W | IW | 84 |  |  |  |  |
| 2440 | East13 Form/Pour Slab | 4d | 2006-12-08 | 2006-12-13 | 2435 | Carpenters [320 h] | 2006-04-13 | Task | 5 | 5 | 2007-01-10 | 2006-04-27 | 5 | 2006-01-30 | 2006-05-02 | 4 | 5 | 2006-01-25 | 3 | 2007-01-04 | 13 | 10 | Slab | E | CP | 81 |  |  |  |  |
| 1464 | West18 Affix Window Wall Frames Floors 16-18 | 5d | 2006-12-13 | 2006-12-19 | 1462, 1425, 1420, 1415, 1410, 401 | Iron Workers [240 h] | 2006-05-08 | Task | 5 | 6 | 2007-03-15 | 2006-05-26 | 6 | 2006-02-17 | 2006-06-01 | 5 | 5 | 2006-02-13 | 4 | 2007-03-09 | 18 |  | Frame | W | IW | 84 |  |  |  |  |
| 1500 | West31 Form/Pour Slab | 4d | 2006-12-13 | 2006-12-18 | 1150, 1145 | Carpenters [320 h] | 2005-12-16 | Task | 5 | 5 | 2007-01-05 | 2006-03-28 | 5 | 2005-12-29 | 2006-03-31 | 4 | 5 | 2005-12-26 | 3 | 2007-01-01 | 31 | 10 | Slab | W | CP |  |  |  |  |  |
| 1540 | West22 Form/Pour Stair Tower Floors 22-32 | 10d | 2006-12-13 | 2006-12-26 | 1150 | Carpenters [800 h] | 2005-12-28 | Task | 9 | 13 | 2007-01-11 | 2006-07-20 | 13 | 2006-01-06 | 2006-08-02 | 10 | 9 | 2005-12-26 | 8 | 2007-01-01 |  | 10 | Stair | W | CP |  |  |  |  |  |
| 2445 | East12 Form/Pour Slab | 4d | 2006-12-14 | 2006-12-19 | 2440 | Carpenters [320 h] | 2006-04-20 | Task | 4 | 5 | 2007-01-16 | 2006-05-03 | 5 | 2006-02-03 | 2006-05-08 | 4 | 4 | 2006-01-31 | 3 | 2007-01-11 | 12 | 10 | Slab | E | CP | 81 |  |  |  |  |
| 1505 | West30 Form/Pour Slab | 4d | 2006-12-19 | 2006-12-22 | 1500, 1145 | Carpenters [320 h] | 2005-12-23 | Task | 4 | 5 | 2007-01-11 | 2006-04-03 | 5 | 2006-01-04 | 2006-04-06 | 4 | 4 | 2005-12-30 | 3 | 2007-01-08 | 30 | 10 | Slab | W | CP |  |  |  |  |  |
| 1275 | SiteGS Casino Electric Fixtures | 40d | 2006-12-20 | 2007-02-13 | 1270 | Electricians [320 h] | 2006-07-18 | Task | 39 | 3 | 2007-02-20 | 2006-09-05 | 3 | 2006-03-30 | 2006-09-06 | 2 | 39 | 2006-03-29 | 2 | 2006-12-28 |  | GS | Elec Fixt | C | EL | 51 |  |  |  |  |
| 1280 | SiteGS Casino Plumbing Fixtures | 20d | 2006-12-20 | 2007-01-16 | 1270 | Plumbers [320 h] | 2006-07-18 | Task | 21 | 3 | 2007-01-25 | 2006-09-05 | 3 | 2006-03-30 | 2006-09-06 | 2 | 21 | 2006-03-29 | 2 | 2006-12-28 |  | GS | PB Fixt | C | PB |  |  |  |  |  |
| 1285 | SiteGS Casino HVAC Fixtures | 10d | 2006-12-20 | 2007-01-02 | 1270 | HVAC Sheet Metal [160 h] | 2006-07-17 | Task | 10 | 1 | 2007-01-10 | 2006-09-06 | 2 | 2006-03-29 | 2006-09-06 | 1 | 10 | 2006-03-29 | 1 | 2006-12-28 |  | GS | HVAC Fixt | C | HV |  |  |  |  |  |
| 1466 | West22 Affix Window Wall Frames Floors 19-22 | 6d | 2006-12-20 | 2006-12-27 | 1464, 1410, 1405, 1400, 1140, 401 | Iron Workers [288 h] | 2006-05-18 | Task | 7 | 8 | 2007-03-26 | 2006-06-02 | 8 | 2006-02-27 | 2006-06-09 | 6 | 7 | 2006-02-20 | 5 | 2007-03-16 | 22 |  | Frame | W | IW | 84 | (ID)302 (Link)FF[10] |  |  |  |
| 2450 | East11 Form/Pour Slab | 4d | 2006-12-20 | 2006-12-25 | 2445 | Carpenters [320 h] | 2006-04-27 | Task | 5 | 5 | 2007-01-23 | 2006-05-09 | 5 | 2006-02-09 | 2006-05-12 | 4 | 5 | 2006-02-06 | 3 | 2007-01-17 | 11 | 10 | Slab | E | CP | 81 |  |  |  |  |
| 1510 | West29 Form/Pour Slab | 4d | 2006-12-25 | 2006-12-28 | 1505, 1145 | Carpenters [320 h] | 2005-12-30 | Task | 5 | 5 | 2007-01-18 | 2006-04-07 | 5 | 2006-01-10 | 2006-04-12 | 4 | 5 | 2006-01-05 | 3 | 2007-01-12 | 29 | 10 | Slab | W | CP |  |  |  |  |  |
| 2460 | East12 Affix Window Wall Frames Floors 10-12 | 6d | 2006-12-26 | 2007-01-02 | 2364, 2450, 2445, 2440, 2130, 401 | Iron Workers [288 h] | 2006-05-09 | Task | 6 | 8 | 2007-02-27 | 2006-05-15 | 8 | 2006-02-17 | 2006-05-22 | 6 | 6 | 2006-02-10 | 5 | 2007-02-20 | 12 |  | Frame | E | IW | 81 |  |  |  |  |
| 1155 | West32 Erect, Bolt, Plumb Steel to Elev 757 | 20d | 2006-12-27 | 2007-01-23 | 2145, 1150 | Iron Workers [1920 h] |  | Task | 19 | 0 | 2007-02-13 | 2006-01-23 | 26 | 2006-01-20 | 2006-02-17 | 0 | 19 | 2005-12-26 | 0 | 2007-01-18 | 12 | 32 | Steel | W | IW | 22 |  |  |  |  |
| 2150 | East32 Form/Pour Slab @ Elev 567 | 10d | 2006-12-27 | 2007-01-09 | 2145 | Carpenters [800 h] |  | Task | 9 | 0 | 2007-01-30 | 2006-01-09 | 13 | 2006-01-20 | 2006-01-20 | 0 | 9 | 2006-01-09 | 0 | 2007-01-18 |  | 10 | Slab | E | CP |  |  |  |  |  |
| 1515 | West28 Form/Pour Slab | 4d | 2006-12-29 | 2007-01-03 | 1510, 1145 | Carpenters [320 h] | 2006-01-06 | Task | 4 | 5 | 2007-01-24 | 2006-04-13 | 5 | 2006-01-16 | 2006-04-18 | 4 | 4 | 2006-01-11 | 3 | 2007-01-19 | 28 | 10 | Slab | W | CP |  |  |  |  |  |
| 2462 | East15 Affix Window Wall Frames Floors 13-15 | 5d | 2007-01-03 | 2007-01-09 | 2460, 2440, 2435, 2430, 2425, 401 | Iron Workers [240 h] | 2006-05-17 | Task | 4 | 6 | 2007-03-05 | 2006-05-23 | 6 | 2006-02-24 | 2006-05-29 | 5 | 4 | 2006-02-20 | 4 | 2007-02-28 | 15 |  | Frame | E | IW | 81 |  |  |  |  |
| 1520 | West27 Form/Pour Slab | 4d | 2007-01-04 | 2007-01-09 | 1515, 1145 | Carpenters [320 h] | 2006-01-13 | Task | 4 | 5 | 2007-01-30 | 2006-04-19 | 5 | 2006-01-20 | 2006-04-24 | 4 | 4 | 2006-01-17 | 3 | 2007-01-25 | 27 | 10 | Slab | W | CP |  |  |  |  |  |
| 1525 | West26 Form/Pour Slab | 4d | 2007-01-10 | 2007-01-15 | 1520, 1145 | Carpenters [320 h] | 2006-01-20 | Task | 4 | 5 | 2007-02-05 | 2006-04-25 | 5 | 2006-01-26 | 2006-04-28 | 4 | 4 | 2006-01-23 | 3 | 2007-01-31 | 26 | 10 | Slab | W | CP |  |  |  |  |  |
| 2464 | East18 Affix Window Wall Frames Floors 16-18 | 5d | 2007-01-10 | 2007-01-16 | 2462, 2425, 2420, 2415, 2410, 401 | Iron Workers [240 h] | 2006-05-25 | Task | 6 | 6 | 2007-03-13 | 2006-05-30 | 6 | 2006-03-03 | 2006-06-05 | 5 | 6 | 2006-02-27 | 4 | 2007-03-06 | 18 |  | Frame | E | IW | 81 |  |  |  |  |
| 2500 | East31 Form/Pour Slab | 4d | 2007-01-10 | 2007-01-15 | 2150 | Carpenters [320 h] | 2005-12-16 | Task | 5 | 5 | 2007-02-06 | 2006-03-28 | 5 | 2006-01-26 | 2006-03-31 | 4 | 5 | 2006-01-23 | 3 | 2007-01-31 | 31 | 10 | Slab | E | CP |  |  |  |  |  |
| 2540 | East22 Form/Pour Stair Tower Floors 22-32 | 10d | 2007-01-10 | 2007-01-23 | 2150 | Carpenters [800 h] | 2005-12-28 | Task | 9 | 13 | 2007-02-12 | 2006-06-01 | 13 | 2006-02-03 | 2006-06-14 | 10 | 9 | 2006-01-23 | 8 | 2007-01-31 |  | 10 | Stair | E | CP |  |  |  |  |  |
| 1530 | West25 Form/Pour Slab | 4d | 2007-01-16 | 2007-01-19 | 1525, 1145 | Carpenters [320 h] | 2006-01-27 | Task | 4 | 5 | 2007-02-09 | 2006-05-01 | 5 | 2006-02-01 | 2006-05-04 | 4 | 4 | 2006-01-27 | 3 | 2007-02-06 | 25 | 10 | Slab | W | CP |  |  |  |  |  |
| 2505 | East30 Form/Pour Slab | 4d | 2007-01-16 | 2007-01-19 | 2500 | Carpenters [320 h] | 2005-12-23 | Task | 4 | 5 | 2007-02-12 | 2006-04-03 | 5 | 2006-02-01 | 2006-04-06 | 4 | 4 | 2006-01-27 | 3 | 2007-02-07 | 30 | 10 | Slab | E | CP |  |  |  |  |  |
| 2466 | East22 Affix Window Wall Frames Floors 19-22 | 6d | 2007-01-17 | 2007-01-24 | 2464, 2410, 2405, 2400, 2140, 401 | Iron Workers [288 h] | 2006-06-06 | Task | 7 | 8 | 2007-03-22 | 2006-06-06 | 8 | 2006-03-13 | 2006-06-13 | 6 | 7 | 2006-03-06 | 5 | 2007-03-14 | 22 |  | Frame | E | IW | 81 | (ID)302 (Link)FF[10] |  |  |  |
| 1532 | West24 Form/Pour Slab | 4d | 2007-01-22 | 2007-01-25 | 1530, 1145 | Carpenters [320 h] | 2006-02-03 | Task | 5 | 5 | 2007-02-16 | 2006-05-05 | 5 | 2006-02-07 | 2006-05-10 | 4 | 5 | 2006-02-02 | 3 | 2007-02-12 | 24 | 10 | Slab | W | CP |  |  |  |  |  |
| 2510 | East29 Form/Pour Slab | 4d | 2007-01-22 | 2007-01-25 | 2505 | Carpenters [320 h] | 2005-12-30 | Task | 4 | 5 | 2007-02-16 | 2006-04-07 | 5 | 2006-02-07 | 2006-04-12 | 4 | 4 | 2006-02-02 | 3 | 2007-02-13 | 29 | 10 | Slab | E | CP |  |  |  |  |  |
| 1160 | WestRF Form/Pour Slab @ Elev 757 | 10d | 2007-01-24 | 2007-02-06 | 1155 | Carpenters [800 h] |  | Task | 10 | 0 | 2007-02-27 | 2006-02-20 | 13 | 2006-02-03 | 2006-03-03 | 0 | 10 | 2006-01-23 | 0 | 2007-02-14 | RF | 10 | Slab | W | CP |  |  |  |  |  |
| 2155 | East32 Erect, Bolt, Plumb Steel to Elev 757 | 20d | 2007-01-24 | 2007-02-20 | 1155, 2150 | Iron Workers [1920 h] |  | Task | 16 | 0 | 2007-03-07 | 2006-01-23 | 26 | 2006-02-17 | 2006-02-17 | 0 | 16 | 2006-01-23 | 0 | 2007-02-14 | 12 | 32 | Steel | E | IW | 22 |  |  |  |  |
| 1534 | West23 Form/Pour Slab | 4d | 2007-01-26 | 2007-01-31 | 1532, 1145 | Carpenters [320 h] | 2006-02-03 | Task | 5 | 5 | 2007-02-23 | 2006-05-11 | 5 | 2006-02-13 | 2006-05-16 | 4 | 5 | 2006-02-08 | 3 | 2007-02-19 |  | 10 | Slab | W | CP |  |  |  |  |  |
| 2515 | East28 Form/Pour Slab | 4d | 2007-01-26 | 2007-01-31 | 2510 | Carpenters [320 h] | 2006-01-06 | Task | 4 | 5 | 2007-02-22 | 2006-04-13 | 5 | 2006-02-13 | 2006-04-18 | 4 | 4 | 2006-02-08 | 3 | 2007-02-19 | 28 | 10 | Slab | E | CP |  |  |  |  |  |
| 1560 | West25 Affix Window Wall Frames Floors 23-25 | 6d | 2007-02-01 | 2007-02-08 | 1466, 1534, 1532, 1530, 1525, 401 | Iron Workers [288 h] | 2006-03-16 | Task | 6 | 8 | 2007-04-03 | 2006-05-17 | 8 | 2006-02-21 | 2006-05-24 | 6 | 6 | 2006-02-14 | 5 | 2007-03-27 | 25 |  | Frame | W | IW |  |  |  |  |  |
| 2520 | East27 Form/Pour Slab | 4d | 2007-02-01 | 2007-02-06 | 2515 | Carpenters [320 h] | 2006-01-13 | Task | 5 | 5 | 2007-03-01 | 2006-04-19 | 5 | 2006-02-17 | 2006-04-24 | 4 | 5 | 2006-02-14 | 3 | 2007-02-23 | 27 | 10 | Slab | E | CP |  |  |  |  |  |
| 1545 | West33 Form/Pour Stair Tower Floors 32-RF | 10d | 2007-02-07 | 2007-02-20 | 1160 | Carpenters [800 h] | 2006-02-02 | Task | 11 | 13 | 2007-03-14 | 2006-06-14 | 13 | 2006-02-17 | 2006-06-27 | 10 | 11 | 2006-02-06 | 8 | 2007-02-28 | RF | 10 | Stair | W | CP |  |  |  |  |  |
| 1600 | West44 Form/Pour Slab | 4d | 2007-02-07 | 2007-02-12 | 1160 | Carpenters [320 h] | 2006-02-09 | Task | 5 | 5 | 2007-03-06 | 2006-03-06 | 5 | 2006-02-09 | 2006-03-09 | 4 | 5 | 2006-02-06 | 3 | 2007-02-28 | 44 | 10 | Slab | W | CP |  |  |  |  |  |
| 2525 | East26 Form/Pour Slab | 4d | 2007-02-07 | 2007-02-12 | 2520 | Carpenters [320 h] | 2006-01-20 | Task | 5 | 5 | 2007-03-08 | 2006-04-25 | 5 | 2006-02-23 | 2006-04-28 | 4 | 5 | 2006-02-20 | 3 | 2007-03-02 | 26 | 10 | Slab | E | CP |  |  |  |  |  |
| 303 | Window Wall Units - Fabricate 23-44 | 80d | 2007-02-08 | 2007-06-26 | 2666 FF+10d, 1666 FF+10d, 302 SS, 301, 302 |  |  |  | 80 |  | 2007-07-30 |  |  |  |  |  | 80 |  |  | 2007-04-10 | GF |  | Window | S |  | 10 |  | (ID)304 (Link)SF[-40] | (ID)303 (Distribution)Triangle(70;80;120) | (ID)304 (Link)SF[-40] |
| 402 | Window Wall Units - Deliver 1-22 | 15d | 2007-02-08 | 2007-02-28 | E004, 302 |  |  |  | 18 |  | 2007-05-07 |  |  |  |  |  | 18 |  |  | 2007-04-12 | GF |  | Window | S |  | 10 |  |  | (ID)402 (Distribution)Triangle(15;15;20) |  |
| 1562 | West28 Affix Window Wall Frames Floors 26-28 | 6d | 2007-02-09 | 2007-02-16 | 1560, 1525, 1520, 1515, 1510, 401 | Iron Workers [288 h] | 2006-03-28 | Task | 5 | 8 | 2007-04-10 | 2006-05-25 | 8 | 2006-03-01 | 2006-06-01 | 6 | 5 | 2006-02-22 | 5 | 2007-04-04 | 28 |  | Frame | W | IW |  |  |  |  |  |
| 1602 | West43 Form/Pour Slab | 4d | 2007-02-13 | 2007-02-16 | 1600 | Carpenters [320 h] | 2006-02-16 | Task | 4 | 5 | 2007-03-12 | 2006-03-10 | 5 | 2006-02-15 | 2006-03-15 | 4 | 4 | 2006-02-10 | 3 | 2007-03-07 | 43 | 10 | Slab | W | CP |  |  |  |  |  |
| 2530 | East25 Form/Pour Slab | 4d | 2007-02-13 | 2007-02-16 | 2525 | Carpenters [320 h] | 2006-01-27 | Task | 5 | 5 | 2007-03-15 | 2006-05-01 | 5 | 2006-03-01 | 2006-05-04 | 4 | 5 | 2006-02-24 | 3 | 2007-03-09 | 25 | 10 | Slab | E | CP |  |  |  |  |  |
| 1290 | SiteGS Casino Paint & Carpeting | 20d | 2007-02-14 | 2007-03-13 | 1285, 1280, 1275 | Subcontract Work [960 h] | 2006-07-21 | Task | 18 | 3 | 2007-03-16 | 2006-09-07 | 3 | 2006-04-03 | 2006-09-08 | 2 | 18 | 2006-03-31 | 2 | 2007-02-21 |  | GS | Paint | C | SB | 51 |  |  |  |  |
| 1564 | West31 Affix Window Wall Frames Floors 29-31 | 6d | 2007-02-19 | 2007-02-26 | 1562, 1510, 1505, 1500, 1150, 401 | Iron Workers [288 h] | 2006-04-07 | Task | 5 | 8 | 2007-04-17 | 2006-06-02 | 8 | 2006-03-09 | 2006-06-09 | 6 | 5 | 2006-03-02 | 5 | 2007-04-11 | 31 |  | Frame | W | IW |  |  |  |  |  |
| 1604 | West42 Form/Pour Slab | 4d | 2007-02-19 | 2007-02-22 | 1602 | Carpenters [320 h] | 2006-02-23 | Task | 4 | 5 | 2007-03-16 | 2006-03-16 | 5 | 2006-02-21 | 2006-03-21 | 4 | 4 | 2006-02-16 | 3 | 2007-03-13 | 42 | 10 | Slab | W | CP |  |  |  |  |  |
| 2532 | East24 Form/Pour Slab | 4d | 2007-02-19 | 2007-02-22 | 2530 | Carpenters [320 h] | 2006-02-03 | Task | 5 | 5 | 2007-03-22 | 2006-05-05 | 5 | 2006-03-07 | 2006-05-10 | 4 | 5 | 2006-03-02 | 3 | 2007-03-16 | 24 | 10 | Slab | E | CP |  |  |  |  |  |
| 1165 | WestRF Roofing | 10d | 2007-02-21 | 2007-03-06 | 1545, 1160, 1140 | Roofers [480 h] | 2006-02-02 | Task | 10 | 13 | 2007-03-28 | 2006-08-28 | 13 | 2006-03-03 | 2006-09-08 | 10 | 10 | 2006-02-20 | 8 | 2007-03-15 | RF |  | Site | W |  |  |  |  |  |  |
| 2160 | EastRF Form/Pour Slab @ Elev 757 | 10d | 2007-02-21 | 2007-03-06 | 2155 | Carpenters [800 h] |  | Task | 8 | 0 | 2007-03-19 | 2006-02-20 | 13 | 2006-03-03 | 2006-03-03 | 0 | 8 | 2006-02-20 | 0 | 2007-03-08 | RF | 10 | Slab | E | CP | 24 |  |  |  |  |

| ID | Activity | Duration | Start | Finish | Predecessors | Constraint | Calendar | Resources | ADur | AFinish | ActDur | AStart | LOC2 Floor | WTYP | LOC1 Tower | CRTY | MEF | P3 Task Type | PESS | Imported Late Start | MOD | Imported Early Finish | Imported Late Finish | MOST | Imported Early Start | OPTD | LOC3 Segment | PL-1 | Opened Ended Tasks | Constraints | CRSZ |
| --- | --- | --- | --- | --- | --- | --- | --- | --- | --- | --- | --- | --- | --- | --- | --- | --- | --- | --- | --- | --- | --- | --- | --- | --- | --- | --- | --- | --- | --- | --- | --- |
| 2205 | Skybridge Erect, Bolt, Plumb Steel @ Elev 377 | 15d | 2007-02-21 | 2007-03-13 | 2155, 2200 |  | Standard | Iron Workers [1440 h] | 12 | 2007-03-23 | 12 | 2007-03-08 | 12 | Steel | E | IW |  |  |  |  |  |  |  |  |  |  |  |  |  |  |  |
| 1605 | West41 Form/Pour Slab | 4d | 2007-02-23 | 2007-02-28 | 1604 |  |  | Carpenters [320 h] | 4 | 2007-03-22 | 4 | 2007-03-19 | 41 | Slab | W | CP | 2006-03-02 | Task | 5 | 2006-03-22 | 5 | 2006-02-27 | 2006-03-27 | 4 | 2006-02-22 | 3 | 10 |  |  |  |  |
| 2534 | East23 Form/Pour Slab | 4d | 2007-02-23 | 2007-02-28 | 2532 |  |  | Carpenters [320 h] | 4 | 2007-03-28 | 4 | 2007-03-23 |  | Slab | E | CP | 2006-02-03 | Task | 5 | 2006-05-11 | 5 | 2006-03-13 | 2006-05-16 | 4 | 2006-03-08 | 3 | 10 |  |  |  |  |
| 1610 | West40 Form/Pour Slab | 4d | 2007-03-01 | 2007-03-06 | 1605 |  |  | Carpenters [320 h] | 5 | 2007-03-29 | 5 | 2007-03-23 | 40 | Slab | W | CP | 2006-03-09 | Task | 5 | 2006-03-28 | 5 | 2006-03-03 | 2006-03-31 | 4 | 2006-02-28 | 3 | 10 |  |  |  |  |
| 2470 | East22 Affix Window Wall Units Floors 1-22 | 12d | 2007-03-01 | 2007-03-16 | E005 FF, 2466, 2464, 2462, 2460, 2364, 2362, 2360, 402 |  |  | Iron Workers [576 h] | 12 | 2007-06-08 | 12 | 2007-05-08 | 21 | Window | E | IW | 2006-06-28 | Task | 16 | 2006-06-14 | 16 | 2006-03-29 | 2006-06-29 | 12 | 2006-03-14 | 10 |  | 26 |  |  |  |
| 2560 | East25 Affix Window Wall Frames Floors 23-25 | 6d | 2007-03-01 | 2007-03-08 | 2466, 2534, 2532, 2530, 2525, 2140, 401 |  |  | Iron Workers [288 h] | 7 | 2007-04-06 | 7 | 2007-03-29 | 25 | Frame | E | IW | 2006-03-16 | Task | 8 | 2006-05-17 | 8 | 2006-03-21 | 2006-05-24 | 6 | 2006-03-14 | 5 |  |  |  |  |  |
| E004 | Event 004 - Industry Strike by Dockworkers | 1d | 2007-03-01 | 2007-03-01 |  | start on or after 2007-03-01 |  |  | 30 | 2007-04-11 | 30 | 2007-03-01 |  |  |  |  |  |  |  |  |  |  |  |  |  |  |  | 15 | No predecessors | (Type)Start on or after (Date)3/1/2007 9:00:00 AM |  |
| 1615 | West39 Form/Pour Slab | 4d | 2007-03-07 | 2007-03-12 | 1610 |  |  | Carpenters [320 h] | 4 | 2007-04-04 | 4 | 2007-03-30 | 39 | Slab | W | CP | 2006-03-16 | Task | 5 | 2006-04-03 | 5 | 2006-03-09 | 2006-04-06 | 4 | 2006-03-06 | 3 | 10 |  |  |  |  |
| 2545 | East33 Form/Pour Stair Tower Floors 32-RF | 10d | 2007-03-07 | 2007-03-20 | 2160 |  |  | Carpenters [800 h] | 8 | 2007-03-29 | 8 | 2007-03-20 | RF | Stair | E | CP | 2006-02-02 | Task | 13 | 2006-05-15 | 13 | 2006-03-17 | 2006-05-26 | 10 | 2006-03-06 | 8 | 10 |  |  |  |  |
| 2600 | East44 Form/Pour Slab | 4d | 2007-03-07 | 2007-03-12 | 2160 |  |  | Carpenters [320 h] | 4 | 2007-03-23 | 4 | 2007-03-20 | 44 | Slab | E | CP | 2006-02-09 | Task | 5 | 2006-03-06 | 5 | 2006-03-09 | 2006-03-09 | 4 | 2006-03-06 | 3 | 10 | 24 |  |  |  |
| 2562 | East26 Affix Window Wall Frames Floors 26-28 | 6d | 2007-03-09 | 2007-03-16 | 2560, 2525, 2520, 2515, 2510, 401 |  |  | Iron Workers [288 h] | 7 | 2007-04-17 | 7 | 2007-04-09 | 28 | Frame | E | IW | 2006-03-28 | Task | 8 | 2006-05-25 | 8 | 2006-03-29 | 2006-06-01 | 6 | 2006-03-22 | 5 |  |  |  |  |  |
| 1620 | West38 Form/Pour Slab | 4d | 2007-03-13 | 2007-03-16 | 1615 |  |  | Carpenters [320 h] | 5 | 2007-04-11 | 5 | 2007-04-05 | 38 | Slab | W | CP | 2006-03-23 | Task | 5 | 2006-04-07 | 5 | 2006-03-15 | 2006-04-12 | 4 | 2006-03-10 | 3 | 10 |  |  |  |  |
| 2602 | East43 Form/Pour Slab | 4d | 2007-03-13 | 2007-03-16 | 2600 |  |  | Carpenters [320 h] | 4 | 2007-03-29 | 4 | 2007-03-26 | 43 | Slab | E | CP | 2006-02-16 | Task | 5 | 2006-03-10 | 5 | 2006-03-15 | 2006-03-15 | 4 | 2006-03-10 | 3 | 10 | 24 |  |  |  |
| 1295 | SiteGS Casino Fit Out | 60d | 2007-03-14 | 2007-06-05 | 1290 |  |  |  | 74 | 2007-06-28 | 74 | 2007-03-19 |  |  | S |  |  |  |  |  |  |  |  |  |  |  | GS | 52 |  |  |  |
| 2210 | Skybridge Form/Pour Slab @ Elev 377 | 5d | 2007-03-14 | 2007-03-20 | 2205 |  |  | Carpenters [400 h] | 6 | 2007-04-02 | 6 | 2007-03-26 | 20 | Slab | E | CP |  |  |  |  |  |  |  |  |  |  | 10 | 70 |  |  |  |
| 1470 | West22 Affix Window Wall Units Floors 1-22 | 12d | 2007-03-19 | 2007-04-03 | E005 FF+24d, 2470, 1466, 1464, 1462, 1460, 1364, 1362, 1360, 402 |  |  | Iron Workers [576 h] | 12 | 2007-07-12 | 12 | 2007-06-11 | 22 | Window | W | IW | 2006-06-09 | Task | 16 | 2006-06-12 | 16 | 2006-03-15 | 2006-06-27 | 12 | 2006-02-28 | 10 |  | 27 |  |  |  |
| 1625 | West37 Form/Pour Slab | 4d | 2007-03-19 | 2007-03-22 | 1620 |  |  | Carpenters [320 h] | 5 | 2007-04-18 | 5 | 2007-04-12 | 37 | Slab | W | CP | 2006-03-30 | Task | 5 | 2006-04-13 | 5 | 2006-03-21 | 2006-04-18 | 4 | 2006-03-16 | 3 | 10 |  |  |  |  |
| 2564 | East29 Affix Window Wall Frames Floors 29-32 | 6d | 2007-03-19 | 2007-03-26 | 2562, 2510, 2505, 2500, 2150, 401 |  |  | Iron Workers [288 h] | 7 | 2007-04-26 | 7 | 2007-04-18 | 31 | Frame | E | IW | 2006-04-07 | Task | 8 | 2006-06-02 | 8 | 2006-04-06 | 2006-06-09 | 6 | 2006-03-30 | 5 |  |  |  |  |  |
| 2604 | East42 Form/Pour Slab | 4d | 2007-03-19 | 2007-03-22 | 2602 |  |  | Carpenters [320 h] | 5 | 2007-04-05 | 5 | 2007-03-30 | 42 | Slab | E | CP | 2006-02-23 | Task | 5 | 2006-03-16 | 5 | 2006-03-21 | 2006-03-21 | 4 | 2006-03-16 | 3 | 10 | 24 |  |  |  |
| 22100 | East21 Layout Floor | 1d | 2007-03-19 | 2007-03-19 | 2470, 2345 |  |  | Carpenters [32 h] | 1 | 2007-06-11 | 1 | 2007-06-11 | 21 | Layout | E | CP | 2006-07-04 | Task | 1 | 2006-06-30 | 2 | 2006-03-30 | 2006-06-30 | 1 | 2006-03-30 | 1 |  |  |  |  |  |
| 22200 | East22 Layout Floor | 1d | 2007-03-19 | 2007-03-19 | 2470, 2345 |  |  | Carpenters [32 h] | 2 | 2007-06-12 | 2 | 2007-06-11 | 22 | Layout | E | CP | 2006-06-30 | Task | 1 | 2006-06-28 | 2 | 2006-06-28 | 2006-06-28 | 1 | 2006-06-28 | 1 |  | 75 |  |  |  |
| 22000 | East20 Layout Floor | 1d | 2007-03-20 | 2007-03-20 | 22100, 2470, 2345 |  |  | Carpenters [32 h] | 1 | 2007-06-12 | 1 | 2007-06-12 | 20 | Layout | E | CP | 2006-07-06 | Task | 1 | 2006-07-04 | 2 | 2006-03-31 | 2006-07-04 | 1 | 2006-03-31 | 1 |  |  |  |  |  |
| 22205 | East22 Studs & Drywall/1 | 2d | 2007-03-20 | 2007-03-21 | 22200 |  |  | Carpenters [96 h] | 2 | 2007-06-14 | 2 | 2007-06-13 | 22 | Stud | E | CP | 2006-07-05 | Task | 3 | 2006-06-29 | 3 | 2006-06-30 | 2006-06-30 | 2 | 2006-06-29 | 2 |  |  |  |  |  |
| 22210 | East22 R/I Plumbing | 2d | 2007-03-20 | 2007-03-21 | 22200 |  |  | Plumbers [64 h] | 2 | 2007-06-14 | 2 | 2007-06-13 | 22 | R/I PB | E | PB | 2006-07-05 | Task | 3 | 2006-06-30 | 3 | 2006-06-30 | 2006-07-03 | 2 | 2006-06-29 | 2 |  |  |  |  |  |
| 22215 | East22 HVAC Ductwork | 2d | 2007-03-20 | 2007-03-21 | 22200 |  |  | HVAC Sheet Metal [64 h] | 2 | 2007-06-14 | 2 | 2007-06-13 | 22 | HVAC | E | HV | 2006-07-05 | Task | 3 | 2006-07-03 | 3 | 2006-06-30 | 2006-07-04 | 2 | 2006-06-29 | 2 |  |  |  |  |  |
| 2165 | EastRF Roofing | 10d | 2007-03-21 | 2007-04-03 | 2545, 2160 |  |  | Roofers [480 h] | 12 | 2007-04-16 | 12 | 2007-03-30 | RF | Site | E |  | 2006-02-21 | Task | 13 | 2006-08-28 | 13 | 2006-03-31 | 2006-09-08 | 10 | 2006-03-20 | 8 |  |  |  |  |  |
| 2235 | Skybridge Affix Window Wall Frames | 15d | 2007-03-21 | 2007-04-10 | E006 FF, 2220, 2210, 401 |  |  | Iron Workers [720 h] | 15 | 2007-06-06 | 15 | 2007-04-03 | 20 | Frame | E | IW |  |  |  |  |  |  |  |  |  |  |  | 86 |  |  | 6 |
| 21900 | East19 Layout Floor | 1d | 2007-03-21 | 2007-03-21 | 22000, 2470, 2345 |  |  | Carpenters [32 h] | 1 | 2007-06-13 | 1 | 2007-06-13 | 19 | Layout | E | CP | 2006-07-10 | Task | 1 | 2006-07-06 | 2 | 2006-04-03 | 2006-07-06 | 1 | 2006-04-03 | 1 |  |  |  |  |  |
| 21800 | East18 Layout Floor | 1d | 2007-03-22 | 2007-03-22 | 21900, 2470, 2345 |  |  | Carpenters [32 h] | 2 | 2007-06-15 | 2 | 2007-06-14 | 18 | Layout | E | CP | 2006-07-12 | Task | 1 | 2006-07-10 | 2 | 2006-04-04 | 2006-07-10 | 1 | 2006-04-04 | 1 |  |  |  |  |  |
| 22105 | East21 Studs & Drywall/1 | 2d | 2007-03-22 | 2007-03-23 | 22205, 22100 |  |  | Carpenters [96 h] | 2 | 2007-06-18 | 2 | 2007-06-15 | 21 | Stud | E | CP | 2006-07-10 | Task | 3 | 2006-07-03 | 3 | 2006-07-04 | 2006-07-04 | 2 | 2006-07-03 | 2 |  |  |  |  |  |
| 22110 | East21 R/I Plumbing | 2d | 2007-03-22 | 2007-03-23 | 22210, 22100 |  |  | Plumbers [64 h] | 2 | 2007-06-18 | 2 | 2007-06-15 | 21 | R/I PB | E | PB | 2006-07-10 | Task | 3 | 2006-07-04 | 3 | 2006-07-04 | 2006-07-05 | 2 | 2006-07-03 | 2 |  |  |  |  |  |
| 22115 | East21 HVAC Ductwork | 2d | 2007-03-22 | 2007-03-23 | 22215, 22100 |  |  | HVAC Sheet Metal [64 h] | 2 | 2007-06-18 | 2 | 2007-06-15 | 21 | HVAC | E | HV | 2006-07-10 | Task | 3 | 2006-07-05 | 3 | 2006-07-04 | 2006-07-06 | 2 | 2006-07-03 | 2 |  |  |  |  |  |
| 22220 | East22 R/I Electric | 2d | 2007-03-22 | 2007-03-23 | 22205 |  |  | Electricians [64 h] | 2 | 2007-06-18 | 2 | 2007-06-15 | 22 | R/I Elec | E | EL | 2006-07-10 | Task | 3 | 2006-08-30 | 3 | 2006-07-04 | 2006-08-31 | 2 | 2006-07-03 | 2 |  |  |  |  |  |
| 22225 | East22 Plumbing Test | 1d | 2007-03-22 | 2007-03-22 | 22210 |  |  | Plumbers [16 h] | 1 | 2007-06-15 | 1 | 2007-06-15 | 22 | PB Test | E | PB | 2006-07-07 | Task | 1 | 2006-08-31 | 2 | 2006-07-03 | 2006-08-31 | 1 | 2006-07-03 | 1 |  |  |  |  |  |
| 1630 | West36 Form/Pour Slab | 4d | 2007-03-23 | 2007-03-28 | 1625 |  |  | Carpenters [320 h] | 4 | 2007-04-24 | 4 | 2007-04-19 | 36 | Slab | W | CP | 2006-04-06 | Task | 5 | 2006-04-19 | 5 | 2006-03-27 | 2006-04-24 | 4 | 2006-03-22 | 3 | 10 |  |  |  |  |
| 2605 | East41 Form/Pour Slab | 4d | 2007-03-23 | 2007-03-28 | 2604 |  |  | Carpenters [320 h] | 5 | 2007-04-12 | 5 | 2007-04-06 | 41 | Slab | E | CP | 2006-03-02 | Task | 5 | 2006-03-22 | 5 | 2006-03-27 | 2006-03-27 | 4 | 2006-03-22 | 3 | 10 | 24 |  |  |  |
| 21700 | East17 Layout Floor | 1d | 2007-03-23 | 2007-03-23 | 21800, 2470, 2345 |  |  | Carpenters [32 h] | 1 | 2007-06-18 | 1 | 2007-06-18 | 17 | Layout | E | CP | 2006-07-14 | Task | 1 | 2006-07-12 | 2 | 2006-04-05 | 2006-07-12 | 1 | 2006-04-05 | 1 |  |  |  |  |  |
| 21600 | East16 Layout Floor | 1d | 2007-03-26 | 2007-03-26 | 21700, 2470, 2345 |  |  | Carpenters [32 h] | 2 | 2007-06-20 | 2 | 2007-06-19 | 16 | Layout | E | CP | 2006-07-18 | Task | 1 | 2006-07-14 | 2 | 2006-04-06 | 2006-07-14 | 1 | 2006-04-06 | 1 |  |  |  |  |  |
| 22005 | East20 Studs & Drywall/1 | 2d | 2007-03-26 | 2007-03-27 | 22105, 22000 |  |  | Carpenters [96 h] | 1 | 2007-06-19 | 1 | 2007-06-19 | 20 | Stud | E | CP | 2006-07-13 | Task | 3 | 2006-07-05 | 3 | 2006-07-06 | 2006-07-06 | 2 | 2006-07-05 | 2 |  |  |  |  |  |
| 22010 | East20 R/I Plumbing | 2d | 2007-03-26 | 2007-03-27 | 22110, 22000 |  |  | Plumbers [64 h] | 2 | 2007-06-20 | 2 | 2007-06-19 | 20 | R/I PB | E | PB | 2006-07-13 | Task | 3 | 2006-07-06 | 3 | 2006-07-06 | 2006-07-07 | 2 | 2006-07-05 | 2 |  |  |  |  |  |
| 22015 | East20 HVAC Ductwork | 2d | 2007-03-26 | 2007-03-27 | 22115, 22000 |  |  | HVAC Sheet Metal [64 h] | 2 | 2007-06-20 | 2 | 2007-06-19 | 20 | HVAC | E | HV | 2006-07-13 | Task | 3 | 2006-07-07 | 3 | 2006-07-06 | 2006-07-10 | 2 | 2006-07-05 | 2 |  |  |  |  |  |
| 22120 | East21 R/I Electric | 2d | 2007-03-26 | 2007-03-27 | 22105 |  |  | Electricians [64 h] | 2 | 2007-06-20 | 2 | 2007-06-19 | 21 | R/I Elec | E | EL | 2006-07-13 | Task | 3 | 2006-08-30 | 3 | 2006-07-06 | 2006-08-31 | 2 | 2006-07-05 | 2 |  |  |  |  |  |
| 22125 | East21 Plumbing Test | 1d | 2007-03-26 | 2007-03-26 | 22110 |  |  | Plumbers [16 h] | 1 | 2007-06-19 | 1 | 2007-06-19 | 21 | PB Test | E | PB | 2006-07-12 | Task | 1 | 2006-08-31 | 2 | 2006-07-05 | 2006-08-31 | 1 | 2006-07-05 | 1 |  |  |  |  |  |
| 22230 | East22 Drywall/2 & Finishes | 2d | 2007-03-26 | 2007-03-27 | 22225, 22220, 22215 |  |  | Carpenters [96 h] | 2 | 2007-06-20 | 2 | 2007-06-19 | 22 | Drywall | E | CP | 2006-07-13 | Task | 3 | 2006-09-01 | 3 | 2006-07-06 | 2006-09-04 | 2 | 2006-07-05 | 2 |  |  |  |  |  |
| 21500 | East15 Layout Floor | 1d | 2007-03-27 | 2007-03-27 | 21600, 2470, 2345 |  |  | Carpenters [32 h] | 1 | 2007-06-21 | 1 | 2007-06-21 | 15 | Layout | E | CP | 2006-07-20 | Task | 1 | 2006-07-18 | 2 | 2006-04-07 | 2006-07-18 | 1 | 2006-04-07 | 1 |  |  |  |  |  |
| 21400 | East14 Layout Floor | 1d | 2007-03-28 | 2007-03-28 | 21500, 2470, 2345 |  |  | Carpenters [32 h] | 2 | 2007-06-25 | 2 | 2007-06-22 | 14 | Layout | E | CP | 2006-07-24 | Task | 1 | 2006-07-20 | 2 | 2006-04-10 | 2006-07-20 | 1 | 2006-04-10 | 1 |  |  |  |  |  |
| 21905 | East19 Studs & Drywall/1 | 2d | 2007-03-28 | 2007-03-29 | 22005, 21900 |  |  | Carpenters [96 h] | 2 | 2007-06-21 | 2 | 2007-06-20 | 19 | Stud | E | CP | 2006-07-18 | Task | 3 | 2006-07-07 | 3 | 2006-07-10 | 2006-07-10 | 2 | 2006-07-07 | 2 |  |  |  |  |  |
| 21910 | East19 R/I Plumbing | 2d | 2007-03-28 | 2007-03-29 | 22010, 21900 |  |  | Plumbers [64 h] | 2 | 2007-06-22 | 2 | 2007-06-21 | 19 | R/I PB | E | PB | 2006-07-18 | Task | 3 | 2006-07-10 | 3 | 2006-07-10 | 2006-07-11 | 2 | 2006-07-07 | 2 |  |  |  |  |  |
| 21915 | East19 HVAC Ductwork | 2d | 2007-03-28 | 2007-03-29 | 22015, 21900 |  |  | HVAC Sheet Metal [64 h] | 3 | 2007-06-25 | 3 | 2007-06-21 | 19 | HVAC | E | HV | 2006-07-18 | Task | 3 | 2006-07-11 | 3 | 2006-07-10 | 2006-07-12 | 2 | 2006-07-07 | 2 |  |  |  |  |  |
| 22020 | East20 R/I Electric | 2d | 2007-03-28 | 2007-03-29 | 22005 |  |  | Electricians [64 h] | 2 | 2007-06-21 | 2 | 2007-06-20 | 20 | R/I Elec | E | EL | 2006-07-18 | Task | 3 | 2006-08-30 | 3 | 2006-07-10 | 2006-08-31 | 2 | 2006-07-07 | 2 |  |  |  |  |  |
| 22025 | East20 Plumbing Test | 1d | 2007-03-28 | 2007-03-28 | 22010 |  |  | Plumbers [16 h] | 1 | 2007-06-21 | 1 | 2007-06-21 | 20 | PB Test | E | PB | 2006-07-17 | Task | 1 | 2006-08-31 | 2 | 2006-07-07 | 2006-08-31 | 1 | 2006-07-07 | 1 |  |  |  |  |  |
| 22130 | East21 Drywall/2 & Finishes | 2d | 2007-03-28 | 2007-03-29 | 22125, 22120, 22115 |  |  | Carpenters [96 h] | 3 | 2007-06-25 | 3 | 2007-06-21 | 21 | Drywall | E | CP | 2006-07-18 | Task | 3 | 2006-09-01 | 3 | 2006-07-10 | 2006-09-04 | 2 | 2006-07-07 | 2 |  |  |  |  |  |
| 22235 | East22 Electric Fixtures | 2d | 2007-03-28 | 2007-03-29 | 22230 |  |  | Electricians [32 h] | 2 | 2007-06-22 | 2 | 2007-06-21 | 22 | Elec Fixt | E | EL | 2006-07-18 | Task | 3 | 2006-09-05 | 3 | 2006-07-10 | 2006-09-06 | 2 | 2006-07-07 | 2 |  |  |  |  |  |
| 22240 | East22 Plumbing Fixtures | 2d | 2007-03-28 | 2007-03-29 | 22230 |  |  | Plumbers [32 h] | 2 | 2007-06-22 | 2 | 2007-06-21 | 22 | PB Fixt | E | PB | 2006-07-18 | Task | 3 | 2006-09-05 | 3 | 2006-07-10 | 2006-09-06 | 2 | 2006-07-07 | 2 |  |  |  |  |  |
| 22245 | East22 HVAC Fixtures | 1d | 2007-03-28 | 2007-03-28 | 22230 |  |  | HVAC Sheet Metal [16 h] | 1 | 2007-06-21 | 1 | 2007-06-21 | 22 | HVAC | E | HV | 2006-07-17 | Task | 1 | 2006-09-06 | 2 | 2006-07-07 | 2006-09-06 | 1 | 2006-07-07 | 1 |  |  |  |  |  |
| 1635 | West35 Form/Pour Slab | 4d | 2007-03-29 | 2007-04-03 | 1630 |  |  | Carpenters [320 h] | 4 | 2007-04-30 | 4 | 2007-04-25 | 35 | Slab | W | CP | 2006-04-13 | Task | 5 | 2006-04-25 | 5 | 2006-03-31 | 2006-04-28 | 4 | 2006-03-28 | 3 | 10 |  |  |  |  |
| 2610 | East40 Form/Pour Slab | 4d | 2007-03-29 | 2007-04-03 | 2605 |  |  | Carpenters [320 h] | 5 | 2007-04-19 | 5 | 2007-04-13 | 40 | Slab | E | CP | 2006-03-09 | Task | 5 | 2006-03-28 | 5 | 2006-03-31 | 2006-03-31 | 4 | 2006-03-28 | 3 | 10 | 24 |  |  |  |
| 21300 | East13 Layout Floor | 1d | 2007-03-29 | 2007-03-29 | 21400, 2470, 2345 |  |  | Carpenters [32 h] | 1 | 2007-06-26 | 1 | 2007-06-26 | 13 | Layout | E | CP | 2006-07-26 | Task | 1 | 2006-07-24 | 2 | 2006-04-11 | 2006-07-24 | 1 | 2006-04-11 | 1 |  |  |  |  |  |
| 21200 | East12 Layout Floor | 1d | 2007-03-30 | 2007-03-30 | 21300, 2470, 2345 |  |  | Carpenters [32 h] | 1 | 2007-06-27 | 1 | 2007-06-27 | 12 | Layout | E | CP | 2006-07-28 | Task | 1 | 2006-07-26 | 2 | 2006-04-12 | 2006-07-26 | 1 | 2006-04-12 | 1 |  |  |  |  |  |
| 21805 | East18 Studs & Drywall/1 | 2d | 2007-03-30 | 2007-04-02 | 21905, 21800 |  |  | Carpenters [96 h] | 2 | 2007-06-25 | 2 | 2007-06-22 | 18 | Stud | E | CP | 2006-07-21 | Task | 3 | 2006-07-11 | 3 | 2006-07-12 | 2006-07-12 | 2 | 2006-07-11 | 2 |  |  |  |  |  |
| 21810 | East18 R/I Plumbing | 2d | 2007-03-30 | 2007-04-02 | 21910, 21800 |  |  | Plumbers [64 h] | 2 | 2007-06-26 | 2 | 2007-06-25 | 18 | R/I PB | E | PB | 2006-07-21 | Task | 3 | 2006-07-12 | 3 | 2006-07-12 | 2006-07-13 | 2 | 2006-07-11 | 2 |  |  |  |  |  |
| 21815 | East18 HVAC Ductwork | 2d | 2007-03-30 | 2007-04-02 | 21915, 21800 |  |  | HVAC Sheet Metal [64 h] | 2 | 2007-06-27 | 2 | 2007-06-26 | 18 | HVAC | E | HV | 2006-07-21 | Task | 3 | 2006-07-13 | 3 | 2006-07-12 | 2006-07-14 | 2 | 2006-07-11 | 2 |  |  |  |  |  |
| 21920 | East19 R/I Electric | 2d | 2007-03-30 | 2007-04-02 | 21905 |  |  | Electricians [64 h] | 2 | 2007-06-25 | 2 | 2007-06-22 | 19 | R/I Elec | E | EL | 2006-07-21 | Task | 3 | 2006-08-30 | 3 | 2006-07-12 | 2006-08-31 | 2 | 2006-07-11 | 2 |  |  |  |  |  |
| 21925 | East19 Plumbing Test | 1d | 2007-03-30 | 2007-03-30 | 21910 |  |  | Plumbers [16 h] | 1 | 2007-06-25 | 1 | 2007-06-25 | 19 | PB Test | E | PB | 2006-07-20 | Task | 1 | 2006-08-31 | 2 | 2006-07-11 | 2006-08-31 | 1 | 2006-07-11 | 1 |  |  |  |  |  |
| 22030 | East20 Drywall/2 & Finishes | 2d | 2007-03-30 | 2007-04-02 | 22025, 22020, 22015 |  |  | Carpenters [96 h] | 2 | 2007-06-25 | 2 | 2007-06-22 | 20 | Drywall | E | CP | 2006-07-21 | Task | 3 | 2006-09-01 | 3 | 2006-07-12 | 2006-09-04 | 2 | 2006-07-11 | 2 |  |  |  |  |  |
| 22135 | East21 Electric Fixtures | 2d | 2007-03-30 | 2007-04-02 | 22130 |  |  | Electricians [32 h] | 2 | 2007-06-27 | 2 | 2007-06-26 | 21 | Elec Fixt | E | EL | 2006-07-21 | Task | 3 | 2006-09-05 | 3 | 2006-07-12 | 2006-09-06 | 2 | 2006-07-11 | 2 |  |  |  |  |  |
| 22140 | East21 Plumbing Fixtures | 2d | 2007-03-30 | 2007-04-02 | 22130 |  |  | Plumbers [32 h] | 2 | 2007-06-27 | 2 | 2007-06-26 | 21 | PB Fixt | E | PB | 2006-07-21 | Task | 3 | 2006-09-05 | 3 | 2006-07-12 | 2006-09-06 | 2 | 2006-07-11 | 2 |  |  |  |  |  |
| 22145 | East21 HVAC Fixtures | 1d | 2007-03-30 | 2007-03-30 | 22130 |  |  | HVAC Sheet Metal [16 h] | 1 | 2007-06-26 | 1 | 2007-06-26 | 21 | HVAC | E | HV | 2006-07-20 | Task | 1 | 2006-09-06 | 2 | 2006-07-11 | 2006-09-06 | 1 | 2006-07-11 | 1 |  |  |  |  |  |
| 22250 | East22 Paint & Carpeting | 2d | 2007-03-30 | 2007-04-02 | 22245, 22240, 22235 |  |  | Subcontract Work [96 h] | 2 | 2007-06-26 | 2 | 2007-06-25 | 22 | Paint | E | SB | 2006-07-21 | Task | 3 | 2006-09-07 | 3 | 2006-07-12 | 2006-09-08 | 2 | 2006-07-11 | 2 |  |  |  |  |  |
| 21100 | East11 Layout Floor | 1d | 2007-04-02 | 2007-04-02 | 22200, 21200, 2470, 2345 |  |  | Carpenters [32 h] | 1 | 2007-06-28 | 1 | 2007-06-28 | 11 | Layout | E | CP | 2006-08-01 | Task | 1 | 2006-07-28 | 2 | 2006-04-13 | 2006-07-28 | 1 | 2006-04-13 | 1 |  |  |  |  |  |

| ID | Activity | Duration | Start | Finish | Predecessors | Resources | MEF | P3 Task Type | ADur | PESS | AFinish | Imported Late Start | MOD | Imported Early Finish | Imported Late Finish | MOST | ActDur | Imported Early Start | OPTD | AStart | LOC3 Segment | WTYP | LOC1 Tower | CRTY | LOC2 Floor | PL-1 |
| --- | --- | --- | --- | --- | --- | --- | --- | --- | --- | --- | --- | --- | --- | --- | --- | --- | --- | --- | --- | --- | --- | --- | --- | --- | --- | --- |
| 21000 | East10 Layout Floor | 1d | 2007-04-03 | 2007-04-03 | 21100, 2470 | Carpenters [32 h] | 2006-08-03 | Task | 1 | 1 | 2007-06-29 | 2006-08-01 | 2 | 2006-04-14 | 2006-08-01 | 1 | 1 | 2006-04-14 | 1 | 2007-06-29 | 10 | Layout | E | CP |  |  |
| 21705 | East17 Studs & Drywall/1 | 2d | 2007-04-03 | 2007-04-04 | 21805, 21700 | Carpenters [96 h] | 2006-07-26 | Task | 1 | 3 | 2007-06-26 | 2006-07-13 | 3 | 2006-07-14 | 2006-07-14 | 2 | 1 | 2006-07-13 | 2 | 2007-06-26 |  | Stud | E | CP | 17 |  |
| 21710 | East17 R/I Plumbing | 2d | 2007-04-03 | 2007-04-04 | 21810, 21700 | Plumbers [64 h] | 2006-07-26 | Task | 2 | 3 | 2007-06-28 | 2006-07-14 | 3 | 2006-07-14 | 2006-07-17 | 2 | 2 | 2006-07-13 | 2 | 2007-06-27 |  | R/I PB | E | PB | 17 |  |
| 21715 | East17 HVAC Ductwork | 2d | 2007-04-03 | 2007-04-04 | 21815, 21700 | HVAC Sheet Metal [64 h] | 2006-07-26 | Task | 2 | 3 | 2007-06-29 | 2006-07-17 | 3 | 2006-07-14 | 2006-07-18 | 2 | 2 | 2006-07-13 | 2 | 2007-06-28 |  | HVAC | E | HV | 17 |  |
| 21820 | East18 R/I Electric | 2d | 2007-04-03 | 2007-04-04 | 21805 | Electricians [64 h] | 2006-07-26 | Task | 1 | 3 | 2007-06-26 | 2006-08-30 | 3 | 2006-07-14 | 2006-08-31 | 2 | 1 | 2006-07-13 | 2 | 2007-06-26 |  | R/I Elec | E | EL | 18 |  |
| 21825 | East18 Plumbing Test | 1d | 2007-04-03 | 2007-04-03 | 21810 | Plumbers [16 h] | 2006-07-25 | Task | 1 | 1 | 2007-06-27 | 2006-08-31 | 2 | 2006-07-13 | 2006-08-31 | 1 | 1 | 2006-07-13 | 1 | 2007-06-27 |  | PB Test | E | PB | 18 |  |
| 21930 | East19 Drywall/2 & Finishes | 2d | 2007-04-03 | 2007-04-04 | 21925, 21920, 21915 | Carpenters [96 h] | 2006-07-26 | Task | 2 | 3 | 2007-06-27 | 2006-09-01 | 3 | 2006-07-14 | 2006-09-04 | 2 | 2 | 2006-07-13 | 2 | 2007-06-26 |  | Drywall | E | CP | 19 |  |
| 22035 | East20 Electric Fixtures | 2d | 2007-04-03 | 2007-04-04 | 22030 | Electricians [32 h] | 2006-07-26 | Task | 3 | 3 | 2007-06-28 | 2006-09-05 | 3 | 2006-07-14 | 2006-09-06 | 2 | 3 | 2006-07-13 | 2 | 2007-06-26 |  | Elec Fixt | E | EL | 20 |  |
| 22040 | East20 Plumbing Fixtures | 2d | 2007-04-03 | 2007-04-04 | 22030 | Plumbers [32 h] | 2006-07-26 | Task | 3 | 3 | 2007-06-28 | 2006-09-05 | 3 | 2006-07-14 | 2006-09-06 | 2 | 3 | 2006-07-13 | 2 | 2007-06-26 |  | PB Fixt | E | PB | 20 |  |
| 22045 | East20 HVAC Fixtures | 1d | 2007-04-03 | 2007-04-03 | 22030 | HVAC Sheet Metal [16 h] | 2006-07-25 | Task | 1 | 1 | 2007-06-26 | 2006-09-06 | 2 | 2006-07-13 | 2006-09-06 | 1 | 1 | 2006-07-13 | 1 | 2007-06-26 |  | HVAC | E | HV | 20 |  |
| 22150 | East21 Paint & Carpeting | 2d | 2007-04-03 | 2007-04-04 | 22145, 22140, 22135 | Subcontract Work [96 h] | 2006-07-26 | Task | 3 | 3 | 2007-07-02 | 2006-09-07 | 3 | 2006-07-14 | 2006-09-08 | 2 | 3 | 2006-07-13 | 2 | 2007-06-28 |  | Paint | E | SB | 21 |  |
| 1640 | West34 Form/Pour Slab | 4d | 2007-04-04 | 2007-04-09 | 1635 | Carpenters [320 h] | 2006-04-20 | Task | 5 | 5 | 2007-05-07 | 2006-05-01 | 5 | 2006-04-06 | 2006-05-04 | 4 | 5 | 2006-04-03 | 3 | 2007-05-01 | 10 | Slab | W | CP | 34 |  |
| 2615 | East39 Form/Pour Slab | 4d | 2007-04-04 | 2007-04-09 | 2610 | Carpenters [320 h] | 2006-03-16 | Task | 4 | 5 | 2007-04-25 | 2006-04-03 | 5 | 2006-04-06 | 2006-04-06 | 4 | 4 | 2006-04-03 | 3 | 2007-04-20 | 10 | Slab | E | CP | 39 | 24 |
| 12200 | West22 Layout Floor | 1d | 2007-04-04 | 2007-04-04 | 1470, 1350 | Carpenters [32 h] | 2006-06-13 | Task | 1 | 1 | 2007-07-13 | 2006-06-28 | 2 | 2006-05-31 | 2006-06-28 | 1 | 1 | 2006-05-31 | 1 | 2007-07-13 |  | Layout | W | CP | 22 | 75 |
| 20900 | East09 Layout Floor | 1d | 2007-04-04 | 2007-04-04 | 21000, 2470, 2340 | Carpenters [32 h] | 2006-08-07 | Task | 1 | 1 | 2007-07-02 | 2006-08-03 | 2 | 2006-04-17 | 2006-08-03 | 1 | 1 | 2006-04-17 | 1 | 2007-07-02 |  | Layout | E | CP | 09 |  |
| 12100 | West21 Layout Floor | 1d | 2007-04-05 | 2007-04-05 | 12200, 1470, 1350 | Carpenters [32 h] | 2006-06-15 | Task | 1 | 1 | 2007-07-16 | 2006-06-30 | 2 | 2006-06-01 | 2006-06-30 | 1 | 1 | 2006-06-01 | 1 | 2007-07-16 |  | Layout | W | CP | 21 |  |
| 12205 | West22 Studs & Drywall/1 | 2d | 2007-04-05 | 2007-04-06 | 12200 | Carpenters [96 h] | 2006-06-16 | Task | 2 | 3 | 2007-07-17 | 2006-06-29 | 3 | 2006-06-02 | 2006-06-30 | 2 | 2 | 2006-06-01 | 2 | 2007-07-16 |  | Stud | W | CP | 22 |  |
| 12210 | West22 R/I Plumbing | 2d | 2007-04-05 | 2007-04-06 | 12200 | Plumbers [64 h] | 2006-06-16 | Task | 3 | 3 | 2007-07-18 | 2006-06-30 | 3 | 2006-06-02 | 2006-07-03 | 2 | 3 | 2006-06-01 | 2 | 2007-07-16 |  | R/I PB | W | PB | 22 |  |
| 12215 | West22 HVAC Ductwork | 2d | 2007-04-05 | 2007-04-06 | 12200 | HVAC Sheet Metal [64 h] | 2006-06-16 | Task | 1 | 3 | 2007-07-16 | 2006-07-03 | 3 | 2006-06-02 | 2006-07-04 | 2 | 1 | 2006-06-01 | 2 | 2007-07-16 |  | HVAC | W | HV | 22 |  |
| 20800 | East08 Layout Floor | 1d | 2007-04-05 | 2007-04-05 | 20900, 2470, 2340 | Carpenters [32 h] | 2006-08-09 | Task | 1 | 1 | 2007-07-03 | 2006-08-07 | 2 | 2006-04-18 | 2006-08-07 | 1 | 1 | 2006-04-18 | 1 | 2007-07-03 |  | Layout | E | CP | 08 |  |
| 21605 | East16 Studs & Drywall/1 | 2d | 2007-04-05 | 2007-04-06 | 21705, 21600 | Carpenters [96 h] | 2006-07-31 | Task | 2 | 3 | 2007-06-28 | 2006-07-17 | 3 | 2006-07-18 | 2006-07-18 | 2 | 2 | 2006-07-17 | 2 | 2007-06-27 |  | Stud | E | CP | 16 |  |
| 21610 | East16 R/I Plumbing | 2d | 2007-04-05 | 2007-04-06 | 21710, 21600 | Plumbers [64 h] | 2006-07-31 | Task | 2 | 3 | 2007-07-02 | 2006-07-18 | 3 | 2006-07-18 | 2006-07-19 | 2 | 2 | 2006-07-17 | 2 | 2007-06-29 |  | R/I PB | E | PB | 16 |  |
| 21615 | East16 HVAC Ductwork | 2d | 2007-04-05 | 2007-04-06 | 21715, 21600 | HVAC Sheet Metal [64 h] | 2006-07-31 | Task | 2 | 3 | 2007-07-03 | 2006-07-19 | 3 | 2006-07-18 | 2006-07-20 | 2 | 2 | 2006-07-17 | 2 | 2007-07-02 |  | HVAC | E | HV | 16 |  |
| 21720 | East17 R/I Electric | 2d | 2007-04-05 | 2007-04-06 | 21705 | Electricians [64 h] | 2006-07-31 | Task | 1 | 3 | 2007-06-27 | 2006-08-30 | 3 | 2006-07-18 | 2006-08-31 | 2 | 1 | 2006-07-17 | 2 | 2007-06-27 |  | R/I Elec | E | EL | 17 |  |
| 21725 | East17 Plumbing Test | 1d | 2007-04-05 | 2007-04-05 | 21710 | Plumbers [16 h] | 2006-07-28 | Task | 1 | 1 | 2007-06-29 | 2006-08-31 | 2 | 2006-07-17 | 2006-08-31 | 1 | 1 | 2006-07-17 | 1 | 2007-06-29 |  | PB Test | E | PB | 17 |  |
| 21830 | East18 Drywall/2 & Finishes | 2d | 2007-04-05 | 2007-04-06 | 21825, 21820, 21815 | Carpenters [96 h] | 2006-07-31 | Task | 1 | 3 | 2007-06-28 | 2006-09-01 | 3 | 2006-07-18 | 2006-09-04 | 2 | 1 | 2006-07-17 | 2 | 2007-06-28 |  | Drywall | E | CP | 18 |  |
| 21935 | East19 Electric Fixtures | 2d | 2007-04-05 | 2007-04-06 | 21930 | Electricians [32 h] | 2006-07-31 | Task | 2 | 3 | 2007-06-29 | 2006-09-05 | 3 | 2006-07-18 | 2006-09-06 | 2 | 2 | 2006-07-17 | 2 | 2007-06-28 |  | Elec Fixt | E | EL | 19 |  |
| 21940 | East19 Plumbing Fixtures | 2d | 2007-04-05 | 2007-04-06 | 21930 | Plumbers [32 h] | 2006-07-31 | Task | 2 | 3 | 2007-06-29 | 2006-09-05 | 3 | 2006-07-18 | 2006-09-06 | 2 | 2 | 2006-07-17 | 2 | 2007-06-28 |  | PB Fixt | E | PB | 19 |  |
| 21945 | East19 HVAC Fixtures | 1d | 2007-04-05 | 2007-04-05 | 21930 | HVAC Sheet Metal [16 h] | 2006-07-28 | Task | 1 | 1 | 2007-06-28 | 2006-09-06 | 2 | 2006-07-17 | 2006-09-06 | 1 | 1 | 2006-07-17 | 1 | 2007-06-28 |  | HVAC | E | HV | 19 |  |
| 22050 | East20 Paint & Carpeting | 2d | 2007-04-05 | 2007-04-06 | 22045, 22040, 22035 | Subcontract Work [96 h] | 2006-07-31 | Task | 2 | 3 | 2007-07-02 | 2006-09-07 | 3 | 2006-07-18 | 2006-09-08 | 2 | 2 | 2006-07-17 | 2 | 2007-06-29 |  | Paint | E | SB | 20 |  |
| 12000 | West20 Layout Floor | 1d | 2007-04-06 | 2007-04-06 | 12100, 1470, 1350 | Carpenters [32 h] | 2006-06-19 | Task | 1 | 1 | 2007-07-17 | 2006-07-04 | 2 | 2006-06-02 | 2006-07-04 | 1 | 1 | 2006-06-02 | 1 | 2007-07-17 |  | Layout | W | CP | 20 |  |
| 20700 | East07 Layout Floor | 1d | 2007-04-06 | 2007-04-06 | 20800, 2470, 2340 | Carpenters [32 h] | 2006-08-11 | Task | 1 | 1 | 2007-07-04 | 2006-08-09 | 2 | 2006-04-19 | 2006-08-09 | 1 | 1 | 2006-04-19 | 1 | 2007-07-04 |  | Layout | E | CP | 07 |  |
| 11900 | West19 Layout Floor | 1d | 2007-04-09 | 2007-04-09 | 12000, 1470, 1350 | Carpenters [32 h] | 2006-06-21 | Task | 1 | 1 | 2007-07-18 | 2006-07-06 | 2 | 2006-06-05 | 2006-07-06 | 1 | 1 | 2006-06-05 | 1 | 2007-07-18 |  | Layout | W | CP | 19 |  |
| 12105 | West21 Studs & Drywall/1 | 2d | 2007-04-09 | 2007-04-10 | 12205, 12100 | Carpenters [96 h] | 2006-06-21 | Task | 2 | 3 | 2007-07-19 | 2006-07-03 | 3 | 2006-06-06 | 2006-07-04 | 2 | 2 | 2006-06-05 | 2 | 2007-07-18 |  | Stud | W | CP | 21 |  |
| 12110 | West21 R/I Plumbing | 2d | 2007-04-09 | 2007-04-10 | 12210, 12100 | Plumbers [64 h] | 2006-06-21 | Task | 1 | 3 | 2007-07-19 | 2006-07-04 | 3 | 2006-06-06 | 2006-07-05 | 2 | 1 | 2006-06-05 | 2 | 2007-07-19 |  | R/I PB | W | PB | 21 |  |
| 12115 | West21 HVAC Ductwork | 2d | 2007-04-09 | 2007-04-10 | 12215, 12100 | HVAC Sheet Metal [64 h] | 2006-06-21 | Task | 2 | 3 | 2007-07-18 | 2006-07-05 | 3 | 2006-06-06 | 2006-07-06 | 2 | 2 | 2006-06-05 | 2 | 2007-07-17 |  | HVAC | W | HV | 21 |  |
| 12220 | West22 R/I Electric | 2d | 2007-04-09 | 2007-04-10 | 12205 | Electricians [64 h] | 2006-06-21 | Task | 1 | 3 | 2007-07-18 | 2006-08-30 | 3 | 2006-06-06 | 2006-08-31 | 2 | 1 | 2006-06-05 | 2 | 2007-07-18 |  | R/I Elec | W | EL | 22 |  |
| 12225 | West22 Plumbing Test | 1d | 2007-04-09 | 2007-04-09 | 12210 | Plumbers [16 h] | 2006-06-20 | Task | 1 | 1 | 2007-07-19 | 2006-08-31 | 2 | 2006-06-05 | 2006-08-31 | 1 | 1 | 2006-06-05 | 1 | 2007-07-19 |  | PB Test | W | PB | 22 |  |
| 20600 | East06 Layout Floor | 1d | 2007-04-09 | 2007-04-09 | 20700, 2470, 2340 | Carpenters [32 h] | 2006-08-15 | Task | 1 | 1 | 2007-07-05 | 2006-08-11 | 2 | 2006-04-20 | 2006-08-11 | 1 | 1 | 2006-04-20 | 1 | 2007-07-05 |  | Layout | E | CP | 06 |  |
| 21505 | East15 Studs & Drywall/1 | 2d | 2007-04-09 | 2007-04-10 | 21605, 21500 | Carpenters [96 h] | 2006-08-03 | Task | 3 | 3 | 2007-07-03 | 2006-07-19 | 3 | 2006-07-20 | 2006-07-20 | 2 | 3 | 2006-07-19 | 2 | 2007-06-29 |  | Stud | E | CP | 15 |  |
| 21510 | East15 R/I Plumbing | 2d | 2007-04-09 | 2007-04-10 | 21610, 21500 | Plumbers [64 h] | 2006-08-03 | Task | 2 | 3 | 2007-07-04 | 2006-07-20 | 3 | 2006-07-20 | 2006-07-21 | 2 | 2 | 2006-07-19 | 2 | 2007-07-03 |  | R/I PB | E | PB | 15 |  |
| 21515 | East15 HVAC Ductwork | 2d | 2007-04-09 | 2007-04-10 | 21615, 21500 | HVAC Sheet Metal [64 h] | 2006-08-03 | Task | 1 | 3 | 2007-07-04 | 2006-07-21 | 3 | 2006-07-20 | 2006-07-24 | 2 | 1 | 2006-07-19 | 2 | 2007-07-04 |  | HVAC | E | HV | 15 |  |
| 21620 | East16 R/I Electric | 2d | 2007-04-09 | 2007-04-10 | 21605 | Electricians [64 h] | 2006-08-03 | Task | 1 | 3 | 2007-06-29 | 2006-08-30 | 3 | 2006-07-20 | 2006-08-31 | 2 | 1 | 2006-07-19 | 2 | 2007-06-29 |  | R/I Elec | E | EL | 16 |  |
| 21625 | East16 Plumbing Test | 1d | 2007-04-09 | 2007-04-09 | 21610 | Plumbers [16 h] | 2006-08-02 | Task | 1 | 1 | 2007-07-03 | 2006-08-31 | 2 | 2006-07-19 | 2006-08-31 | 1 | 1 | 2006-07-19 | 1 | 2007-07-03 |  | PB Test | E | PB | 16 |  |
| 21730 | East17 Drywall/2 & Finishes | 2d | 2007-04-09 | 2007-04-10 | 21725, 21720, 21715 | Carpenters [96 h] | 2006-08-03 | Task | 2 | 3 | 2007-07-03 | 2006-09-01 | 3 | 2006-07-20 | 2006-09-04 | 2 | 2 | 2006-07-19 | 2 | 2007-07-02 |  | Drywall | E | CP | 17 |  |
| 21835 | East18 Electric Fixtures | 2d | 2007-04-09 | 2007-04-10 | 21830 | Electricians [32 h] | 2006-08-03 | Task | 2 | 3 | 2007-07-02 | 2006-09-05 | 3 | 2006-07-20 | 2006-09-06 | 2 | 2 | 2006-07-19 | 2 | 2007-06-29 |  | Elec Fixt | E | EL | 18 |  |
| 21840 | East18 Plumbing Fixtures | 2d | 2007-04-09 | 2007-04-10 | 21830 | Plumbers [32 h] | 2006-08-03 | Task | 2 | 3 | 2007-07-02 | 2006-09-05 | 3 | 2006-07-20 | 2006-09-06 | 2 | 2 | 2006-07-19 | 2 | 2007-06-29 |  | PB Fixt | E | PB | 18 |  |
| 21845 | East18 HVAC Fixtures | 1d | 2007-04-09 | 2007-04-09 | 21830 | HVAC Sheet Metal [16 h] | 2006-08-02 | Task | 1 | 1 | 2007-06-29 | 2006-09-06 | 2 | 2006-07-19 | 2006-09-06 | 1 | 1 | 2006-07-19 | 1 | 2007-06-29 |  | HVAC | E | HV | 18 |  |
| 21950 | East19 Paint & Carpeting | 2d | 2007-04-09 | 2007-04-10 | 21945, 21940, 21935 | Subcontract Work [96 h] | 2006-08-03 | Task | 2 | 3 | 2007-07-03 | 2006-09-07 | 3 | 2006-07-20 | 2006-09-08 | 2 | 2 | 2006-07-19 | 2 | 2007-07-02 |  | Paint | E | SB | 19 |  |
| 1645 | West33 Form/Pour Slab | 4d | 2007-04-10 | 2007-04-13 | 1640 | Carpenters [320 h] | 2006-04-27 | Task | 4 | 5 | 2007-05-11 | 2006-05-05 | 5 | 2006-04-12 | 2006-05-10 | 4 | 4 | 2006-04-07 | 3 | 2007-05-08 | 10 | Slab | W | CP | 33 |  |
| 2620 | East38 Form/Pour Slab | 4d | 2007-04-10 | 2007-04-13 | 2615 | Carpenters [320 h] | 2006-03-23 | Task | 5 | 5 | 2007-05-02 | 2006-04-07 | 5 | 2006-04-12 | 2006-04-12 | 4 | 5 | 2006-04-07 | 3 | 2007-04-26 | 10 | Slab | E | CP | 38 | 24 |
| 11800 | West18 Layout Floor | 1d | 2007-04-10 | 2007-04-10 | 11900, 1470, 1350 | Carpenters [32 h] | 2006-06-23 | Task | 1 | 1 | 2007-07-19 | 2006-07-10 | 2 | 2006-06-06 | 2006-07-10 | 1 | 1 | 2006-06-06 | 1 | 2007-07-19 |  | Layout | W | CP | 18 |  |
| 20500 | East05 Layout Floor | 1d | 2007-04-10 | 2007-04-10 | 20600, 2470, 2340 | Carpenters [32 h] | 2006-08-17 | Task | 1 | 1 | 2007-07-06 | 2006-08-15 | 2 | 2006-04-21 | 2006-08-15 | 1 | 1 | 2006-04-21 | 1 | 2007-07-06 |  | Layout | E | CP | 05 |  |
| 304 | Window Wall Units - Fabricate/Deliver Skybridge | 30d | 2007-04-11 | 2007-05-22 | E006 FS+30d, 2235, 303 SS, 303 SF |  |  |  | 30 |  | 2007-08-29 |  |  |  |  |  | 30 |  |  | 2007-07-19 |  | Window | S |  | G0 | 11 |
| 11700 | West17 Layout Floor | 1d | 2007-04-11 | 2007-04-11 | 11800, 1470, 1350 | Carpenters [32 h] | 2006-06-27 | Task | 2 | 1 | 2007-07-23 | 2006-07-12 | 2 | 2006-06-07 | 2006-07-12 | 1 | 2 | 2006-06-07 | 1 | 2007-07-20 |  | Layout | W | CP | 17 |  |
| 12005 | West20 Studs & Drywall/1 | 2d | 2007-04-11 | 2007-04-12 | 12105, 12000 | Carpenters [96 h] | 2006-06-26 | Task | 3 | 3 | 2007-07-24 | 2006-07-05 | 3 | 2006-06-08 | 2006-07-06 | 2 | 3 | 2006-06-07 | 2 | 2007-07-20 |  | Stud | W | CP | 20 |  |
| 12010 | West20 R/I Plumbing | 2d | 2007-04-11 | 2007-04-12 | 12110, 12000 | Plumbers [64 h] | 2006-06-26 | Task | 2 | 3 | 2007-07-23 | 2006-07-06 | 3 | 2006-06-08 | 2006-07-07 | 2 | 2 | 2006-06-07 | 2 | 2007-07-20 |  | R/I PB | W | PB | 20 |  |
| 12015 | West20 HVAC Ductwork | 2d | 2007-04-11 | 2007-04-12 | 12115, 12000 | HVAC Sheet Metal [64 h] | 2006-06-26 | Task | 2 | 3 | 2007-07-20 | 2006-07-07 | 3 | 2006-06-08 | 2006-07-10 | 2 | 2 | 2006-06-07 | 2 | 2007-07-19 |  | HVAC | W | HV | 20 |  |
| 12120 | West21 R/I Electric | 2d | 2007-04-11 | 2007-04-12 | 12105 | Electricians [64 h] | 2006-06-26 | Task | 2 | 3 | 2007-07-23 | 2006-08-30 | 3 | 2006-06-08 | 2006-08-31 | 2 | 2 | 2006-06-07 | 2 | 2007-07-20 |  | R/I Elec | W | EL | 21 |  |
| 12125 | West21 Plumbing Test | 1d | 2007-04-11 | 2007-04-11 | 12110 | Plumbers [16 h] | 2006-06-23 | Task | 2 | 1 | 2007-07-23 | 2006-08-31 | 2 | 2006-06-07 | 2006-08-31 | 1 | 2 | 2006-06-07 | 1 | 2007-07-20 |  | PB Test | W | PB | 21 |  |
| 12230 | West22 Drywall/2 & Finishes | 2d | 2007-04-11 | 2007-04-12 | 12225, 12220, 12215 | Carpenters [96 h] | 2006-06-26 | Task | 2 | 3 | 2007-07-23 | 2006-09-01 | 3 | 2006-06-08 | 2006-09-04 | 2 | 2 | 2006-06-07 | 2 | 2007-07-20 |  | Drywall | W | CP | 22 |  |
| 20400 | East04 Layout Floor | 1d | 2007-04-11 | 2007-04-11 | 20500, 2470, 2340 | Carpenters [32 h] | 2006-08-21 | Task | 1 | 1 | 2007-07-09 | 2006-08-17 | 2 | 2006-04-24 | 2006-08-17 | 1 | 1 | 2006-04-24 | 1 | 2007-07-09 |  | Layout | E | CP | 04 |  |
| 21405 | East14 Studs & Drywall/1 | 2d | 2007-04-11 | 2007-04-12 | 21505, 21400 | Carpenters [96 h] | 2006-08-08 | Task | 2 | 3 | 2007-07-05 | 2006-07-21 | 3 | 2006-07-24 | 2006-07-24 | 2 | 2 | 2006-07-21 | 2 | 2007-07-04 |  | Stud | E | CP | 14 |  |
| 21410 | East14 R/I Plumbing | 2d | 2007-04-11 | 2007-04-12 | 21510, 21400 | Plumbers [64 h] | 2006-08-08 | Task | 2 | 3 | 2007-07-06 | 2006-07-24 | 3 | 2006-07-24 | 2006-07-25 | 2 | 2 | 2006-07-21 | 2 | 2007-07-05 |  | R/I PB | E | PB | 14 |  |
| 21415 | East14 HVAC Ductwork | 2d | 2007-04-11 | 2007-04-12 | 21515, 21400 | HVAC Sheet Metal [64 h] | 2006-08-08 | Task | 3 | 3 | 2007-07-09 | 2006-07-25 | 3 | 2006-07-24 | 2006-07-26 | 2 | 3 | 2006-07-21 | 2 | 2007-07-05 |  | HVAC | E | HV | 14 |  |
| 21520 | East15 R/I Electric | 2d | 2007-04-11 | 2007-04-12 | 21505 | Electricians [64 h] | 2006-08-08 | Task | 3 | 3 | 2007-07-06 | 2006-08-30 | 3 | 2006-07-24 | 2006-08-31 | 2 | 3 | 2006-07-21 | 2 | 2007-07-04 |  | R/I Elec | E | EL | 15 |  |
| 21525 | East15 Plumbing Test | 1d | 2007-04-11 | 2007-04-11 | 21510 | Plumbers [16 h] | 2006-08-07 | Task | 1 | 1 | 2007-07-05 | 2006-08-31 | 2 | 2006-07-21 | 2006-08-31 | 1 | 1 | 2006-07-21 | 1 | 2007-07-05 |  | PB Test | E | PB | 15 |  |
| 21630 | East16 Drywall/2 & Finishes | 2d | 2007-04-11 | 2007-04-12 | 21625, 21620, 21615 | Carpenters [96 h] | 2006-08-08 | Task | 2 | 3 | 2007-07-05 | 2006-09-01 | 3 | 2006-07-24 | 2006-09-04 | 2 | 2 | 2006-07-21 | 2 | 2007-07-04 |  | Drywall | E | CP | 16 |  |
| 21735 | East17 Electric Fixtures | 2d | 2007-04-11 | 2007-04-12 | 21730 | Electricians [32 h] | 2006-08-08 | Task | 1 | 3 | 2007-07-04 | 2006-09-05 | 3 | 2006-07-24 | 2006-09-06 | 2 | 1 | 2006-07-21 | 2 | 2007-07-04 |  | Elec Fixt | E | EL | 17 |  |
| 21740 | East17 Plumbing Fixtures | 2d | 2007-04-11 | 2007-04-12 | 21730 | Plumbers [32 h] | 2006-08-08 | Task | 2 | 3 | 2007-07-05 | 2006-09-05 | 3 | 2006-07-24 | 2006-09-06 | 2 | 2 | 2006-07-21 | 2 | 2007-07-04 |  | PB Fixt | E | PB | 17 |  |

| ID | Activity | Duration | Start | Finish | Predecessors | Resources | MEF | P3 Task Type | ADur | PESS | AFinish | Imported Late Start | MOD | Imported Early Finish | Imported Late Finish | MOST | ActDur | Imported Early Start | OPTD | AStart | LOC2 Floor | WTYP | LOC1 Tower | CRTY | PL-1 | LOC3 Segment |
| --- | --- | --- | --- | --- | --- | --- | --- | --- | --- | --- | --- | --- | --- | --- | --- | --- | --- | --- | --- | --- | --- | --- | --- | --- | --- | --- |
| 21745 | East17 HVAC Fixtures | 1d | 2007-04-11 | 2007-04-11 | 21730 | HVAC Sheet Metal [16 h] | 2006-08-07 | Task | 1 | 1 | 2007-07-04 | 2006-09-06 | 2 | 2006-07-21 | 2006-09-06 | 1 | 1 | 2006-07-21 | 1 | 2007-07-04 | 17 | HVAC | E | HV |  |  |
| 21850 | East18 Paint & Carpeting | 2d | 2007-04-11 | 2007-04-12 | 21845, 21840, 21835 | Subcontract Work [96 h] | 2006-08-08 | Task | 1 | 3 | 2007-07-03 | 2006-09-07 | 3 | 2006-07-24 | 2006-09-08 | 2 | 1 | 2006-07-21 | 2 | 2007-07-03 | 18 | Paint | E | SB |  |  |
| 11600 | West16 Layout Floor | 1d | 2007-04-12 | 2007-04-12 | 11700, 1470, 1350 | Carpenters [32 h] | 2006-06-29 | Task | 2 | 1 | 2007-07-25 | 2006-07-14 | 2 | 2006-06-08 | 2006-07-14 | 1 | 2 | 2006-06-08 | 1 | 2007-07-24 | 16 | Layout | W | CP |  |  |
| 20300 | East03 Layout Floor | 1d | 2007-04-12 | 2007-04-12 | 20400, 2470, 2340 | Carpenters [32 h] | 2006-08-23 | Task | 1 | 1 | 2007-07-10 | 2006-08-21 | 2 | 2006-04-25 | 2006-08-21 | 1 | 1 | 2006-04-25 | 1 | 2007-07-10 | 03 | Layout | E | CP |  |  |
| 11500 | West15 Layout Floor | 1d | 2007-04-13 | 2007-04-13 | 11600, 1470, 1350 | Carpenters [32 h] | 2006-07-03 | Task | 1 | 1 | 2007-07-26 | 2006-07-18 | 2 | 2006-06-09 | 2006-07-18 | 1 | 1 | 2006-06-09 | 1 | 2007-07-26 | 15 | Layout | W | CP |  |  |
| 11905 | West19 Studs & Drywall/1 | 2d | 2007-04-13 | 2007-04-16 | 12005, 11900 | Carpenters [96 h] | 2006-06-29 | Task | 2 | 3 | 2007-07-26 | 2006-07-07 | 3 | 2006-06-12 | 2006-07-10 | 2 | 2 | 2006-06-09 | 2 | 2007-07-25 | 19 | Stud | W | CP |  |  |
| 11910 | West19 R/I Plumbing | 2d | 2007-04-13 | 2007-04-16 | 12010, 11900 | Plumbers [64 h] | 2006-06-29 | Task | 3 | 3 | 2007-07-26 | 2006-07-10 | 3 | 2006-06-12 | 2006-07-11 | 2 | 3 | 2006-06-09 | 2 | 2007-07-24 | 19 | R/I PB | W | PB |  |  |
| 11915 | West19 HVAC Ductwork | 2d | 2007-04-13 | 2007-04-16 | 12015, 11900 | HVAC Sheet Metal [64 h] | 2006-06-29 | Task | 2 | 3 | 2007-07-24 | 2006-07-11 | 3 | 2006-06-12 | 2006-07-12 | 2 | 2 | 2006-06-09 | 2 | 2007-07-23 | 19 | HVAC | W | HV |  |  |
| 12020 | West20 R/I Electric | 2d | 2007-04-13 | 2007-04-16 | 12005 | Electricians [64 h] | 2006-06-29 | Task | 2 | 3 | 2007-07-26 | 2006-08-30 | 3 | 2006-06-12 | 2006-08-31 | 2 | 2 | 2006-06-09 | 2 | 2007-07-25 | 20 | R/I Elec | W | EL |  |  |
| 12025 | West20 Plumbing Test | 1d | 2007-04-13 | 2007-04-13 | 12010 | Plumbers [16 h] | 2006-06-28 | Task | 1 | 1 | 2007-07-24 | 2006-08-31 | 2 | 2006-06-09 | 2006-08-31 | 1 | 1 | 2006-06-09 | 1 | 2007-07-24 | 20 | PB Test | W | PB |  |  |
| 12130 | West21 Drywall/2 & Finishes | 2d | 2007-04-13 | 2007-04-16 | 12125, 12120, 12115 | Carpenters [96 h] | 2006-06-29 | Task | 1 | 3 | 2007-07-24 | 2006-09-01 | 3 | 2006-06-12 | 2006-09-04 | 2 | 1 | 2006-06-09 | 2 | 2007-07-24 | 21 | Drywall | W | CP |  |  |
| 12235 | West22 Electric Fixtures | 2d | 2007-04-13 | 2007-04-16 | 12230 | Electricians [32 h] | 2006-06-29 | Task | 2 | 3 | 2007-07-25 | 2006-09-05 | 3 | 2006-06-12 | 2006-09-06 | 2 | 2 | 2006-06-09 | 2 | 2007-07-24 | 22 | Elec Fixt | W | EL |  |  |
| 12240 | West22 Plumbing Fixtures | 2d | 2007-04-13 | 2007-04-16 | 12230 | Plumbers [32 h] | 2006-06-29 | Task | 2 | 3 | 2007-07-25 | 2006-09-05 | 3 | 2006-06-12 | 2006-09-06 | 2 | 2 | 2006-06-09 | 2 | 2007-07-24 | 22 | PB Fixt | W | PB |  |  |
| 12245 | West22 HVAC Fixtures | 1d | 2007-04-13 | 2007-04-13 | 12230 | HVAC Sheet Metal [16 h] | 2006-06-28 | Task | 1 | 1 | 2007-07-24 | 2006-09-06 | 2 | 2006-06-09 | 2006-09-06 | 1 | 1 | 2006-06-09 | 1 | 2007-07-24 | 22 | HVAC Fixt | W | HV |  |  |
| 20200 | East02 Layout Floor | 1d | 2007-04-13 | 2007-04-13 | 20300, 2470, 2340 | Carpenters [32 h] | 2006-08-25 | Task | 2 | 1 | 2007-07-12 | 2006-08-23 | 2 | 2006-04-26 | 2006-08-23 | 1 | 2 | 2006-04-26 | 1 | 2007-07-11 | 02 | Layout | E | CP |  |  |
| 21305 | East13 Studs & Drywall/1 | 2d | 2007-04-13 | 2007-04-16 | 21405, 21300 | Carpenters [96 h] | 2006-08-11 | Task | 2 | 3 | 2007-07-09 | 2006-07-25 | 3 | 2006-07-26 | 2006-07-26 | 2 | 2 | 2006-07-25 | 2 | 2007-07-06 | 13 | Stud | E | CP |  |  |
| 21310 | East13 R/I Plumbing | 2d | 2007-04-13 | 2007-04-16 | 21410, 21300 | Plumbers [64 h] | 2006-08-11 | Task | 2 | 3 | 2007-07-10 | 2006-07-26 | 3 | 2006-07-26 | 2006-07-27 | 2 | 2 | 2006-07-25 | 2 | 2007-07-09 | 13 | R/I PB | E | PB |  |  |
| 21315 | East13 HVAC Ductwork | 2d | 2007-04-13 | 2007-04-16 | 21415, 21300 | HVAC Sheet Metal [64 h] | 2006-08-11 | Task | 2 | 3 | 2007-07-11 | 2006-07-27 | 3 | 2006-07-26 | 2006-07-28 | 2 | 2 | 2006-07-25 | 2 | 2007-07-10 | 13 | HVAC | E | HV |  |  |
| 21420 | East14 R/I Electric | 2d | 2007-04-13 | 2007-04-16 | 21405 | Electricians [64 h] | 2006-08-11 | Task | 2 | 3 | 2007-07-09 | 2006-08-30 | 3 | 2006-07-26 | 2006-08-31 | 2 | 2 | 2006-07-25 | 2 | 2007-07-06 | 14 | R/I Elec | E | EL |  |  |
| 21425 | East14 Plumbing Test | 1d | 2007-04-13 | 2007-04-13 | 21410 | Plumbers [16 h] | 2006-08-10 | Task | 1 | 1 | 2007-07-09 | 2006-08-31 | 2 | 2006-07-25 | 2006-08-31 | 1 | 1 | 2006-07-25 | 1 | 2007-07-09 | 14 | PB Test | E | PB |  |  |
| 21530 | East15 Drywall/2 & Finishes | 2d | 2007-04-13 | 2007-04-16 | 21525, 21520, 21515 | Carpenters [96 h] | 2006-08-11 | Task | 2 | 3 | 2007-07-10 | 2006-09-01 | 3 | 2006-07-26 | 2006-09-04 | 2 | 2 | 2006-07-25 | 2 | 2007-07-09 | 15 | Drywall | E | CP |  |  |
| 21635 | East16 Electric Fixtures | 2d | 2007-04-13 | 2007-04-16 | 21630 | Electricians [32 h] | 2006-08-11 | Task | 2 | 3 | 2007-07-09 | 2006-09-05 | 3 | 2006-07-26 | 2006-09-06 | 2 | 2 | 2006-07-25 | 2 | 2007-07-06 | 16 | Elec Fixt | E | EL |  |  |
| 21640 | East16 Plumbing Fixtures | 2d | 2007-04-13 | 2007-04-16 | 21630 | Plumbers [32 h] | 2006-08-11 | Task | 2 | 3 | 2007-07-09 | 2006-09-05 | 3 | 2006-07-26 | 2006-09-06 | 2 | 2 | 2006-07-25 | 2 | 2007-07-06 | 16 | PB Fixt | E | PB |  |  |
| 21645 | East16 HVAC Fixtures | 1d | 2007-04-13 | 2007-04-13 | 21630 | HVAC Sheet Metal [16 h] | 2006-08-10 | Task | 1 | 1 | 2007-07-06 | 2006-09-06 | 2 | 2006-07-25 | 2006-09-06 | 1 | 1 | 2006-07-25 | 1 | 2007-07-06 | 16 | HVAC | E | HV |  |  |
| 21750 | East17 Paint & Carpeting | 2d | 2007-04-13 | 2007-04-16 | 21745, 21740, 21735 | Subcontract Work [96 h] | 2006-08-11 | Task | 2 | 3 | 2007-07-09 | 2006-09-07 | 3 | 2006-07-26 | 2006-09-08 | 2 | 2 | 2006-07-25 | 2 | 2007-07-06 | 17 | Paint | E | SB |  |  |
| 1660 | West34 Affix Window Wall Frames Floors 32-34 | 6d | 2007-04-16 | 2007-04-23 | 1564, 1645, 1640, 1635, 1150, 401 | Iron Workers [288 h] | 2006-05-09 | Task | 6 | 8 | 2007-05-21 | 2006-05-11 | 8 | 2006-04-20 | 2006-05-18 | 6 | 6 | 2006-04-13 | 5 | 2007-05-14 | 34 | Frame | W | IW |  |  |
| 2625 | East37 Form/Pour Slab | 4d | 2007-04-16 | 2007-04-19 | 2620 | Carpenters [320 h] | 2006-03-30 | Task | 5 | 5 | 2007-05-09 | 2006-04-13 | 5 | 2006-04-18 | 2006-04-18 | 4 | 5 | 2006-04-13 | 3 | 2007-05-03 | 37 | Slab | E | CP | 24 | 10 |
| 11400 | West14 Layout Floor | 1d | 2007-04-16 | 2007-04-16 | 11500, 1470, 1350 | Carpenters [32 h] | 2006-07-05 | Task | 1 | 1 | 2007-07-27 | 2006-07-20 | 2 | 2006-06-12 | 2006-07-20 | 1 | 1 | 2006-06-12 | 1 | 2007-07-27 | 14 | Layout | W | CP |  |  |
| 20100 | EastCL Layout Floor | 1d | 2007-04-16 | 2007-04-16 | 20200, 2470, 2340 | Carpenters [32 h] | 2006-08-29 | Task | 2 | 1 | 2007-07-16 | 2006-08-25 | 2 | 2006-04-27 | 2006-08-25 | 1 | 2 | 2006-04-27 | 1 | 2007-07-13 | CL | Layout | E | CP |  |  |
| 11300 | West13 Layout Floor | 1d | 2007-04-17 | 2007-04-17 | 11400, 1470, 1350 | Carpenters [32 h] | 2006-07-07 | Task | 1 | 1 | 2007-07-30 | 2006-07-24 | 2 | 2006-06-13 | 2006-07-24 | 1 | 1 | 2006-06-13 | 1 | 2007-07-30 | 13 | Layout | W | CP |  |  |
| 11805 | West18 Studs & Drywall/1 | 2d | 2007-04-17 | 2007-04-18 | 11905, 11800 | Carpenters [96 h] | 2006-07-04 | Task | 2 | 3 | 2007-07-30 | 2006-07-11 | 3 | 2006-06-14 | 2006-07-12 | 2 | 2 | 2006-06-13 | 2 | 2007-07-27 | 18 | Stud | W | CP |  |  |
| 11810 | West18 R/I Plumbing | 2d | 2007-04-17 | 2007-04-18 | 11910, 11800 | Plumbers [64 h] | 2006-07-04 | Task | 2 | 3 | 2007-07-30 | 2006-07-12 | 3 | 2006-06-14 | 2006-07-13 | 2 | 2 | 2006-06-13 | 2 | 2007-07-27 | 18 | R/I PB | W | PB |  |  |
| 11815 | West18 HVAC Ductwork | 2d | 2007-04-17 | 2007-04-18 | 11915, 11800 | HVAC Sheet Metal [64 h] | 2006-07-04 | Task | 2 | 3 | 2007-07-26 | 2006-07-13 | 3 | 2006-06-14 | 2006-07-14 | 2 | 2 | 2006-06-13 | 2 | 2007-07-25 | 18 | HVAC | W | HV |  |  |
| 11920 | West19 R/I Electric | 2d | 2007-04-17 | 2007-04-18 | 11905 | Electricians [64 h] | 2006-07-04 | Task | 3 | 3 | 2007-07-31 | 2006-08-30 | 3 | 2006-06-14 | 2006-08-31 | 2 | 3 | 2006-06-13 | 2 | 2007-07-27 | 19 | R/I Elec | W | EL |  |  |
| 11925 | West19 Plumbing Test | 1d | 2007-04-17 | 2007-04-17 | 11910 | Plumbers [16 h] | 2006-07-03 | Task | 1 | 1 | 2007-07-27 | 2006-08-31 | 2 | 2006-06-13 | 2006-08-31 | 1 | 1 | 2006-06-13 | 1 | 2007-07-27 | 19 | PB Test | W | PB |  |  |
| 12030 | West20 Drywall/2 & Finishes | 2d | 2007-04-17 | 2007-04-18 | 12025, 12020, 12015 | Carpenters [96 h] | 2006-07-04 | Task | 3 | 3 | 2007-07-31 | 2006-09-01 | 3 | 2006-06-14 | 2006-09-04 | 2 | 3 | 2006-06-13 | 2 | 2007-07-27 | 20 | Drywall | W | CP |  |  |
| 12135 | West21 Electric Fixtures | 2d | 2007-04-17 | 2007-04-18 | 12130 | Electricians [32 h] | 2006-07-04 | Task | 2 | 3 | 2007-07-26 | 2006-09-05 | 3 | 2006-06-14 | 2006-09-06 | 2 | 2 | 2006-06-13 | 2 | 2007-07-25 | 21 | Elec Fixt | W | EL |  |  |
| 12140 | West21 Plumbing Fixtures | 2d | 2007-04-17 | 2007-04-18 | 12130 | Plumbers [32 h] | 2006-07-04 | Task | 2 | 3 | 2007-07-26 | 2006-09-05 | 3 | 2006-06-14 | 2006-09-06 | 2 | 2 | 2006-06-13 | 2 | 2007-07-25 | 21 | PB Fixt | W | PB |  |  |
| 12145 | West21 HVAC Fixtures | 1d | 2007-04-17 | 2007-04-17 | 12130 | HVAC Sheet Metal [16 h] | 2006-07-03 | Task | 1 | 1 | 2007-07-25 | 2006-09-06 | 2 | 2006-06-13 | 2006-09-06 | 1 | 1 | 2006-06-13 | 1 | 2007-07-25 | 21 | HVAC | W | HV |  |  |
| 12250 | West22 Paint & Carpeting | 2d | 2007-04-17 | 2007-04-18 | 12245, 12240, 12235 | Subcontract Work [96 h] | 2006-07-04 | Task | 2 | 3 | 2007-07-27 | 2006-09-07 | 3 | 2006-06-14 | 2006-09-08 | 2 | 2 | 2006-06-13 | 2 | 2007-07-26 | 22 | Paint | W | SB |  |  |
| 21205 | East12 Studs & Drywall/1 | 2d | 2007-04-17 | 2007-04-18 | 21305, 21200 | Carpenters [96 h] | 2006-08-16 | Task | 2 | 3 | 2007-07-11 | 2006-07-27 | 3 | 2006-07-28 | 2006-07-28 | 2 | 2 | 2006-07-27 | 2 | 2007-07-10 | 12 | Stud | E | CP |  |  |
| 21210 | East12 R/I Plumbing | 2d | 2007-04-17 | 2007-04-18 | 21310, 21200 | Plumbers [64 h] | 2006-08-16 | Task | 2 | 3 | 2007-07-12 | 2006-07-28 | 3 | 2006-07-28 | 2006-07-31 | 2 | 2 | 2006-07-27 | 2 | 2007-07-11 | 12 | R/I PB | E | PB |  |  |
| 21215 | East12 HVAC Ductwork | 2d | 2007-04-17 | 2007-04-18 | 21315, 21200 | HVAC Sheet Metal [64 h] | 2006-08-16 | Task | 3 | 3 | 2007-07-16 | 2006-07-31 | 3 | 2006-07-28 | 2006-08-01 | 2 | 3 | 2006-07-27 | 2 | 2007-07-12 | 12 | HVAC | E | HV |  |  |
| 21320 | East13 R/I Electric | 2d | 2007-04-17 | 2007-04-18 | 21305 | Electricians [64 h] | 2006-08-16 | Task | 2 | 3 | 2007-07-11 | 2006-08-30 | 3 | 2006-07-28 | 2006-08-31 | 2 | 2 | 2006-07-27 | 2 | 2007-07-10 | 13 | R/I Elec | E | EL |  |  |
| 21325 | East13 Plumbing Test | 1d | 2007-04-17 | 2007-04-17 | 21310 | Plumbers [16 h] | 2006-08-15 | Task | 1 | 1 | 2007-07-11 | 2006-08-31 | 2 | 2006-07-27 | 2006-08-31 | 1 | 1 | 2006-07-27 | 1 | 2007-07-11 | 13 | PB Test | E | PB |  |  |
| 21430 | East14 Drywall/2 & Finishes | 2d | 2007-04-17 | 2007-04-18 | 21425, 21420, 21415 | Carpenters [96 h] | 2006-08-16 | Task | 2 | 3 | 2007-07-11 | 2006-09-01 | 3 | 2006-07-28 | 2006-09-04 | 2 | 2 | 2006-07-27 | 2 | 2007-07-10 | 14 | Drywall | E | CP |  |  |
| 21535 | East15 Electric Fixtures | 2d | 2007-04-17 | 2007-04-18 | 21530 | Electricians [32 h] | 2006-08-16 | Task | 2 | 3 | 2007-07-12 | 2006-09-05 | 3 | 2006-07-28 | 2006-09-06 | 2 | 2 | 2006-07-27 | 2 | 2007-07-11 | 15 | Elec Fixt | E | EL |  |  |
| 21540 | East15 Plumbing Fixtures | 2d | 2007-04-17 | 2007-04-18 | 21530 | Plumbers [32 h] | 2006-08-16 | Task | 1 | 3 | 2007-07-11 | 2006-09-05 | 3 | 2006-07-28 | 2006-09-06 | 2 | 1 | 2006-07-27 | 2 | 2007-07-11 | 15 | PB Fixt | E | PB |  |  |
| 21545 | East15 HVAC Fixtures | 1d | 2007-04-17 | 2007-04-17 | 21530 | HVAC Sheet Metal [16 h] | 2006-08-15 | Task | 1 | 1 | 2007-07-11 | 2006-09-06 | 2 | 2006-07-27 | 2006-09-06 | 1 | 1 | 2006-07-27 | 1 | 2007-07-11 | 15 | HVAC | E | HV |  |  |
| 21650 | East16 Paint & Carpeting | 2d | 2007-04-17 | 2007-04-18 | 21645, 21640, 21635 | Subcontract Work [96 h] | 2006-08-16 | Task | 2 | 3 | 2007-07-11 | 2006-09-07 | 3 | 2006-07-28 | 2006-09-08 | 2 | 2 | 2006-07-27 | 2 | 2007-07-10 | 16 | Paint | E | SB |  |  |
| 11200 | West12 Layout Floor | 1d | 2007-04-18 | 2007-04-18 | 11300, 1470, 1350 | Carpenters [32 h] | 2006-07-11 | Task | 1 | 1 | 2007-07-31 | 2006-07-26 | 2 | 2006-06-14 | 2006-07-26 | 1 | 1 | 2006-06-14 | 1 | 2007-07-31 | 12 | Layout | W | CP |  |  |
| 11100 | West11 Layout Floor | 1d | 2007-04-19 | 2007-04-19 | 11200, 1470, 1350 | Carpenters [32 h] | 2006-07-13 | Task | 2 | 1 | 2007-08-02 | 2006-07-28 | 2 | 2006-06-15 | 2006-07-28 | 1 | 2 | 2006-06-15 | 1 | 2007-08-01 | 11 | Layout | W | CP |  |  |
| 11705 | West17 Studs & Drywall/1 | 2d | 2007-04-19 | 2007-04-20 | 11805, 11700 | Carpenters [96 h] | 2006-07-07 | Task | 2 | 3 | 2007-08-01 | 2006-07-13 | 3 | 2006-06-16 | 2006-07-14 | 2 | 2 | 2006-06-15 | 2 | 2007-07-31 | 17 | Stud | W | CP |  |  |
| 11710 | West17 R/I Plumbing | 2d | 2007-04-19 | 2007-04-20 | 11810, 11700 | Plumbers [64 h] | 2006-07-07 | Task | 3 | 3 | 2007-08-02 | 2006-07-14 | 3 | 2006-06-16 | 2006-07-17 | 2 | 3 | 2006-06-15 | 2 | 2007-07-31 | 17 | R/I PB | W | PB |  |  |
| 11715 | West17 HVAC Ductwork | 2d | 2007-04-19 | 2007-04-20 | 11815, 11700 | HVAC Sheet Metal [64 h] | 2006-07-07 | Task | 2 | 3 | 2007-07-30 | 2006-07-17 | 3 | 2006-06-16 | 2006-07-18 | 2 | 2 | 2006-06-15 | 2 | 2007-07-27 | 17 | HVAC | W | HV |  |  |
| 11820 | West18 R/I Electric | 2d | 2007-04-19 | 2007-04-20 | 11805 | Electricians [64 h] | 2006-07-07 | Task | 2 | 3 | 2007-08-01 | 2006-08-30 | 3 | 2006-06-16 | 2006-08-31 | 2 | 2 | 2006-06-15 | 2 | 2007-07-31 | 18 | R/I Elec | W | EL |  |  |
| 11825 | West18 Plumbing Test | 1d | 2007-04-19 | 2007-04-19 | 11810 | Plumbers [16 h] | 2006-07-06 | Task | 1 | 1 | 2007-07-31 | 2006-08-31 | 2 | 2006-06-15 | 2006-08-31 | 1 | 1 | 2006-06-15 | 1 | 2007-07-31 | 18 | PB Test | W | PB |  |  |
| 11930 | West19 Drywall/2 & Finishes | 2d | 2007-04-19 | 2007-04-20 | 11925, 11920, 11915 | Carpenters [96 h] | 2006-07-07 | Task | 1 | 3 | 2007-08-01 | 2006-09-01 | 3 | 2006-06-16 | 2006-09-04 | 2 | 1 | 2006-06-15 | 2 | 2007-08-01 | 19 | Drywall | W | CP |  |  |
| 12035 | West20 Electric Fixtures | 2d | 2007-04-19 | 2007-04-20 | 12030 | Electricians [32 h] | 2006-07-07 | Task | 2 | 3 | 2007-08-02 | 2006-09-05 | 3 | 2006-06-16 | 2006-09-06 | 2 | 2 | 2006-06-15 | 2 | 2007-08-01 | 20 | Elec Fixt | W | EL |  |  |
| 12040 | West20 Plumbing Fixtures | 2d | 2007-04-19 | 2007-04-20 | 12030 | Plumbers [32 h] | 2006-07-07 | Task | 3 | 3 | 2007-08-03 | 2006-09-05 | 3 | 2006-06-16 | 2006-09-06 | 2 | 3 | 2006-06-15 | 2 | 2007-08-01 | 20 | PB Fixt | W | PB |  |  |
| 12045 | West20 HVAC Fixtures | 1d | 2007-04-19 | 2007-04-19 | 12030 | HVAC Sheet Metal [16 h] | 2006-07-06 | Task | 2 | 1 | 2007-08-02 | 2006-09-06 | 2 | 2006-06-15 | 2006-09-06 | 1 | 2 | 2006-06-15 | 1 | 2007-08-01 | 20 | HVAC | W | HV |  |  |
| 12150 | West21 Paint & Carpeting | 2d | 2007-04-19 | 2007-04-20 | 12145, 12140, 12135 | Subcontract Work [96 h] | 2006-07-07 | Task | 2 | 3 | 2007-07-30 | 2006-09-07 | 3 | 2006-06-16 | 2006-09-08 | 2 | 2 | 2006-06-15 | 2 | 2007-07-27 | 21 | Paint | W | SB |  |  |
| 21105 | East11 Studs & Drywall/1 | 2d | 2007-04-19 | 2007-04-20 | 21205, 21100 | Carpenters [96 h] | 2006-08-21 | Task | 2 | 3 | 2007-07-13 | 2006-07-31 | 3 | 2006-08-01 | 2006-08-01 | 2 | 2 | 2006-07-31 | 2 | 2007-07-12 | 11 | Stud | E | CP |  |  |
| 21110 | East11 R/I Plumbing | 2d | 2007-04-19 | 2007-04-20 | 21210, 21100 | Plumbers [64 h] | 2006-08-21 | Task | 2 | 3 | 2007-07-16 | 2006-08-01 | 3 | 2006-08-01 | 2006-08-02 | 2 | 2 | 2006-07-31 | 2 | 2007-07-13 | 11 | R/I PB | E | PB |  |  |
| 21115 | East11 HVAC Ductwork | 2d | 2007-04-19 | 2007-04-20 | 21215, 21100 | HVAC Sheet Metal [64 h] | 2006-08-21 | Task | 2 | 3 | 2007-07-18 | 2006-08-02 | 3 | 2006-08-01 | 2006-08-03 | 2 | 2 | 2006-07-31 | 2 | 2007-07-17 | 11 | HVAC | E | HV |  |  |
| 21220 | East12 R/I Electric | 2d | 2007-04-19 | 2007-04-20 | 21205 | Electricians [64 h] | 2006-08-21 | Task | 2 | 3 | 2007-07-13 | 2006-08-30 | 3 | 2006-08-01 | 2006-08-31 | 2 | 2 | 2006-07-31 | 2 | 2007-07-12 | 12 | R/I Elec | E | EL |  |  |
| 21225 | East12 Plumbing Test | 1d | 2007-04-19 | 2007-04-19 | 21210 | Plumbers [16 h] | 2006-08-18 | Task | 1 | 1 | 2007-07-13 | 2006-08-31 | 2 | 2006-07-31 | 2006-08-31 | 1 | 1 | 2006-07-31 | 1 | 2007-07-13 | 12 | PB Test | E | PB |  |  |
| 21330 | East13 Drywall/2 & Finishes | 2d | 2007-04-19 | 2007-04-20 | 21325, 21320, 21315 | Carpenters [96 h] | 2006-08-21 | Task | 2 | 3 | 2007-07-13 | 2006-09-01 | 3 | 2006-08-01 | 2006-09-04 | 2 | 2 | 2006-07-31 | 2 | 2007-07-12 | 13 | Drywall | E | CP |  |  |
| 21435 | East14 Electric Fixtures | 2d | 2007-04-19 | 2007-04-20 | 21430 | Electricians [32 h] | 2006-08-21 | Task | 1 | 3 | 2007-07-12 | 2006-09-05 | 3 | 2006-08-01 | 2006-09-06 | 2 | 1 | 2006-07-31 | 2 | 2007-07-12 | 14 | Elec Fixt | E | EL |  |  |
| 21440 | East14 Plumbing Fixtures | 2d | 2007-04-19 | 2007-04-20 | 21430 | Plumbers [32 h] | 2006-08-21 | Task | 2 | 3 | 2007-07-13 | 2006-09-05 | 3 | 2006-08-01 | 2006-09-06 | 2 | 2 | 2006-07-31 | 2 | 2007-07-12 | 14 | PB Fixt | E | PB |  |  |

| ID | Activity | Duration | Start | Finish | Predecessors | Resources | MEF | P3 Task Type | ADur | PESS | AFinish | Imported Late Start | MOD | Imported Early Finish | Imported Late Finish | MOST | ActDur | Imported Early Start | OPTD | AStart | LOC2 Floor | WTYP | LOC1 Tower | CRTY | PL-1 | LOC3 Segment |
| --- | --- | --- | --- | --- | --- | --- | --- | --- | --- | --- | --- | --- | --- | --- | --- | --- | --- | --- | --- | --- | --- | --- | --- | --- | --- | --- |
| 21445 | East14 HVAC Fixtures | 1d | 2007-04-19 | 2007-04-19 | 21430 | HVAC Sheet Metal [16 h] | 2006-08-18 | Task | 1 | 1 | 2007-07-12 | 2006-09-06 | 2 | 2006-07-31 | 2006-09-06 | 1 | 1 | 2006-07-31 | 1 | 2007-07-12 | 14 | HVAC | E | HV |  |  |
| 21550 | East15 Paint & Carpeting | 2d | 2007-04-19 | 2007-04-20 | 21545, 21540, 21535 | Subcontract Work [96 h] | 2006-08-21 | Task | 2 | 3 | 2007-07-16 | 2006-09-07 | 3 | 2006-08-01 | 2006-09-08 | 2 | 2 | 2006-07-31 | 2 | 2007-07-13 | 15 | Paint | E | SB |  |  |
| 2630 | East36 Form/Pour Slab | 4d | 2007-04-20 | 2007-04-25 | 2625 | Carpenters [320 h] | 2006-04-06 | Task | 4 | 5 | 2007-05-15 | 2006-04-19 | 5 | 2006-04-24 | 2006-04-24 | 4 | 4 | 2006-04-19 | 3 | 2007-05-10 | 36 | Slab | E | CP | 24 | 10 |
| 11000 | West10 Layout Floor | 1d | 2007-04-20 | 2007-04-20 | 11100, 1470 | Carpenters [32 h] | 2006-07-17 | Task | 1 | 1 | 2007-08-03 | 2006-08-01 | 2 | 2006-06-16 | 2006-08-01 | 1 | 1 | 2006-06-16 | 1 | 2007-08-03 |  | Layout | W | CP |  | 10 |
| 10900 | West09 Layout Floor | 1d | 2007-04-23 | 2007-04-23 | 11000, 1470, 1340 | Carpenters [32 h] | 2006-07-19 | Task | 1 | 1 | 2007-08-06 | 2006-08-03 | 2 | 2006-06-19 | 2006-08-03 | 1 | 1 | 2006-06-19 | 1 | 2007-08-06 | 09 | Layout | W | CP |  |  |
| 11605 | West16 Studs & Drywall/1 | 2d | 2007-04-23 | 2007-04-24 | 11705, 11600 | Carpenters [96 h] | 2006-07-12 | Task | 2 | 3 | 2007-08-03 | 2006-07-17 | 3 | 2006-06-20 | 2006-07-18 | 2 | 2 | 2006-06-19 | 2 | 2007-08-02 | 16 | Stud | W | CP |  |  |
| 11610 | West16 R/I Plumbing | 2d | 2007-04-23 | 2007-04-24 | 11710, 11600 | Plumbers [64 h] | 2006-07-12 | Task | 2 | 3 | 2007-08-06 | 2006-07-18 | 3 | 2006-06-20 | 2006-07-19 | 2 | 2 | 2006-06-19 | 2 | 2007-08-03 | 16 | R/I PB | W | PB |  |  |
| 11615 | West16 HVAC Ductwork | 2d | 2007-04-23 | 2007-04-24 | 11715, 11600 | HVAC Sheet Metal [64 h] | 2006-07-12 | Task | 1 | 3 | 2007-07-31 | 2006-07-19 | 3 | 2006-06-20 | 2006-07-20 | 2 | 1 | 2006-06-19 | 2 | 2007-07-31 | 16 | HVAC | W | HV |  |  |
| 11720 | West17 R/I Electric | 2d | 2007-04-23 | 2007-04-24 | 11705 | Electricians [64 h] | 2006-07-12 | Task | 2 | 3 | 2007-08-03 | 2006-08-30 | 3 | 2006-06-20 | 2006-08-31 | 2 | 2 | 2006-06-19 | 2 | 2007-08-02 | 17 | R/I Elec | W | EL |  |  |
| 11725 | West17 Plumbing Test | 1d | 2007-04-23 | 2007-04-23 | 11710 | Plumbers [16 h] | 2006-07-11 | Task | 2 | 1 | 2007-08-06 | 2006-08-31 | 2 | 2006-06-19 | 2006-08-31 | 1 | 2 | 2006-06-19 | 1 | 2007-08-03 | 17 | PB Test | W | PB |  |  |
| 11830 | West18 Drywall/2 & Finishes | 2d | 2007-04-23 | 2007-04-24 | 11825, 11820, 11815 | Carpenters [96 h] | 2006-07-12 | Task | 2 | 3 | 2007-08-03 | 2006-09-01 | 3 | 2006-06-20 | 2006-09-04 | 2 | 2 | 2006-06-19 | 2 | 2007-08-02 | 18 | Drywall | W | CP |  |  |
| 11935 | West19 Electric Fixtures | 2d | 2007-04-23 | 2007-04-24 | 11930 | Electricians [32 h] | 2006-07-12 | Task | 1 | 3 | 2007-08-02 | 2006-09-05 | 3 | 2006-06-20 | 2006-09-06 | 2 | 1 | 2006-06-19 | 2 | 2007-08-02 | 19 | Elec Fixt | W | EL |  |  |
| 11940 | West19 Plumbing Fixtures | 2d | 2007-04-23 | 2007-04-24 | 11930 | Plumbers [32 h] | 2006-07-12 | Task | 1 | 3 | 2007-08-02 | 2006-09-05 | 3 | 2006-06-20 | 2006-09-06 | 2 | 1 | 2006-06-19 | 2 | 2007-08-02 | 19 | PB Fixt | W | PB |  |  |
| 11945 | West19 HVAC Fixtures | 1d | 2007-04-23 | 2007-04-23 | 11930 | HVAC Sheet Metal [16 h] | 2006-07-11 | Task | 1 | 1 | 2007-08-02 | 2006-09-06 | 2 | 2006-06-19 | 2006-09-06 | 1 | 1 | 2006-06-19 | 1 | 2007-08-02 | 19 | HVAC | W | HV |  |  |
| 12050 | West20 Paint & Carpeting | 2d | 2007-04-23 | 2007-04-24 | 12045, 12040, 12035 | Subcontract Work [96 h] | 2006-07-12 | Task | 2 | 3 | 2007-08-07 | 2006-09-07 | 3 | 2006-06-20 | 2006-09-08 | 2 | 2 | 2006-06-19 | 2 | 2007-08-06 | 20 | Paint | W | SB |  |  |
| 21005 | East10 Studs & Drywall/1 | 2d | 2007-04-23 | 2007-04-24 | 21105, 21000 | Carpenters [96 h] | 2006-08-24 | Task | 1 | 3 | 2007-07-16 | 2006-08-02 | 3 | 2006-08-03 | 2006-08-03 | 2 | 1 | 2006-08-02 | 2 | 2007-07-16 |  | Stud | E | CP |  | 10 |
| 21010 | East10 R/I Plumbing | 2d | 2007-04-23 | 2007-04-24 | 21110, 21000 | Plumbers [64 h] | 2006-08-24 | Task | 2 | 3 | 2007-07-18 | 2006-08-03 | 3 | 2006-08-03 | 2006-08-04 | 2 | 2 | 2006-08-02 | 2 | 2007-07-17 |  | R/I PB | E | PB |  | 10 |
| 21015 | East10 HVAC Ductwork | 2d | 2007-04-23 | 2007-04-24 | 21115, 21000 | HVAC Sheet Metal [64 h] | 2006-08-24 | Task | 3 | 3 | 2007-07-23 | 2006-08-04 | 3 | 2006-08-03 | 2006-08-07 | 2 | 3 | 2006-08-02 | 2 | 2007-07-19 |  | HVAC | E | HV |  | 10 |
| 21120 | East11 R/I Electric | 2d | 2007-04-23 | 2007-04-24 | 21105 | Electricians [64 h] | 2006-08-24 | Task | 2 | 3 | 2007-07-17 | 2006-08-30 | 3 | 2006-08-03 | 2006-08-31 | 2 | 2 | 2006-08-02 | 2 | 2007-07-16 | 11 | R/I Elec | E | EL |  |  |
| 21125 | East11 Plumbing Test | 1d | 2007-04-23 | 2007-04-23 | 21110 | Plumbers [16 h] | 2006-08-23 | Task | 2 | 1 | 2007-07-18 | 2006-08-31 | 2 | 2006-08-02 | 2006-08-31 | 1 | 2 | 2006-08-02 | 1 | 2007-07-17 | 11 | PB Test | E | PB |  |  |
| 21230 | East12 Drywall/2 & Finishes | 2d | 2007-04-23 | 2007-04-24 | 21225, 21220, 21215 | Carpenters [96 h] | 2006-08-24 | Task | 2 | 3 | 2007-07-18 | 2006-09-01 | 3 | 2006-08-03 | 2006-09-04 | 2 | 2 | 2006-08-02 | 2 | 2007-07-17 | 12 | Drywall | E | CP |  |  |
| 21335 | East13 Electric Fixtures | 2d | 2007-04-23 | 2007-04-24 | 21330 | Electricians [32 h] | 2006-08-24 | Task | 2 | 3 | 2007-07-17 | 2006-09-05 | 3 | 2006-08-03 | 2006-09-06 | 2 | 2 | 2006-08-02 | 2 | 2007-07-16 | 13 | Elec Fixt | E | EL |  |  |
| 21340 | East13 Plumbing Fixtures | 2d | 2007-04-23 | 2007-04-24 | 21330 | Plumbers [32 h] | 2006-08-24 | Task | 3 | 3 | 2007-07-18 | 2006-09-05 | 3 | 2006-08-03 | 2006-09-06 | 2 | 3 | 2006-08-02 | 2 | 2007-07-16 | 13 | PB Fixt | E | PB |  |  |
| 21345 | East13 HVAC Fixtures | 1d | 2007-04-23 | 2007-04-23 | 21330 | HVAC Sheet Metal [16 h] | 2006-08-23 | Task | 1 | 1 | 2007-07-16 | 2006-09-06 | 2 | 2006-08-02 | 2006-09-06 | 1 | 1 | 2006-08-02 | 1 | 2007-07-16 | 13 | HVAC | E | HV |  |  |
| 21450 | East14 Paint & Carpeting | 2d | 2007-04-23 | 2007-04-24 | 21445, 21440, 21435 | Subcontract Work [96 h] | 2006-08-24 | Task | 2 | 3 | 2007-07-17 | 2006-09-07 | 3 | 2006-08-03 | 2006-09-08 | 2 | 2 | 2006-08-02 | 2 | 2007-07-16 | 14 | Paint | E | SB |  |  |
| 1662 | West37 Affix Window Wall Frames Floors 35-37 | 5d | 2007-04-24 | 2007-04-30 | 1660, 1635, 1630, 1625, 1620, 401 | Iron Workers [240 h] | 2006-05-17 | Task | 5 | 6 | 2007-05-28 | 2006-05-19 | 6 | 2006-04-27 | 2006-05-25 | 5 | 5 | 2006-04-21 | 4 | 2007-05-22 | 37 | Frame | W | IW |  |  |
| 10800 | West08 Layout Floor | 1d | 2007-04-24 | 2007-04-24 | 10900, 1470, 1340 | Carpenters [32 h] | 2006-07-21 | Task | 1 | 1 | 2007-08-07 | 2006-08-07 | 2 | 2006-06-20 | 2006-08-07 | 1 | 1 | 2006-06-20 | 1 | 2007-08-07 | 08 | Layout | W | CP |  |  |
| 10700 | West07 Layout Floor | 1d | 2007-04-25 | 2007-04-25 | 10800, 1470, 1340 | Carpenters [32 h] | 2006-07-25 | Task | 1 | 1 | 2007-08-08 | 2006-08-09 | 2 | 2006-06-21 | 2006-08-09 | 1 | 1 | 2006-06-21 | 1 | 2007-08-08 | 07 | Layout | W | CP |  |  |
| 11505 | West15 Studs & Drywall/1 | 2d | 2007-04-25 | 2007-04-26 | 11605, 11500 | Carpenters [96 h] | 2006-07-17 | Task | 2 | 3 | 2007-08-07 | 2006-07-19 | 3 | 2006-06-22 | 2006-07-20 | 2 | 2 | 2006-06-21 | 2 | 2007-08-06 | 15 | Stud | W | CP |  |  |
| 11510 | West15 R/I Plumbing | 2d | 2007-04-25 | 2007-04-26 | 11610, 11500 | Plumbers [64 h] | 2006-07-17 | Task | 2 | 3 | 2007-08-08 | 2006-07-20 | 3 | 2006-06-22 | 2006-07-21 | 2 | 2 | 2006-06-21 | 2 | 2007-08-07 | 15 | R/I PB | W | PB |  |  |
| 11515 | West15 HVAC Ductwork | 2d | 2007-04-25 | 2007-04-26 | 11615, 11500 | HVAC Sheet Metal [64 h] | 2006-07-17 | Task | 2 | 3 | 2007-08-02 | 2006-07-21 | 3 | 2006-06-22 | 2006-07-24 | 2 | 2 | 2006-06-21 | 2 | 2007-08-01 | 15 | HVAC | W | HV |  |  |
| 11620 | West16 R/I Electric | 2d | 2007-04-25 | 2007-04-26 | 11605 | Electricians [64 h] | 2006-07-17 | Task | 3 | 3 | 2007-08-08 | 2006-08-30 | 3 | 2006-06-22 | 2006-08-31 | 2 | 3 | 2006-06-21 | 2 | 2007-08-06 | 16 | R/I Elec | W | EL |  |  |
| 11625 | West16 Plumbing Test | 1d | 2007-04-25 | 2007-04-25 | 11610 | Plumbers [16 h] | 2006-07-14 | Task | 2 | 1 | 2007-08-08 | 2006-08-31 | 2 | 2006-06-21 | 2006-08-31 | 1 | 2 | 2006-06-21 | 1 | 2007-08-07 | 16 | PB Test | W | PB |  |  |
| 11730 | West17 Drywall/2 & Finishes | 2d | 2007-04-25 | 2007-04-26 | 11725, 11720, 11715 | Carpenters [96 h] | 2006-07-17 | Task | 2 | 3 | 2007-08-08 | 2006-09-01 | 3 | 2006-06-22 | 2006-09-04 | 2 | 2 | 2006-06-21 | 2 | 2007-08-07 | 17 | Drywall | W | CP |  |  |
| 11835 | West18 Electric Fixtures | 2d | 2007-04-25 | 2007-04-26 | 11830 | Electricians [32 h] | 2006-07-17 | Task | 2 | 3 | 2007-08-07 | 2006-09-05 | 3 | 2006-06-22 | 2006-09-06 | 2 | 2 | 2006-06-21 | 2 | 2007-08-06 | 18 | Elec Fixt | W | EL |  |  |
| 11840 | West18 Plumbing Fixtures | 2d | 2007-04-25 | 2007-04-26 | 11830 | Plumbers [32 h] | 2006-07-17 | Task | 2 | 3 | 2007-08-07 | 2006-09-05 | 3 | 2006-06-22 | 2006-09-06 | 2 | 2 | 2006-06-21 | 2 | 2007-08-06 | 18 | PB Fixt | W | PB |  |  |
| 11845 | West18 HVAC Fixtures | 1d | 2007-04-25 | 2007-04-25 | 11830 | HVAC Sheet Metal [16 h] | 2006-07-14 | Task | 2 | 1 | 2007-08-07 | 2006-09-06 | 2 | 2006-06-21 | 2006-09-06 | 1 | 2 | 2006-06-21 | 1 | 2007-08-06 | 18 | HVAC | W | HV |  |  |
| 11950 | West19 Paint & Carpeting | 2d | 2007-04-25 | 2007-04-26 | 11945, 11940, 11935 | Subcontract Work [96 h] | 2006-07-17 | Task | 3 | 3 | 2007-08-07 | 2006-09-07 | 3 | 2006-06-22 | 2006-09-08 | 2 | 3 | 2006-06-21 | 2 | 2007-08-03 | 19 | Paint | W | SB |  |  |
| 20905 | East09 Studs & Drywall/1 | 2d | 2007-04-25 | 2007-04-26 | 21005, 20900 | Carpenters [96 h] | 2006-08-29 | Task | 2 | 3 | 2007-07-18 | 2006-08-04 | 3 | 2006-08-07 | 2006-08-07 | 2 | 2 | 2006-08-04 | 2 | 2007-07-17 | 09 | Stud | E | CP |  |  |
| 20910 | East09 R/I Plumbing | 2d | 2007-04-25 | 2007-04-26 | 21010, 20900 | Plumbers [64 h] | 2006-08-29 | Task | 2 | 3 | 2007-07-20 | 2006-08-07 | 3 | 2006-08-07 | 2006-08-08 | 2 | 2 | 2006-08-04 | 2 | 2007-07-19 | 09 | R/I PB | E | PB |  |  |
| 20915 | East09 HVAC Ductwork | 2d | 2007-04-25 | 2007-04-26 | 21015, 20900 | HVAC Sheet Metal [64 h] | 2006-08-29 | Task | 2 | 3 | 2007-07-25 | 2006-08-08 | 3 | 2006-08-07 | 2006-08-09 | 2 | 2 | 2006-08-04 | 2 | 2007-07-24 | 09 | HVAC | E | HV |  |  |
| 21020 | East10 R/I Electric | 2d | 2007-04-25 | 2007-04-26 | 21005 | Electricians [64 h] | 2006-08-29 | Task | 2 | 3 | 2007-07-18 | 2006-08-30 | 3 | 2006-08-07 | 2006-08-31 | 2 | 2 | 2006-08-04 | 2 | 2007-07-17 |  | R/I Elec | E | EL |  | 10 |
| 21025 | East10 Plumbing Test | 1d | 2007-04-25 | 2007-04-25 | 21010 | Plumbers [16 h] | 2006-08-28 | Task | 1 | 1 | 2007-07-19 | 2006-08-31 | 2 | 2006-08-04 | 2006-08-31 | 1 | 1 | 2006-08-04 | 1 | 2007-07-19 |  | PB Test | E | PB |  | 10 |
| 21130 | East11 Drywall/2 & Finishes | 2d | 2007-04-25 | 2007-04-26 | 21125, 21120, 21115 | Carpenters [96 h] | 2006-08-29 | Task | 1 | 3 | 2007-07-19 | 2006-09-01 | 3 | 2006-08-07 | 2006-09-04 | 2 | 1 | 2006-08-04 | 2 | 2007-07-19 | 11 | Drywall | E | CP |  |  |
| 21235 | East12 Electric Fixtures | 2d | 2007-04-25 | 2007-04-26 | 21230 | Electricians [32 h] | 2006-08-29 | Task | 2 | 3 | 2007-07-20 | 2006-09-05 | 3 | 2006-08-07 | 2006-09-06 | 2 | 2 | 2006-08-04 | 2 | 2007-07-19 | 12 | Elec Fixt | E | EL |  |  |
| 21240 | East12 Plumbing Fixtures | 2d | 2007-04-25 | 2007-04-26 | 21230 | Plumbers [32 h] | 2006-08-29 | Task | 3 | 3 | 2007-07-23 | 2006-09-05 | 3 | 2006-08-07 | 2006-09-06 | 2 | 3 | 2006-08-04 | 2 | 2007-07-19 | 12 | PB Fixt | E | PB |  |  |
| 21245 | East12 HVAC Fixtures | 1d | 2007-04-25 | 2007-04-25 | 21230 | HVAC Sheet Metal [16 h] | 2006-08-28 | Task | 1 | 1 | 2007-07-19 | 2006-09-06 | 2 | 2006-08-04 | 2006-09-06 | 1 | 1 | 2006-08-04 | 1 | 2007-07-19 | 12 | HVAC | E | HV |  |  |
| 21350 | East13 Paint & Carpeting | 2d | 2007-04-25 | 2007-04-26 | 21345, 21340, 21335 | Subcontract Work [96 h] | 2006-08-29 | Task | 2 | 3 | 2007-07-20 | 2006-09-07 | 3 | 2006-08-07 | 2006-09-08 | 2 | 2 | 2006-08-04 | 2 | 2007-07-19 | 13 | Paint | E | SB |  |  |
| 2635 | East35 Form/Pour Slab | 4d | 2007-04-26 | 2007-05-01 | 2630 | Carpenters [320 h] | 2006-04-13 | Task | 5 | 5 | 2007-05-22 | 2006-04-25 | 5 | 2006-04-28 | 2006-04-28 | 4 | 5 | 2006-04-25 | 3 | 2007-05-16 | 35 | Slab | E | CP | 24 | 10 |
| 10600 | West06 Layout Floor | 1d | 2007-04-26 | 2007-04-26 | 10700, 1470, 1340 | Carpenters [32 h] | 2006-07-27 | Task | 1 | 1 | 2007-08-09 | 2006-08-11 | 2 | 2006-06-22 | 2006-08-11 | 1 | 1 | 2006-06-22 | 1 | 2007-08-09 | 06 | Layout | W | CP |  |  |
| 10500 | West05 Layout Floor | 1d | 2007-04-27 | 2007-04-27 | 10600, 1470, 1340 | Carpenters [32 h] | 2006-07-31 | Task | 1 | 1 | 2007-08-10 | 2006-08-15 | 2 | 2006-06-23 | 2006-08-15 | 1 | 1 | 2006-06-23 | 1 | 2007-08-10 | 05 | Layout | W | CP |  |  |
| 11405 | West14 Studs & Drywall/1 | 2d | 2007-04-27 | 2007-04-30 | 11505, 11400 | Carpenters [96 h] | 2006-07-20 | Task | 1 | 3 | 2007-08-08 | 2006-07-21 | 3 | 2006-06-26 | 2006-07-24 | 2 | 1 | 2006-06-23 | 2 | 2007-08-08 | 14 | Stud | W | CP |  |  |
| 11410 | West14 R/I Plumbing | 2d | 2007-04-27 | 2007-04-30 | 11510, 11400 | Plumbers [64 h] | 2006-07-20 | Task | 2 | 3 | 2007-08-10 | 2006-07-24 | 3 | 2006-06-26 | 2006-07-25 | 2 | 2 | 2006-06-23 | 2 | 2007-08-09 | 14 | R/I PB | W | PB |  |  |
| 11415 | West14 HVAC Ductwork | 2d | 2007-04-27 | 2007-04-30 | 11515, 11400 | HVAC Sheet Metal [64 h] | 2006-07-20 | Task | 1 | 3 | 2007-08-03 | 2006-07-25 | 3 | 2006-06-26 | 2006-07-26 | 2 | 1 | 2006-06-23 | 2 | 2007-08-03 | 14 | HVAC | W | HV |  |  |
| 11520 | West15 R/I Electric | 2d | 2007-04-27 | 2007-04-30 | 11505 | Electricians [64 h] | 2006-07-20 | Task | 2 | 3 | 2007-08-09 | 2006-08-30 | 3 | 2006-06-26 | 2006-08-31 | 2 | 2 | 2006-06-23 | 2 | 2007-08-08 | 15 | R/I Elec | W | EL |  |  |
| 11525 | West15 Plumbing Test | 1d | 2007-04-27 | 2007-04-27 | 11510 | Plumbers [16 h] | 2006-07-19 | Task | 1 | 1 | 2007-08-09 | 2006-08-31 | 2 | 2006-06-23 | 2006-08-31 | 1 | 1 | 2006-06-23 | 1 | 2007-08-09 | 15 | PB Test | W | PB |  |  |
| 11630 | West16 Drywall/2 & Finishes | 2d | 2007-04-27 | 2007-04-30 | 11625, 11620, 11615 | Carpenters [96 h] | 2006-07-20 | Task | 2 | 3 | 2007-08-10 | 2006-09-01 | 3 | 2006-06-26 | 2006-09-04 | 2 | 2 | 2006-06-23 | 2 | 2007-08-09 | 16 | Drywall | W | CP |  |  |
| 11735 | West17 Electric Fixtures | 2d | 2007-04-27 | 2007-04-30 | 11730 | Electricians [32 h] | 2006-07-20 | Task | 1 | 3 | 2007-08-09 | 2006-09-05 | 3 | 2006-06-26 | 2006-09-06 | 2 | 1 | 2006-06-23 | 2 | 2007-08-09 | 17 | Elec Fixt | W | EL |  |  |
| 11740 | West17 Plumbing Fixtures | 2d | 2007-04-27 | 2007-04-30 | 11730 | Plumbers [32 h] | 2006-07-20 | Task | 2 | 3 | 2007-08-10 | 2006-09-05 | 3 | 2006-06-26 | 2006-09-06 | 2 | 2 | 2006-06-23 | 2 | 2007-08-09 | 17 | PB Fixt | W | PB |  |  |
| 11745 | West17 HVAC Fixtures | 1d | 2007-04-27 | 2007-04-27 | 11730 | HVAC Sheet Metal [16 h] | 2006-07-19 | Task | 1 | 1 | 2007-08-09 | 2006-09-06 | 2 | 2006-06-23 | 2006-09-06 | 1 | 1 | 2006-06-23 | 1 | 2007-08-09 | 17 | HVAC | W | HV |  |  |
| 11850 | West18 Paint & Carpeting | 2d | 2007-04-27 | 2007-04-30 | 11845, 11840, 11835 | Subcontract Work [96 h] | 2006-07-20 | Task | 2 | 3 | 2007-08-09 | 2006-09-07 | 3 | 2006-06-26 | 2006-09-08 | 2 | 2 | 2006-06-23 | 2 | 2007-08-08 | 18 | Paint | W | SB |  |  |
| 20805 | East08 Studs & Drywall/1 | 2d | 2007-04-27 | 2007-04-30 | 20905, 20800 | Carpenters [96 h] | 2006-09-01 | Task | 2 | 3 | 2007-07-20 | 2006-08-08 | 3 | 2006-08-09 | 2006-08-09 | 2 | 2 | 2006-08-08 | 2 | 2007-07-19 | 08 | Stud | E | CP |  |  |
| 20810 | East08 R/I Plumbing | 2d | 2007-04-27 | 2007-04-30 | 20910, 20800 | Plumbers [64 h] | 2006-09-01 | Task | 2 | 3 | 2007-07-24 | 2006-08-09 | 3 | 2006-08-09 | 2006-08-10 | 2 | 2 | 2006-08-08 | 2 | 2007-07-23 | 08 | R/I PB | E | PB |  |  |
| 20815 | East08 HVAC Ductwork | 2d | 2007-04-27 | 2007-04-30 | 20915, 20800 | HVAC Sheet Metal [64 h] | 2006-09-01 | Task | 2 | 3 | 2007-07-27 | 2006-08-10 | 3 | 2006-08-09 | 2006-08-11 | 2 | 2 | 2006-08-08 | 2 | 2007-07-26 | 08 | HVAC | E | HV |  |  |
| 20920 | East09 R/I Electric | 2d | 2007-04-27 | 2007-04-30 | 20905 | Electricians [64 h] | 2006-09-01 | Task | 2 | 3 | 2007-07-20 | 2006-08-30 | 3 | 2006-08-09 | 2006-08-31 | 2 | 2 | 2006-08-08 | 2 | 2007-07-19 | 09 | R/I Elec | E | EL |  |  |
| 20925 | East09 Plumbing Test | 1d | 2007-04-27 | 2007-04-27 | 20910 | Plumbers [16 h] | 2006-08-31 | Task | 1 | 1 | 2007-07-23 | 2006-08-31 | 2 | 2006-08-08 | 2006-08-31 | 1 | 1 | 2006-08-08 | 1 | 2007-07-23 | 09 | PB Test | E | PB |  |  |
| 21030 | East10 Drywall/2 & Finishes | 2d | 2007-04-27 | 2007-04-30 | 21025, 21020, 21015 | Carpenters [96 h] | 2006-09-01 | Task | 2 | 3 | 2007-07-25 | 2006-09-01 | 3 | 2006-08-09 | 2006-09-04 | 2 | 2 | 2006-08-08 | 2 | 2007-07-24 |  | Drywall | E | CP |  | 10 |
| 21135 | East11 Electric Fixtures | 2d | 2007-04-27 | 2007-04-30 | 21130 | Electricians [32 h] | 2006-09-01 | Task | 2 | 3 | 2007-07-23 | 2006-09-05 | 3 | 2006-08-09 | 2006-09-06 | 2 | 2 | 2006-08-08 | 2 | 2007-07-20 | 11 | Elec Fixt | E | EL |  |  |
| 21140 | East11 Plumbing Fixtures | 2d | 2007-04-27 | 2007-04-30 | 21130 | Plumbers [32 h] | 2006-09-01 | Task | 1 | 3 | 2007-07-20 | 2006-09-05 | 3 | 2006-08-09 | 2006-09-06 | 2 | 1 | 2006-08-08 | 2 | 2007-07-20 | 11 | PB Fixt | E | PB |  |  |
| 21145 | East11 HVAC Fixtures | 1d | 2007-04-27 | 2007-04-27 | 21130 | HVAC Sheet Metal [16 h] | 2006-08-31 | Task | 1 | 1 | 2007-07-20 | 2006-09-06 | 2 | 2006-08-08 | 2006-09-06 | 1 | 1 | 2006-08-08 | 1 | 2007-07-20 | 11 | HVAC | E | HV |  |  |

| ID | Activity | Duration | Start | Finish | Predecessors | Constraint | Calendar | Resources | MEF | P3 Task Type | ADur | PESS | AFinish | Imported Late Start | MOD | Imported Early Finish | Imported Late Finish | MOST | ActDur | Imported Early Start | OPTD | AStart | LOC2 Floor | WTYP | LOC1 Tower | CRTY | LOC3 Segment | PL-1 | Links with Lags longer than ? units |
| --- | --- | --- | --- | --- | --- | --- | --- | --- | --- | --- | --- | --- | --- | --- | --- | --- | --- | --- | --- | --- | --- | --- | --- | --- | --- | --- | --- | --- | --- |
| 21250 | East12 Paint & Carpeting | 2d | 2007-04-27 | 2007-04-30 | 21245, 21240, 21235 |  |  | Subcontract Work [96 h] | 2006-09-01 | Task | 2 | 3 | 2007-07-25 | 2006-09-07 | 3 | 2006-08-09 | 2006-09-08 | 2 | 2 | 2006-08-08 | 2 | 2007-07-24 | 12 | Paint | E | SB |  |  |  |
| 10400 | West04 Layout Floor | 1d | 2007-04-30 | 2007-04-30 | 10500, 1470, 1340 |  |  | Carpenters [32 h] | 2006-08-02 | Task | 2 | 1 | 2007-08-14 | 2006-08-17 | 2 | 2006-06-26 | 2006-08-17 | 1 | 2 | 2006-06-26 | 1 | 2007-08-13 | 04 | Layout | W | CP |  |  |  |
| 1664 | West40 Affix Window Wall Frames Floors 38-40 | 5d | 2007-05-01 | 2007-05-07 | 1662, 1620, 1615, 1610, 1605, 401 |  |  | Iron Workers [240 h] | 2006-05-25 | Task | 5 | 6 | 2007-06-04 | 2006-05-26 | 6 | 2006-05-04 | 2006-06-01 | 5 | 5 | 2006-04-28 | 4 | 2007-05-29 | 40 | Frame | W | IW |  |  |  |
| 10300 | West03 Layout Floor | 1d | 2007-05-01 | 2007-05-01 | 10400, 1470, 1340 |  |  | Carpenters [32 h] | 2006-08-04 | Task | 1 | 1 | 2007-08-15 | 2006-08-21 | 2 | 2006-06-27 | 2006-08-21 | 1 | 1 | 2006-06-27 | 1 | 2007-08-15 | 03 | Layout | W | CP |  |  |  |
| 11305 | West13 Studs & Drywall/1 | 2d | 2007-05-01 | 2007-05-02 | 11405, 11300 |  |  | Carpenters [96 h] | 2006-07-25 | Task | 3 | 3 | 2007-08-13 | 2006-07-25 | 3 | 2006-06-28 | 2006-07-26 | 2 | 3 | 2006-06-27 | 2 | 2007-08-09 | 13 | Stud | W | CP |  |  |  |
| 11310 | West13 R/I Plumbing | 2d | 2007-05-01 | 2007-05-02 | 11410, 11300 |  |  | Plumbers [64 h] | 2006-07-25 | Task | 1 | 3 | 2007-08-13 | 2006-07-26 | 3 | 2006-06-28 | 2006-07-27 | 2 | 1 | 2006-06-27 | 2 | 2007-08-13 | 13 | R/I PB | W | PB |  |  |  |
| 11315 | West13 HVAC Ductwork | 2d | 2007-05-01 | 2007-05-02 | 11415, 11300 |  |  | HVAC Sheet Metal [64 h] | 2006-07-25 | Task | 2 | 3 | 2007-08-07 | 2006-07-27 | 3 | 2006-06-28 | 2006-07-28 | 2 | 2 | 2006-06-27 | 2 | 2007-08-06 | 13 | HVAC | W | HV |  |  |  |
| 11420 | West14 R/I Electric | 2d | 2007-05-01 | 2007-05-02 | 11405 |  |  | Electricians [64 h] | 2006-07-25 | Task | 2 | 3 | 2007-08-10 | 2006-08-30 | 3 | 2006-06-28 | 2006-08-31 | 2 | 2 | 2006-06-27 | 2 | 2007-08-09 | 14 | R/I Elec | W | EL |  |  |  |
| 11425 | West14 Plumbing Test | 1d | 2007-05-01 | 2007-05-01 | 11410 |  |  | Plumbers [16 h] | 2006-07-24 | Task | 1 | 1 | 2007-08-13 | 2006-08-31 | 2 | 2006-06-27 | 2006-08-31 | 1 | 1 | 2006-06-27 | 1 | 2007-08-13 | 14 | PB Test | W | PB |  |  |  |
| 11530 | West15 Drywall/2 & Finishes | 2d | 2007-05-01 | 2007-05-02 | 11525, 11520, 11515 |  |  | Carpenters [96 h] | 2006-07-25 | Task | 1 | 3 | 2007-08-10 | 2006-09-01 | 3 | 2006-06-28 | 2006-09-04 | 2 | 1 | 2006-06-27 | 2 | 2007-08-10 | 15 | Drywall | W | CP |  |  |  |
| 11635 | West16 Electric Fixtures | 2d | 2007-05-01 | 2007-05-02 | 11630 |  |  | Electricians [32 h] | 2006-07-25 | Task | 3 | 3 | 2007-08-15 | 2006-09-05 | 3 | 2006-06-28 | 2006-09-06 | 2 | 3 | 2006-06-27 | 2 | 2007-08-13 | 16 | Elec Fixt | W | EL |  |  |  |
| 11640 | West16 Plumbing Fixtures | 2d | 2007-05-01 | 2007-05-02 | 11630 |  |  | Plumbers [32 h] | 2006-07-25 | Task | 2 | 3 | 2007-08-14 | 2006-09-05 | 3 | 2006-06-28 | 2006-09-06 | 2 | 2 | 2006-06-27 | 2 | 2007-08-13 | 16 | PB Fixt | W | PB |  |  |  |
| 11645 | West16 HVAC Fixtures | 1d | 2007-05-01 | 2007-05-01 | 11630 |  |  | HVAC Sheet Metal [16 h] | 2006-07-24 | Task | 1 | 1 | 2007-08-13 | 2006-09-06 | 2 | 2006-06-27 | 2006-09-06 | 1 | 1 | 2006-06-27 | 1 | 2007-08-13 | 16 | HVAC | W | HV |  |  |  |
| 11750 | West17 Paint & Carpeting | 2d | 2007-05-01 | 2007-05-02 | 11745, 11740, 11735 |  |  | Subcontract Work [96 h] | 2006-07-25 | Task | 2 | 3 | 2007-08-14 | 2006-09-07 | 3 | 2006-06-28 | 2006-09-08 | 2 | 2 | 2006-06-27 | 2 | 2007-08-13 | 17 | Paint | W | SB |  |  |  |
| 20705 | East07 Studs & Drywall/1 | 2d | 2007-05-01 | 2007-05-02 | 20805, 20700 |  |  | Carpenters [96 h] | 2006-09-06 | Task | 1 | 3 | 2007-07-23 | 2006-08-10 | 3 | 2006-08-11 | 2006-08-11 | 2 | 1 | 2006-08-10 | 2 | 2007-07-23 | 07 | Stud | E | CP |  |  |  |
| 20710 | East07 R/I Plumbing | 2d | 2007-05-01 | 2007-05-02 | 20810, 20700 |  |  | Plumbers [64 h] | 2006-09-06 | Task | 2 | 3 | 2007-07-26 | 2006-08-11 | 3 | 2006-08-11 | 2006-08-14 | 2 | 2 | 2006-08-10 | 2 | 2007-07-25 | 07 | R/I PB | E | PB |  |  |  |
| 20715 | East07 HVAC Ductwork | 2d | 2007-05-01 | 2007-05-02 | 20815, 20700 |  |  | HVAC Sheet Metal [64 h] | 2006-09-06 | Task | 1 | 3 | 2007-07-30 | 2006-08-14 | 3 | 2006-08-11 | 2006-08-15 | 2 | 1 | 2006-08-10 | 2 | 2007-07-30 | 07 | HVAC | E | HV |  |  |  |
| 20820 | East08 R/I Electric | 2d | 2007-05-01 | 2007-05-02 | 20805 |  |  | Electricians [64 h] | 2006-09-06 | Task | 2 | 3 | 2007-07-24 | 2006-08-30 | 3 | 2006-08-11 | 2006-08-31 | 2 | 2 | 2006-08-10 | 2 | 2007-07-23 | 08 | R/I Elec | E | EL |  |  |  |
| 20825 | East08 Plumbing Test | 1d | 2007-05-01 | 2007-05-01 | 20810 |  |  | Plumbers [16 h] | 2006-09-05 | Task | 1 | 1 | 2007-07-25 | 2006-08-31 | 2 | 2006-08-10 | 2006-08-31 | 1 | 1 | 2006-08-10 | 1 | 2007-07-25 | 08 | PB Test | E | PB |  |  |  |
| 20930 | East09 Drywall/2 & Finishes | 2d | 2007-05-01 | 2007-05-02 | 20925, 20920, 20915 |  |  | Carpenters [96 h] | 2006-09-06 | Task | 2 | 3 | 2007-07-27 | 2006-09-01 | 3 | 2006-08-11 | 2006-09-04 | 2 | 2 | 2006-08-10 | 2 | 2007-07-26 | 09 | Drywall | E | CP |  |  |  |
| 21035 | East10 Electric Fixtures | 2d | 2007-05-01 | 2007-05-02 | 21030 |  |  | Electricians [32 h] | 2006-09-06 | Task | 3 | 3 | 2007-07-30 | 2006-09-05 | 3 | 2006-08-11 | 2006-09-06 | 2 | 3 | 2006-08-10 | 2 | 2007-07-26 |  | Elec Fixt | E | EL | 10 |  |  |
| 21040 | East10 Plumbing Fixtures | 2d | 2007-05-01 | 2007-05-02 | 21030 |  |  | Plumbers [32 h] | 2006-09-06 | Task | 2 | 3 | 2007-07-27 | 2006-09-05 | 3 | 2006-08-11 | 2006-09-06 | 2 | 2 | 2006-08-10 | 2 | 2007-07-26 |  | PB Fixt | E | PB | 10 |  |  |
| 21045 | East10 HVAC Fixtures | 1d | 2007-05-01 | 2007-05-01 | 21030 |  |  | HVAC Sheet Metal [16 h] | 2006-09-05 | Task | 1 | 1 | 2007-07-26 | 2006-09-06 | 2 | 2006-08-10 | 2006-09-06 | 1 | 1 | 2006-08-10 | 1 | 2007-07-26 |  | HVAC | E | HV | 10 |  |  |
| 21150 | East11 Paint & Carpeting | 2d | 2007-05-01 | 2007-05-02 | 21145, 21140, 21135 |  |  | Subcontract Work [96 h] | 2006-09-06 | Task | 2 | 3 | 2007-07-25 | 2006-09-07 | 3 | 2006-08-11 | 2006-09-08 | 2 | 2 | 2006-08-10 | 2 | 2007-07-24 | 11 | Paint | E | SB |  |  |  |
| 2640 | East34 Form/Pour Slab | 4d | 2007-05-02 | 2007-05-07 | 2635 |  |  | Carpenters [320 h] | 2006-04-20 | Task | 5 | 5 | 2007-05-29 | 2006-05-01 | 5 | 2006-05-04 | 2006-05-04 | 4 | 5 | 2006-05-01 | 3 | 2007-05-23 | 34 | Slab | E | CP | 10 | 24 |  |
| 10200 | West02 Layout Floor | 1d | 2007-05-02 | 2007-05-02 | 10300, 1470, 1340 |  |  | Carpenters [32 h] | 2006-08-08 | Task | 2 | 1 | 2007-08-17 | 2006-08-23 | 2 | 2006-06-28 | 2006-08-23 | 1 | 2 | 2006-06-28 | 1 | 2007-08-16 | 02 | Layout | W | CP |  |  |  |
| 10100 | WestCL Layout Floor | 1d | 2007-05-03 | 2007-05-03 | 10200, 1470, 1340 |  |  | Carpenters [32 h] | 2006-08-10 | Task | 1 | 1 | 2007-08-20 | 2006-08-25 | 2 | 2006-06-29 | 2006-08-25 | 1 | 1 | 2006-06-29 | 1 | 2007-08-20 | CL | Layout | W | CP |  |  |  |
| 11205 | West12 Studs & Drywall/1 | 2d | 2007-05-03 | 2007-05-04 | 11305, 11200 |  |  | Carpenters [96 h] | 2006-07-28 | Task | 3 | 3 | 2007-08-16 | 2006-07-27 | 3 | 2006-06-30 | 2006-07-28 | 2 | 3 | 2006-06-29 | 2 | 2007-08-14 | 12 | Stud | W | CP |  |  |  |
| 11210 | West12 R/I Plumbing | 2d | 2007-05-03 | 2007-05-04 | 11310, 11200 |  |  | Plumbers [64 h] | 2006-07-28 | Task | 2 | 3 | 2007-08-15 | 2006-07-28 | 3 | 2006-06-30 | 2006-07-31 | 2 | 2 | 2006-06-29 | 2 | 2007-08-14 | 12 | R/I PB | W | PB |  |  |  |
| 11215 | West12 HVAC Ductwork | 2d | 2007-05-03 | 2007-05-04 | 11315, 11200 |  |  | HVAC Sheet Metal [64 h] | 2006-07-28 | Task | 2 | 3 | 2007-08-09 | 2006-07-31 | 3 | 2006-06-30 | 2006-08-01 | 2 | 2 | 2006-06-29 | 2 | 2007-08-08 | 12 | HVAC | W | HV |  |  |  |
| 11320 | West13 R/I Electric | 2d | 2007-05-03 | 2007-05-04 | 11305 |  |  | Electricians [64 h] | 2006-07-28 | Task | 3 | 3 | 2007-08-16 | 2006-08-30 | 3 | 2006-06-30 | 2006-08-31 | 2 | 3 | 2006-06-29 | 2 | 2007-08-14 | 13 | R/I Elec | W | EL |  |  |  |
| 11325 | West13 Plumbing Test | 1d | 2007-05-03 | 2007-05-03 | 11310 |  |  | Plumbers [16 h] | 2006-07-27 | Task | 1 | 1 | 2007-08-14 | 2006-08-31 | 2 | 2006-06-29 | 2006-08-31 | 1 | 1 | 2006-06-29 | 1 | 2007-08-14 | 13 | PB Test | W | PB |  |  |  |
| 11430 | West14 Drywall/2 & Finishes | 2d | 2007-05-03 | 2007-05-04 | 11425, 11420, 11415 |  |  | Carpenters [96 h] | 2006-07-28 | Task | 2 | 3 | 2007-08-15 | 2006-09-01 | 3 | 2006-06-30 | 2006-09-04 | 2 | 2 | 2006-06-29 | 2 | 2007-08-14 | 14 | Drywall | W | CP |  |  |  |
| 11535 | West15 Electric Fixtures | 2d | 2007-05-03 | 2007-05-04 | 11530 |  |  | Electricians [32 h] | 2006-07-28 | Task | 2 | 3 | 2007-08-14 | 2006-09-05 | 3 | 2006-06-30 | 2006-09-06 | 2 | 2 | 2006-06-29 | 2 | 2007-08-13 | 15 | Elec Fixt | W | EL |  |  |  |
| 11540 | West15 Plumbing Fixtures | 2d | 2007-05-03 | 2007-05-04 | 11530 |  |  | Plumbers [32 h] | 2006-07-28 | Task | 2 | 3 | 2007-08-14 | 2006-09-05 | 3 | 2006-06-30 | 2006-09-06 | 2 | 2 | 2006-06-29 | 2 | 2007-08-13 | 15 | PB Fixt | W | PB |  |  |  |
| 11545 | West15 HVAC Fixtures | 1d | 2007-05-03 | 2007-05-03 | 11530 |  |  | HVAC Sheet Metal [16 h] | 2006-07-27 | Task | 1 | 1 | 2007-08-13 | 2006-09-06 | 2 | 2006-06-29 | 2006-09-06 | 1 | 1 | 2006-06-29 | 1 | 2007-08-13 | 15 | HVAC | W | HV |  |  |  |
| 11650 | West16 Paint & Carpeting | 2d | 2007-05-03 | 2007-05-04 | 11645, 11640, 11635 |  |  | Subcontract Work [96 h] | 2006-07-28 | Task | 1 | 3 | 2007-08-16 | 2006-09-07 | 3 | 2006-06-30 | 2006-09-08 | 2 | 1 | 2006-06-29 | 2 | 2007-08-16 | 16 | Paint | W | SB |  |  |  |
| 20605 | East06 Studs & Drywall/1 | 2d | 2007-05-03 | 2007-05-04 | 20705, 20600 |  |  | Carpenters [96 h] | 2006-09-11 | Task | 3 | 3 | 2007-07-26 | 2006-08-14 | 3 | 2006-08-15 | 2006-08-15 | 2 | 3 | 2006-08-14 | 2 | 2007-07-24 | 06 | Stud | E | CP |  |  |  |
| 20610 | East06 R/I Plumbing | 2d | 2007-05-03 | 2007-05-04 | 20710, 20600 |  |  | Plumbers [64 h] | 2006-09-11 | Task | 2 | 3 | 2007-07-30 | 2006-08-15 | 3 | 2006-08-15 | 2006-08-16 | 2 | 2 | 2006-08-14 | 2 | 2007-07-27 | 06 | R/I PB | E | PB |  |  |  |
| 20615 | East06 HVAC Ductwork | 2d | 2007-05-03 | 2007-05-04 | 20715, 20600 |  |  | HVAC Sheet Metal [64 h] | 2006-09-11 | Task | 2 | 3 | 2007-08-01 | 2006-08-16 | 3 | 2006-08-15 | 2006-08-17 | 2 | 2 | 2006-08-14 | 2 | 2007-07-31 | 06 | HVAC | E | HV |  |  |  |
| 20720 | East07 R/I Electric | 2d | 2007-05-03 | 2007-05-04 | 20705 |  |  | Electricians [64 h] | 2006-09-11 | Task | 2 | 3 | 2007-07-25 | 2006-08-30 | 3 | 2006-08-15 | 2006-08-31 | 2 | 2 | 2006-08-14 | 2 | 2007-07-24 | 07 | R/I Elec | E | EL |  |  |  |
| 20725 | East07 Plumbing Test | 1d | 2007-05-03 | 2007-05-03 | 20710 |  |  | Plumbers [16 h] | 2006-09-08 | Task | 1 | 1 | 2007-07-27 | 2006-08-31 | 2 | 2006-08-14 | 2006-08-31 | 1 | 1 | 2006-08-14 | 1 | 2007-07-27 | 07 | PB Test | E | PB |  |  |  |
| 20830 | East08 Drywall/2 & Finishes | 2d | 2007-05-03 | 2007-05-04 | 20825, 20820, 20815 |  |  | Carpenters [96 h] | 2006-09-11 | Task | 1 | 3 | 2007-07-30 | 2006-09-01 | 3 | 2006-08-15 | 2006-09-04 | 2 | 1 | 2006-08-14 | 2 | 2007-07-30 | 08 | Drywall | E | CP |  |  |  |
| 20935 | East09 Electric Fixtures | 2d | 2007-05-03 | 2007-05-04 | 20930 |  |  | Electricians [32 h] | 2006-09-11 | Task | 2 | 3 | 2007-07-31 | 2006-09-05 | 3 | 2006-08-15 | 2006-09-06 | 2 | 2 | 2006-08-14 | 2 | 2007-07-30 | 09 | Elec Fixt | E | EL |  |  |  |
| 20940 | East09 Plumbing Fixtures | 2d | 2007-05-03 | 2007-05-04 | 20930 |  |  | Plumbers [32 h] | 2006-09-11 | Task | 2 | 3 | 2007-07-31 | 2006-09-05 | 3 | 2006-08-15 | 2006-09-06 | 2 | 2 | 2006-08-14 | 2 | 2007-07-30 | 09 | PB Fixt | E | PB |  |  |  |
| 20945 | East09 HVAC Fixtures | 1d | 2007-05-03 | 2007-05-03 | 20930 |  |  | HVAC Sheet Metal [16 h] | 2006-09-08 | Task | 1 | 1 | 2007-07-30 | 2006-09-06 | 2 | 2006-08-14 | 2006-09-06 | 1 | 1 | 2006-08-14 | 1 | 2007-07-30 | 09 | HVAC | E | HV |  |  |  |
| 21050 | East10 Paint & Carpeting | 2d | 2007-05-03 | 2007-05-04 | 21045, 21040, 21035 |  |  | Subcontract Work [96 h] | 2006-09-11 | Task | 1 | 3 | 2007-07-31 | 2006-09-07 | 3 | 2006-08-15 | 2006-09-08 | 2 | 1 | 2006-08-14 | 2 | 2007-07-31 |  | Paint | E | SB | 10 |  |  |
| 11105 | West11 Studs & Drywall/1 | 2d | 2007-05-07 | 2007-05-08 | 11205, 11100 |  |  | Carpenters [96 h] | 2006-08-02 | Task | 2 | 3 | 2007-08-20 | 2006-07-31 | 3 | 2006-07-04 | 2006-08-01 | 2 | 2 | 2006-07-03 | 2 | 2007-08-17 | 11 | Stud | W | CP |  |  |  |
| 11110 | West11 R/I Plumbing | 2d | 2007-05-07 | 2007-05-08 | 11210, 11100 |  |  | Plumbers [64 h] | 2006-08-02 | Task | 2 | 3 | 2007-08-17 | 2006-08-01 | 3 | 2006-07-04 | 2006-08-02 | 2 | 2 | 2006-07-03 | 2 | 2007-08-16 | 11 | R/I PB | W | PB |  |  |  |
| 11115 | West11 HVAC Ductwork | 2d | 2007-05-07 | 2007-05-08 | 11215, 11100 |  |  | HVAC Sheet Metal [64 h] | 2006-08-02 | Task | 1 | 3 | 2007-08-10 | 2006-08-02 | 3 | 2006-07-04 | 2006-08-03 | 2 | 1 | 2006-07-03 | 2 | 2007-08-10 | 11 | HVAC | W | HV |  |  |  |
| 11220 | West12 R/I Electric | 2d | 2007-05-07 | 2007-05-08 | 11205 |  |  | Electricians [64 h] | 2006-08-02 | Task | 2 | 3 | 2007-08-20 | 2006-08-30 | 3 | 2006-07-04 | 2006-08-31 | 2 | 2 | 2006-07-03 | 2 | 2007-08-17 | 12 | R/I Elec | W | EL |  |  |  |
| 11225 | West12 Plumbing Test | 1d | 2007-05-07 | 2007-05-07 | 11210 |  |  | Plumbers [16 h] | 2006-08-01 | Task | 2 | 1 | 2007-08-17 | 2006-08-31 | 2 | 2006-07-03 | 2006-08-31 | 1 | 2 | 2006-07-03 | 1 | 2007-08-16 | 12 | PB Test | W | PB |  |  |  |
| 11330 | West13 Drywall/2 & Finishes | 2d | 2007-05-07 | 2007-05-08 | 11325, 11320, 11315 |  |  | Carpenters [96 h] | 2006-08-02 | Task | 2 | 3 | 2007-08-20 | 2006-09-01 | 3 | 2006-07-04 | 2006-09-04 | 2 | 2 | 2006-07-03 | 2 | 2007-08-17 | 13 | Drywall | W | CP |  |  |  |
| 11435 | West14 Electric Fixtures | 2d | 2007-05-07 | 2007-05-08 | 11430 |  |  | Electricians [32 h] | 2006-08-02 | Task | 3 | 3 | 2007-08-20 | 2006-09-05 | 3 | 2006-07-04 | 2006-09-06 | 2 | 3 | 2006-07-03 | 2 | 2007-08-16 | 14 | Elec Fixt | W | EL |  |  |  |
| 11440 | West14 Plumbing Fixtures | 2d | 2007-05-07 | 2007-05-08 | 11430 |  |  | Plumbers [32 h] | 2006-08-02 | Task | 2 | 3 | 2007-08-17 | 2006-09-05 | 3 | 2006-07-04 | 2006-09-06 | 2 | 2 | 2006-07-03 | 2 | 2007-08-16 | 14 | PB Fixt | W | PB |  |  |  |
| 11445 | West14 HVAC Fixtures | 1d | 2007-05-07 | 2007-05-07 | 11430 |  |  | HVAC Sheet Metal [16 h] | 2006-08-01 | Task | 1 | 1 | 2007-08-16 | 2006-09-06 | 2 | 2006-07-03 | 2006-09-06 | 1 | 1 | 2006-07-03 | 1 | 2007-08-16 | 14 | HVAC | W | HV |  |  |  |
| 11550 | West15 Paint & Carpeting | 2d | 2007-05-07 | 2007-05-08 | 11545, 11540, 11535 |  |  | Subcontract Work [96 h] | 2006-08-02 | Task | 2 | 3 | 2007-08-16 | 2006-09-07 | 3 | 2006-07-04 | 2006-09-08 | 2 | 2 | 2006-07-03 | 2 | 2007-08-15 | 15 | Paint | W | SB |  |  |  |
| 20505 | East05 Studs & Drywall/1 | 2d | 2007-05-07 | 2007-05-08 | 20605, 20500 |  |  | Carpenters [96 h] | 2006-09-14 | Task | 3 | 3 | 2007-07-31 | 2006-08-16 | 3 | 2006-08-17 | 2006-08-17 | 2 | 3 | 2006-08-16 | 2 | 2007-07-27 | 05 | Stud | E | CP |  |  |  |
| 20510 | East05 R/I Plumbing | 2d | 2007-05-07 | 2007-05-08 | 20610, 20500 |  |  | Plumbers [64 h] | 2006-09-14 | Task | 2 | 3 | 2007-08-01 | 2006-08-17 | 3 | 2006-08-17 | 2006-08-18 | 2 | 2 | 2006-08-16 | 2 | 2007-07-31 | 05 | R/I PB | E | PB |  |  |  |
| 20515 | East05 HVAC Ductwork | 2d | 2007-05-07 | 2007-05-08 | 20615, 20500 |  |  | HVAC Sheet Metal [64 h] | 2006-09-14 | Task | 2 | 3 | 2007-08-03 | 2006-08-18 | 3 | 2006-08-17 | 2006-08-21 | 2 | 2 | 2006-08-16 | 2 | 2007-08-02 | 05 | HVAC | E | HV |  |  |  |
| 20620 | East06 R/I Electric | 2d | 2007-05-07 | 2007-05-08 | 20605 |  |  | Electricians [64 h] | 2006-09-14 | Task | 2 | 3 | 2007-07-30 | 2006-08-30 | 3 | 2006-08-17 | 2006-08-31 | 2 | 2 | 2006-08-16 | 2 | 2007-07-27 | 06 | R/I Elec | E | EL |  |  |  |
| 20625 | East06 Plumbing Test | 1d | 2007-05-07 | 2007-05-07 | 20610 |  |  | Plumbers [16 h] | 2006-09-13 | Task | 1 | 1 | 2007-07-31 | 2006-08-31 | 2 | 2006-08-16 | 2006-08-31 | 1 | 1 | 2006-08-16 | 1 | 2007-07-31 | 06 | PB Test | E | PB |  |  |  |
| 20730 | East07 Drywall/2 & Finishes | 2d | 2007-05-07 | 2007-05-08 | 20725, 20720, 20715 |  |  | Carpenters [96 h] | 2006-09-14 | Task | 2 | 3 | 2007-08-01 | 2006-09-01 | 3 | 2006-08-17 | 2006-09-04 | 2 | 2 | 2006-08-16 | 2 | 2007-07-31 | 07 | Drywall | E | CP |  |  |  |
| 20835 | East08 Electric Fixtures | 2d | 2007-05-07 | 2007-05-08 | 20830 |  |  | Electricians [32 h] | 2006-09-14 | Task | 3 | 3 | 2007-08-02 | 2006-09-05 | 3 | 2006-08-17 | 2006-09-06 | 2 | 3 | 2006-08-16 | 2 | 2007-07-31 | 08 | Elec Fixt | E | EL |  |  |  |
| 20840 | East08 Plumbing Fixtures | 2d | 2007-05-07 | 2007-05-08 | 20830 |  |  | Plumbers [32 h] | 2006-09-14 | Task | 2 | 3 | 2007-08-01 | 2006-09-05 | 3 | 2006-08-17 | 2006-09-06 | 2 | 2 | 2006-08-16 | 2 | 2007-07-31 | 08 | PB Fixt | E | PB |  |  |  |
| 20845 | East08 HVAC Fixtures | 1d | 2007-05-07 | 2007-05-07 | 20830 |  |  | HVAC Sheet Metal [16 h] | 2006-09-13 | Task | 1 | 1 | 2007-07-31 | 2006-09-06 | 2 | 2006-08-16 | 2006-09-06 | 1 | 1 | 2006-08-16 | 1 | 2007-07-31 | 08 | HVAC | E | HV |  |  |  |
| 20950 | East09 Paint & Carpeting | 2d | 2007-05-07 | 2007-05-08 | 20945, 20940, 20935 |  |  | Subcontract Work [96 h] | 2006-09-14 | Task | 2 | 3 | 2007-08-02 | 2006-09-07 | 3 | 2006-08-17 | 2006-09-08 | 2 | 2 | 2006-08-16 | 2 | 2007-08-01 | 09 | Paint | E | SB |  |  |  |
| 1666 | West44 Affix Window Wall Frames Floors 41-44 | 6d | 2007-05-08 | 2007-05-15 | 1664, 1605, 1604, 1602, 1600, 1160, 401 |  |  | Iron Workers [288 h] | 2006-06-06 | Task | 5 | 8 | 2007-06-11 | 2006-06-02 | 8 | 2006-05-12 | 2006-06-09 | 6 | 5 | 2006-05-05 | 5 | 2007-06-05 | 44 | Frame | W | IW |  | 35 | (ID)303 (Link)FF[10] |
| 2645 | East33 Form/Pour Slab | 4d | 2007-05-08 | 2007-05-11 | 2640 |  |  | Carpenters [320 h] | 2006-04-27 | Task | 4 | 5 | 2007-06-04 | 2006-05-05 | 5 | 2006-05-10 | 2006-05-10 | 4 | 4 | 2006-05-05 | 3 | 2007-05-30 | 33 | Slab | E | CP | 10 | 24 |  |
| E005 | Event 005 - Window Connector Design Error - Requires 2X duration to install | 1d | 2007-05-08 | 2007-05-08 |  | start on or after 2007-05-08 | Standard |  |  |  | 24 |  | 2007-06-08 |  |  |  |  |  | 24 |  |  | 2007-05-08 |  |  |  |  |  | 15 |  |

| ID | Activity | Duration | Start | Finish | Predecessors | Resources | MEF | P3 Task Type | ADur | PESS | AFinish | Imported Late Start | MOD | Imported Early Finish | Imported Late Finish | MOST | ActDur | Imported Early Start | OPTD | AStart | LOC3 Segment | WTYP | LOC1 Tower | CRTY | LOC2 Floor | PL-1 |
| --- | --- | --- | --- | --- | --- | --- | --- | --- | --- | --- | --- | --- | --- | --- | --- | --- | --- | --- | --- | --- | --- | --- | --- | --- | --- | --- |
| 11005 | West10 Studs & Drywall/1 | 2d | 2007-05-09 | 2007-05-10 | 11105, 11000 | Carpenters [96 h] | 2006-08-07 | Task | 1 | 3 | 2007-08-21 | 2006-08-02 | 3 | 2006-07-06 | 2006-08-03 | 2 | 1 | 2006-07-05 | 2 | 2007-08-21 | 10 | Stud | W | CP |  |  |
| 11010 | West10 R/I Plumbing | 2d | 2007-05-09 | 2007-05-10 | 11110, 11000 | Plumbers [64 h] | 2006-08-07 | Task | 2 | 3 | 2007-08-21 | 2006-08-03 | 3 | 2006-07-06 | 2006-08-04 | 2 | 2 | 2006-07-05 | 2 | 2007-08-20 | 10 | R/I PB | W | PB |  |  |
| 11015 | West10 HVAC Ductwork | 2d | 2007-05-09 | 2007-05-10 | 11115, 11000 | HVAC Sheet Metal [64 h] | 2006-08-07 | Task | 2 | 3 | 2007-08-14 | 2006-08-04 | 3 | 2006-07-06 | 2006-08-07 | 2 | 2 | 2006-07-05 | 2 | 2007-08-13 | 10 | HVAC | W | HV |  |  |
| 11120 | West11 R/I Electric | 2d | 2007-05-09 | 2007-05-10 | 11105 | Electricians [64 h] | 2006-08-07 | Task | 2 | 3 | 2007-08-22 | 2006-08-30 | 3 | 2006-07-06 | 2006-08-31 | 2 | 2 | 2006-07-05 | 2 | 2007-08-21 |  | R/I Elec | W | EL | 11 |  |
| 11125 | West11 Plumbing Test | 1d | 2007-05-09 | 2007-05-09 | 11110 | Plumbers [16 h] | 2006-08-04 | Task | 1 | 1 | 2007-08-20 | 2006-08-31 | 2 | 2006-07-05 | 2006-08-31 | 1 | 1 | 2006-07-05 | 1 | 2007-08-20 |  | PB Test | W | PB | 11 |  |
| 11230 | West12 Drywall/2 & Finishes | 2d | 2007-05-09 | 2007-05-10 | 11225, 11220, 11215 | Carpenters [96 h] | 2006-08-07 | Task | 1 | 3 | 2007-08-21 | 2006-09-01 | 3 | 2006-07-06 | 2006-09-04 | 2 | 1 | 2006-07-05 | 2 | 2007-08-21 |  | Drywall | W | CP | 12 |  |
| 11335 | West13 Electric Fixtures | 2d | 2007-05-09 | 2007-05-10 | 11330 | Electricians [32 h] | 2006-08-07 | Task | 2 | 3 | 2007-08-22 | 2006-09-05 | 3 | 2006-07-06 | 2006-09-06 | 2 | 2 | 2006-07-05 | 2 | 2007-08-21 |  | Elec Fixt | W | EL | 13 |  |
| 11340 | West13 Plumbing Fixtures | 2d | 2007-05-09 | 2007-05-10 | 11330 | Plumbers [32 h] | 2006-08-07 | Task | 2 | 3 | 2007-08-22 | 2006-09-05 | 3 | 2006-07-06 | 2006-09-06 | 2 | 2 | 2006-07-05 | 2 | 2007-08-21 |  | PB Fixt | W | PB | 13 |  |
| 11345 | West13 HVAC Fixtures | 1d | 2007-05-09 | 2007-05-09 | 11330 | HVAC Sheet Metal [16 h] | 2006-08-04 | Task | 1 | 1 | 2007-08-21 | 2006-09-06 | 2 | 2006-07-05 | 2006-09-06 | 1 | 1 | 2006-07-05 | 1 | 2007-08-21 |  | HVAC | W | HV | 13 |  |
| 11450 | West14 Paint & Carpeting | 2d | 2007-05-09 | 2007-05-10 | 11445, 11440, 11435 | Subcontract Work [96 h] | 2006-08-07 | Task | 2 | 3 | 2007-08-22 | 2006-09-07 | 3 | 2006-07-06 | 2006-09-08 | 2 | 2 | 2006-07-05 | 2 | 2007-08-21 |  | Paint | W | SB | 14 |  |
| 20405 | East04 Studs & Drywall/1 | 2d | 2007-05-09 | 2007-05-10 | 20505, 20400 | Carpenters [96 h] | 2006-09-19 | Task | 3 | 3 | 2007-08-03 | 2006-08-18 | 3 | 2006-08-21 | 2006-08-21 | 2 | 3 | 2006-08-18 | 2 | 2007-08-01 |  | Stud | E | CP | 04 |  |
| 20410 | East04 R/I Plumbing | 2d | 2007-05-09 | 2007-05-10 | 20510, 20400 | Plumbers [64 h] | 2006-09-19 | Task | 3 | 3 | 2007-08-06 | 2006-08-21 | 3 | 2006-08-21 | 2006-08-22 | 2 | 3 | 2006-08-18 | 2 | 2007-08-02 |  | R/I PB | E | PB | 04 |  |
| 20415 | East04 HVAC Ductwork | 2d | 2007-05-09 | 2007-05-10 | 20515, 20400 | HVAC Sheet Metal [64 h] | 2006-09-19 | Task | 3 | 3 | 2007-08-08 | 2006-08-22 | 3 | 2006-08-21 | 2006-08-23 | 2 | 3 | 2006-08-18 | 2 | 2007-08-06 |  | HVAC | E | HV | 04 |  |
| 20520 | East05 R/I Electric | 2d | 2007-05-09 | 2007-05-10 | 20505 | Electricians [64 h] | 2006-09-19 | Task | 2 | 3 | 2007-08-02 | 2006-08-30 | 3 | 2006-08-21 | 2006-08-31 | 2 | 2 | 2006-08-18 | 2 | 2007-08-01 |  | R/I Elec | E | EL | 05 |  |
| 20525 | East05 Plumbing Test | 1d | 2007-05-09 | 2007-05-09 | 20510 | Plumbers [16 h] | 2006-09-18 | Task | 1 | 1 | 2007-08-02 | 2006-08-31 | 2 | 2006-08-18 | 2006-08-31 | 1 | 1 | 2006-08-18 | 1 | 2007-08-02 |  | PB Test | E | PB | 05 |  |
| 20630 | East06 Drywall/2 & Finishes | 2d | 2007-05-09 | 2007-05-10 | 20625, 20620, 20615 | Carpenters [96 h] | 2006-09-19 | Task | 1 | 3 | 2007-08-02 | 2006-09-01 | 3 | 2006-08-21 | 2006-09-04 | 2 | 1 | 2006-08-18 | 2 | 2007-08-02 |  | Drywall | E | CP | 06 |  |
| 20735 | East07 Electric Fixtures | 2d | 2007-05-09 | 2007-05-10 | 20730 | Electricians [32 h] | 2006-09-19 | Task | 2 | 3 | 2007-08-03 | 2006-09-05 | 3 | 2006-08-21 | 2006-09-06 | 2 | 2 | 2006-08-18 | 2 | 2007-08-02 |  | Elec Fixt | E | EL | 07 |  |
| 20740 | East07 Plumbing Fixtures | 2d | 2007-05-09 | 2007-05-10 | 20730 | Plumbers [32 h] | 2006-09-19 | Task | 2 | 3 | 2007-08-03 | 2006-09-05 | 3 | 2006-08-21 | 2006-09-06 | 2 | 2 | 2006-08-18 | 2 | 2007-08-02 |  | PB Fixt | E | PB | 07 |  |
| 20745 | East07 HVAC Fixtures | 1d | 2007-05-09 | 2007-05-09 | 20730 | HVAC Sheet Metal [16 h] | 2006-09-18 | Task | 1 | 1 | 2007-08-02 | 2006-09-06 | 2 | 2006-08-18 | 2006-09-06 | 1 | 1 | 2006-08-18 | 1 | 2007-08-02 |  | HVAC | E | HV | 07 |  |
| 20850 | East08 Paint & Carpeting | 2d | 2007-05-09 | 2007-05-10 | 20845, 20840, 20835 | Subcontract Work [96 h] | 2006-09-19 | Task | 2 | 3 | 2007-08-06 | 2006-09-07 | 3 | 2006-08-21 | 2006-09-08 | 2 | 2 | 2006-08-18 | 2 | 2007-08-03 |  | Paint | E | SB | 08 |  |
| 10905 | West09 Studs & Drywall/1 | 2d | 2007-05-11 | 2007-05-14 | 11005, 10900 | Carpenters [96 h] | 2006-08-10 | Task | 3 | 3 | 2007-08-24 | 2006-08-04 | 3 | 2006-07-10 | 2006-08-07 | 2 | 3 | 2006-07-07 | 2 | 2007-08-22 |  | Stud | W | CP | 09 |  |
| 10910 | West09 R/I Plumbing | 2d | 2007-05-11 | 2007-05-14 | 11010, 10900 | Plumbers [64 h] | 2006-08-10 | Task | 3 | 3 | 2007-08-24 | 2006-08-07 | 3 | 2006-07-10 | 2006-08-08 | 2 | 3 | 2006-07-07 | 2 | 2007-08-22 |  | R/I PB | W | PB | 09 |  |
| 10915 | West09 HVAC Ductwork | 2d | 2007-05-11 | 2007-05-14 | 11015, 10900 | HVAC Sheet Metal [64 h] | 2006-08-10 | Task | 2 | 3 | 2007-08-16 | 2006-08-08 | 3 | 2006-07-10 | 2006-08-09 | 2 | 2 | 2006-07-07 | 2 | 2007-08-15 |  | HVAC | W | HV | 09 |  |
| 11020 | West10 R/I Electric | 2d | 2007-05-11 | 2007-05-14 | 11005 | Electricians [64 h] | 2006-08-10 | Task | 2 | 3 | 2007-08-23 | 2006-08-30 | 3 | 2006-07-10 | 2006-08-31 | 2 | 2 | 2006-07-07 | 2 | 2007-08-22 | 10 | R/I Elec | W | EL |  |  |
| 11025 | West10 Plumbing Test | 1d | 2007-05-11 | 2007-05-11 | 11010 | Plumbers [16 h] | 2006-08-09 | Task | 1 | 1 | 2007-08-22 | 2006-08-31 | 2 | 2006-07-07 | 2006-08-31 | 1 | 1 | 2006-07-07 | 1 | 2007-08-22 | 10 | PB Test | W | PB |  |  |
| 11130 | West11 Drywall/2 & Finishes | 2d | 2007-05-11 | 2007-05-14 | 11125, 11120, 11115 | Carpenters [96 h] | 2006-08-10 | Task | 3 | 3 | 2007-08-27 | 2006-09-01 | 3 | 2006-07-10 | 2006-09-04 | 2 | 3 | 2006-07-07 | 2 | 2007-08-23 |  | Drywall | W | CP | 11 |  |
| 11235 | West12 Electric Fixtures | 2d | 2007-05-11 | 2007-05-14 | 11230 | Electricians [32 h] | 2006-08-10 | Task | 2 | 3 | 2007-08-23 | 2006-09-05 | 3 | 2006-07-10 | 2006-09-06 | 2 | 2 | 2006-07-07 | 2 | 2007-08-22 |  | Elec Fixt | W | EL | 12 |  |
| 11240 | West12 Plumbing Fixtures | 2d | 2007-05-11 | 2007-05-14 | 11230 | Plumbers [32 h] | 2006-08-10 | Task | 2 | 3 | 2007-08-23 | 2006-09-05 | 3 | 2006-07-10 | 2006-09-06 | 2 | 2 | 2006-07-07 | 2 | 2007-08-22 |  | PB Fixt | W | PB | 12 |  |
| 11245 | West12 HVAC Fixtures | 1d | 2007-05-11 | 2007-05-11 | 11230 | HVAC Sheet Metal [16 h] | 2006-08-09 | Task | 2 | 1 | 2007-08-23 | 2006-09-06 | 2 | 2006-07-07 | 2006-09-06 | 1 | 2 | 2006-07-07 | 1 | 2007-08-22 |  | HVAC | W | HV | 12 |  |
| 11350 | West13 Paint & Carpeting | 2d | 2007-05-11 | 2007-05-14 | 11345, 11340, 11335 | Subcontract Work [96 h] | 2006-08-10 | Task | 2 | 3 | 2007-08-24 | 2006-09-07 | 3 | 2006-07-10 | 2006-09-08 | 2 | 2 | 2006-07-07 | 2 | 2007-08-23 |  | Paint | W | SB | 13 |  |
| 20305 | East03 Studs & Drywall/1 | 2d | 2007-05-11 | 2007-05-14 | 20405, 20300 | Carpenters [96 h] | 2006-09-22 | Task | 3 | 3 | 2007-08-08 | 2006-08-22 | 3 | 2006-08-23 | 2006-08-23 | 2 | 3 | 2006-08-22 | 2 | 2007-08-06 |  | Stud | E | CP | 03 |  |
| 20310 | East03 R/I Plumbing | 2d | 2007-05-11 | 2007-05-14 | 20410, 20300 | Plumbers [64 h] | 2006-09-22 | Task | 2 | 3 | 2007-08-08 | 2006-08-23 | 3 | 2006-08-23 | 2006-08-24 | 2 | 2 | 2006-08-22 | 2 | 2007-08-07 |  | R/I PB | E | PB | 03 |  |
| 20315 | East03 HVAC Ductwork | 2d | 2007-05-11 | 2007-05-14 | 20415, 20300 | HVAC Sheet Metal [64 h] | 2006-09-22 | Task | 1 | 3 | 2007-08-09 | 2006-08-24 | 3 | 2006-08-23 | 2006-08-25 | 2 | 1 | 2006-08-22 | 2 | 2007-08-09 |  | HVAC | E | HV | 03 |  |
| 20420 | East04 R/I Electric | 2d | 2007-05-11 | 2007-05-14 | 20405 | Electricians [64 h] | 2006-09-22 | Task | 1 | 3 | 2007-08-06 | 2006-08-30 | 3 | 2006-08-23 | 2006-08-31 | 2 | 1 | 2006-08-22 | 2 | 2007-08-06 |  | R/I Elec | E | EL | 04 |  |
| 20425 | East04 Plumbing Test | 1d | 2007-05-11 | 2007-05-11 | 20410 | Plumbers [16 h] | 2006-09-21 | Task | 1 | 1 | 2007-08-07 | 2006-08-31 | 2 | 2006-08-22 | 2006-08-31 | 1 | 1 | 2006-08-22 | 1 | 2007-08-07 |  | PB Test | E | PB | 04 |  |
| 20530 | East05 Drywall/2 & Finishes | 2d | 2007-05-11 | 2007-05-14 | 20525, 20520, 20515 | Carpenters [96 h] | 2006-09-22 | Task | 2 | 3 | 2007-08-07 | 2006-09-01 | 3 | 2006-08-23 | 2006-09-04 | 2 | 2 | 2006-08-22 | 2 | 2007-08-06 |  | Drywall | E | CP | 05 |  |
| 20635 | East06 Electric Fixtures | 2d | 2007-05-11 | 2007-05-14 | 20630 | Electricians [32 h] | 2006-09-22 | Task | 3 | 3 | 2007-08-07 | 2006-09-05 | 3 | 2006-08-23 | 2006-09-06 | 2 | 3 | 2006-08-22 | 2 | 2007-08-03 |  | Elec Fixt | E | EL | 06 |  |
| 20640 | East06 Plumbing Fixtures | 2d | 2007-05-11 | 2007-05-14 | 20630 | Plumbers [32 h] | 2006-09-22 | Task | 2 | 3 | 2007-08-06 | 2006-09-05 | 3 | 2006-08-23 | 2006-09-06 | 2 | 2 | 2006-08-22 | 2 | 2007-08-03 |  | PB Fixt | E | PB | 06 |  |
| 20645 | East06 HVAC Fixtures | 1d | 2007-05-11 | 2007-05-11 | 20630 | HVAC Sheet Metal [16 h] | 2006-09-21 | Task | 1 | 1 | 2007-08-03 | 2006-09-06 | 2 | 2006-08-22 | 2006-09-06 | 1 | 1 | 2006-08-22 | 1 | 2007-08-03 |  | HVAC | E | HV | 06 |  |
| 20750 | East07 Paint & Carpeting | 2d | 2007-05-11 | 2007-05-14 | 20745, 20740, 20735 | Subcontract Work [96 h] | 2006-09-22 | Task | 2 | 3 | 2007-08-07 | 2006-09-07 | 3 | 2006-08-23 | 2006-09-08 | 2 | 2 | 2006-08-22 | 2 | 2007-08-06 |  | Paint | E | SB | 07 |  |
| 2660 | East34 Affix Window Wall Frames Floors 32-34 | 6d | 2007-05-14 | 2007-05-21 | 2564, 2645, 2640, 2635, 2150, 401 | Iron Workers [288 h] | 2006-05-09 | Task | 6 | 8 | 2007-06-12 | 2006-05-11 | 8 | 2006-05-18 | 2006-05-18 | 6 | 6 | 2006-05-11 | 5 | 2007-06-05 |  | Frame | E | IW | 34 | 26 |
| 10805 | West08 Studs & Drywall/1 | 2d | 2007-05-15 | 2007-05-16 | 10905, 10800 | Carpenters [96 h] | 2006-08-15 | Task | 2 | 3 | 2007-08-28 | 2006-08-08 | 3 | 2006-07-12 | 2006-08-09 | 2 | 2 | 2006-07-11 | 2 | 2007-08-27 |  | Stud | W | CP | 08 |  |
| 10810 | West08 R/I Plumbing | 2d | 2007-05-15 | 2007-05-16 | 10910, 10800 | Plumbers [64 h] | 2006-08-15 | Task | 3 | 3 | 2007-08-29 | 2006-08-09 | 3 | 2006-07-12 | 2006-08-10 | 2 | 3 | 2006-07-11 | 2 | 2007-08-27 |  | R/I PB | W | PB | 08 |  |
| 10815 | West08 HVAC Ductwork | 2d | 2007-05-15 | 2007-05-16 | 10915, 10800 | HVAC Sheet Metal [64 h] | 2006-08-15 | Task | 1 | 3 | 2007-08-17 | 2006-08-10 | 3 | 2006-07-12 | 2006-08-11 | 2 | 1 | 2006-07-11 | 2 | 2007-08-17 |  | HVAC | W | HV | 08 |  |
| 10920 | West09 R/I Electric | 2d | 2007-05-15 | 2007-05-16 | 10905 | Electricians [64 h] | 2006-08-15 | Task | 1 | 3 | 2007-08-27 | 2006-08-30 | 3 | 2006-07-12 | 2006-08-31 | 2 | 1 | 2006-07-11 | 2 | 2007-08-27 |  | R/I Elec | W | EL | 09 |  |
| 10925 | West09 Plumbing Test | 1d | 2007-05-15 | 2007-05-15 | 10910 | Plumbers [16 h] | 2006-08-14 | Task | 1 | 1 | 2007-08-27 | 2006-08-31 | 2 | 2006-07-11 | 2006-08-31 | 1 | 1 | 2006-07-11 | 1 | 2007-08-27 |  | PB Test | W | PB | 09 |  |
| 11030 | West10 Drywall/2 & Finishes | 2d | 2007-05-15 | 2007-05-16 | 11025, 11020, 11015 | Carpenters [96 h] | 2006-08-15 | Task | 3 | 3 | 2007-08-28 | 2006-09-01 | 3 | 2006-07-12 | 2006-09-04 | 2 | 3 | 2006-07-11 | 2 | 2007-08-24 | 10 | Drywall | W | CP |  |  |
| 11135 | West11 Electric Fixtures | 2d | 2007-05-15 | 2007-05-16 | 11130 | Electricians [32 h] | 2006-08-15 | Task | 2 | 3 | 2007-08-29 | 2006-09-05 | 3 | 2006-07-12 | 2006-09-06 | 2 | 2 | 2006-07-11 | 2 | 2007-08-28 |  | Elec Fixt | W | EL | 11 |  |
| 11140 | West11 Plumbing Fixtures | 2d | 2007-05-15 | 2007-05-16 | 11130 | Plumbers [32 h] | 2006-08-15 | Task | 2 | 3 | 2007-08-29 | 2006-09-05 | 3 | 2006-07-12 | 2006-09-06 | 2 | 2 | 2006-07-11 | 2 | 2007-08-28 |  | PB Fixt | W | PB | 11 |  |
| 11145 | West11 HVAC Fixtures | 1d | 2007-05-15 | 2007-05-15 | 11130 | HVAC Sheet Metal [16 h] | 2006-08-14 | Task | 1 | 1 | 2007-08-28 | 2006-09-06 | 2 | 2006-07-11 | 2006-09-06 | 1 | 1 | 2006-07-11 | 1 | 2007-08-28 |  | HVAC | W | HV | 11 |  |
| 11250 | West12 Paint & Carpeting | 2d | 2007-05-15 | 2007-05-16 | 11245, 11240, 11235 | Subcontract Work [96 h] | 2006-08-15 | Task | 1 | 3 | 2007-08-24 | 2006-09-07 | 3 | 2006-07-12 | 2006-09-08 | 2 | 1 | 2006-07-11 | 2 | 2007-08-24 |  | Paint | W | SB | 12 |  |
| 20205 | East02 Studs & Drywall/1 | 2d | 2007-05-15 | 2007-05-16 | 20305, 20200 | Carpenters [96 h] | 2006-09-27 | Task | 2 | 3 | 2007-08-10 | 2006-08-24 | 3 | 2006-08-25 | 2006-08-25 | 2 | 2 | 2006-08-24 | 2 | 2007-08-09 |  | Stud | E | CP | 02 |  |
| 20210 | East02 R/I Plumbing | 2d | 2007-05-15 | 2007-05-16 | 20310, 20200 | Plumbers [64 h] | 2006-09-27 | Task | 2 | 3 | 2007-08-10 | 2006-08-25 | 3 | 2006-08-25 | 2006-08-28 | 2 | 2 | 2006-08-24 | 2 | 2007-08-09 |  | R/I PB | E | PB | 02 |  |
| 20215 | East02 HVAC Ductwork | 2d | 2007-05-15 | 2007-05-16 | 20315, 20200 | HVAC Sheet Metal [64 h] | 2006-09-27 | Task | 3 | 3 | 2007-08-14 | 2006-08-28 | 3 | 2006-08-25 | 2006-08-29 | 2 | 3 | 2006-08-24 | 2 | 2007-08-10 |  | HVAC | E | HV | 02 |  |
| 20320 | East03 R/I Electric | 2d | 2007-05-15 | 2007-05-16 | 20305 | Electricians [64 h] | 2006-09-27 | Task | 2 | 3 | 2007-08-10 | 2006-08-30 | 3 | 2006-08-25 | 2006-08-31 | 2 | 2 | 2006-08-24 | 2 | 2007-08-09 |  | R/I Elec | E | EL | 03 |  |
| 20325 | East03 Plumbing Test | 1d | 2007-05-15 | 2007-05-15 | 20310 | Plumbers [16 h] | 2006-09-26 | Task | 2 | 1 | 2007-08-10 | 2006-08-31 | 2 | 2006-08-24 | 2006-08-31 | 1 | 2 | 2006-08-24 | 1 | 2007-08-09 |  | PB Test | E | PB | 03 |  |
| 20430 | East04 Drywall/2 & Finishes | 2d | 2007-05-15 | 2007-05-16 | 20425, 20420, 20415 | Carpenters [96 h] | 2006-09-27 | Task | 2 | 3 | 2007-08-10 | 2006-09-01 | 3 | 2006-08-25 | 2006-09-04 | 2 | 2 | 2006-08-24 | 2 | 2007-08-09 |  | Drywall | E | CP | 04 |  |
| 20535 | East05 Electric Fixtures | 2d | 2007-05-15 | 2007-05-16 | 20530 | Electricians [32 h] | 2006-09-27 | Task | 2 | 3 | 2007-08-09 | 2006-09-05 | 3 | 2006-08-25 | 2006-09-06 | 2 | 2 | 2006-08-24 | 2 | 2007-08-08 |  | Elec Fixt | E | EL | 05 |  |
| 20540 | East05 Plumbing Fixtures | 2d | 2007-05-15 | 2007-05-16 | 20530 | Plumbers [32 h] | 2006-09-27 | Task | 2 | 3 | 2007-08-09 | 2006-09-05 | 3 | 2006-08-25 | 2006-09-06 | 2 | 2 | 2006-08-24 | 2 | 2007-08-08 |  | PB Fixt | E | PB | 05 |  |
| 20545 | East05 HVAC Fixtures | 1d | 2007-05-15 | 2007-05-15 | 20530 | HVAC Sheet Metal [16 h] | 2006-09-26 | Task | 2 | 1 | 2007-08-09 | 2006-09-06 | 2 | 2006-08-24 | 2006-09-06 | 1 | 2 | 2006-08-24 | 1 | 2007-08-08 |  | HVAC | E | HV | 05 |  |
| 20650 | East06 Paint & Carpeting | 2d | 2007-05-15 | 2007-05-16 | 20645, 20640, 20635 | Subcontract Work [96 h] | 2006-09-27 | Task | 2 | 3 | 2007-08-09 | 2006-09-07 | 3 | 2006-08-25 | 2006-09-08 | 2 | 2 | 2006-08-24 | 2 | 2007-08-08 |  | Paint | E | SB | 06 |  |
| 10705 | West07 Studs & Drywall/1 | 2d | 2007-05-17 | 2007-05-18 | 10805, 10700 | Carpenters [96 h] | 2006-08-18 | Task | 2 | 3 | 2007-08-30 | 2006-08-10 | 3 | 2006-07-14 | 2006-08-11 | 2 | 2 | 2006-07-13 | 2 | 2007-08-29 |  | Stud | W | CP | 07 |  |
| 10710 | West07 R/I Plumbing | 2d | 2007-05-17 | 2007-05-18 | 10810, 10700 | Plumbers [64 h] | 2006-08-18 | Task | 3 | 3 | 2007-09-03 | 2006-08-11 | 3 | 2006-07-14 | 2006-08-14 | 2 | 3 | 2006-07-13 | 2 | 2007-08-30 |  | R/I PB | W | PB | 07 |  |
| 10715 | West07 HVAC Ductwork | 2d | 2007-05-17 | 2007-05-18 | 10815, 10700 | HVAC Sheet Metal [64 h] | 2006-08-18 | Task | 3 | 3 | 2007-08-22 | 2006-08-14 | 3 | 2006-07-14 | 2006-08-15 | 2 | 3 | 2006-07-13 | 2 | 2007-08-20 |  | HVAC | W | HV | 07 |  |
| 10820 | West08 R/I Electric | 2d | 2007-05-17 | 2007-05-18 | 10805 | Electricians [64 h] | 2006-08-18 | Task | 2 | 3 | 2007-08-30 | 2006-08-30 | 3 | 2006-07-14 | 2006-08-31 | 2 | 2 | 2006-07-13 | 2 | 2007-08-29 |  | R/I Elec | W | EL | 08 |  |
| 10825 | West08 Plumbing Test | 1d | 2007-05-17 | 2007-05-17 | 10810 | Plumbers [16 h] | 2006-08-17 | Task | 1 | 1 | 2007-08-30 | 2006-08-31 | 2 | 2006-07-13 | 2006-08-31 | 1 | 1 | 2006-07-13 | 1 | 2007-08-30 |  | PB Test | W | PB | 08 |  |
| 10930 | West09 Drywall/2 & Finishes | 2d | 2007-05-17 | 2007-05-18 | 10925, 10920, 10915 | Carpenters [96 h] | 2006-08-18 | Task | 2 | 3 | 2007-08-29 | 2006-09-01 | 3 | 2006-07-14 | 2006-09-04 | 2 | 2 | 2006-07-13 | 2 | 2007-08-28 |  | Drywall | W | CP | 09 |  |
| 11035 | West10 Electric Fixtures | 2d | 2007-05-17 | 2007-05-18 | 11030 | Electricians [32 h] | 2006-08-18 | Task | 2 | 3 | 2007-08-30 | 2006-09-05 | 3 | 2006-07-14 | 2006-09-06 | 2 | 2 | 2006-07-13 | 2 | 2007-08-29 | 10 | Elec Fixt | W | EL |  |  |
| 11040 | West10 Plumbing Fixtures | 2d | 2007-05-17 | 2007-05-18 | 11030 | Plumbers [32 h] | 2006-08-18 | Task | 2 | 3 | 2007-08-30 | 2006-09-05 | 3 | 2006-07-14 | 2006-09-06 | 2 | 2 | 2006-07-13 | 2 | 2007-08-29 | 10 | PB Fixt | W | PB |  |  |
| 11045 | West10 HVAC Fixtures | 1d | 2007-05-17 | 2007-05-17 | 11030 | HVAC Sheet Metal [16 h] | 2006-08-17 | Task | 1 | 1 | 2007-08-29 | 2006-09-06 | 2 | 2006-07-13 | 2006-09-06 | 1 | 1 | 2006-07-13 | 1 | 2007-08-29 | 10 | HVAC | W | HV |  |  |

| ID | Activity | Duration | Start | Finish | Predecessors | Constraint | Resources | MEF | P3 Task Type | ADur | PESS | AFinish | Imported Late Start | MOD | Imported Early Finish | Imported Late Finish | MOST | ActDur | Imported Early Start | OPTD | AStart | LOC2 Floor | WTYP | LOC1 Tower | CRTY | LOC3 Segment | PL-1 | Opened Ended Tasks | Constraints |
| --- | --- | --- | --- | --- | --- | --- | --- | --- | --- | --- | --- | --- | --- | --- | --- | --- | --- | --- | --- | --- | --- | --- | --- | --- | --- | --- | --- | --- | --- |
| 11150 | West11 Paint & Carpeting | 2d | 2007-05-17 | 2007-05-18 | 11145, 11140, 11135 |  | Subcontract Work [96 h] | 2006-08-18 | Task | 3 | 3 | 2007-09-03 | 2006-09-07 | 3 | 2006-07-14 | 2006-09-08 | 2 | 3 | 2006-07-13 | 2 | 2007-08-30 | 11 | Paint | W | SB |  |  |  |  |
| 20105 | EastCL Studs & Drywall/1 | 2d | 2007-05-17 | 2007-05-18 | 20205, 20100 |  | Carpenters [96 h] | 2006-10-02 | Task | 2 | 3 | 2007-08-14 | 2006-08-28 | 3 | 2006-08-29 | 2006-08-29 | 2 | 2 | 2006-08-28 | 2 | 2007-08-13 | CL | Stud | E | CP |  |  |  |  |
| 20110 | EastCL R/I Plumbing | 2d | 2007-05-17 | 2007-05-18 | 20210, 20100 |  | Plumbers [64 h] | 2006-10-02 | Task | 2 | 3 | 2007-08-14 | 2006-08-29 | 3 | 2006-08-29 | 2006-08-30 | 2 | 2 | 2006-08-28 | 2 | 2007-08-13 | CL | R/I PB | E | PB |  |  |  |  |
| 20115 | EastCL HVAC Ductwork | 2d | 2007-05-17 | 2007-05-18 | 20215, 20100 |  | HVAC Sheet Metal [64 h] | 2006-10-02 | Task | 2 | 3 | 2007-08-16 | 2006-08-30 | 3 | 2006-08-29 | 2006-08-31 | 2 | 2 | 2006-08-28 | 2 | 2007-08-15 | CL | HVAC | E | HV |  |  |  |  |
| 20220 | East02 R/I Electric | 2d | 2007-05-17 | 2007-05-18 | 20205 |  | Electricians [64 h] | 2006-10-02 | Task | 2 | 3 | 2007-08-14 | 2006-08-30 | 3 | 2006-08-29 | 2006-08-31 | 2 | 2 | 2006-08-28 | 2 | 2007-08-13 | 02 | R/I Elec | E | EL |  |  |  |  |
| 20225 | East02 Plumbing Test | 1d | 2007-05-17 | 2007-05-17 | 20210 |  | Plumbers [16 h] | 2006-09-29 | Task | 1 | 1 | 2007-08-13 | 2006-08-31 | 2 | 2006-08-28 | 2006-08-31 | 1 | 1 | 2006-08-28 | 1 | 2007-08-13 | 02 | PB Test | E | PB |  |  |  |  |
| 20330 | East03 Drywall/2 & Finishes | 2d | 2007-05-17 | 2007-05-18 | 20325, 20320, 20315 |  | Carpenters [96 h] | 2006-10-02 | Task | 1 | 3 | 2007-08-13 | 2006-09-01 | 3 | 2006-08-29 | 2006-09-04 | 2 | 1 | 2006-08-28 | 2 | 2007-08-13 | 03 | Drywall | E | CP |  |  |  |  |
| 20435 | East04 Electric Fixtures | 2d | 2007-05-17 | 2007-05-18 | 20430 |  | Electricians [32 h] | 2006-10-02 | Task | 2 | 3 | 2007-08-14 | 2006-09-05 | 3 | 2006-08-29 | 2006-09-06 | 2 | 2 | 2006-08-28 | 2 | 2007-08-13 | 04 | Elec Fixt | E | EL |  |  |  |  |
| 20440 | East04 Plumbing Fixtures | 2d | 2007-05-17 | 2007-05-18 | 20430 |  | Plumbers [32 h] | 2006-10-02 | Task | 2 | 3 | 2007-08-14 | 2006-09-05 | 3 | 2006-08-29 | 2006-09-06 | 2 | 2 | 2006-08-28 | 2 | 2007-08-13 | 04 | PB Fixt | E | PB |  |  |  |  |
| 20445 | East04 HVAC Fixtures | 1d | 2007-05-17 | 2007-05-17 | 20430 |  | HVAC Sheet Metal [16 h] | 2006-09-29 | Task | 1 | 1 | 2007-08-13 | 2006-09-06 | 2 | 2006-08-28 | 2006-09-06 | 1 | 1 | 2006-08-28 | 1 | 2007-08-13 | 04 | HVAC | E | HV |  |  |  |  |
| 20550 | East05 Paint & Carpeting | 2d | 2007-05-17 | 2007-05-18 | 20545, 20540, 20535 |  | Subcontract Work [96 h] | 2006-10-02 | Task | 2 | 3 | 2007-08-13 | 2006-09-07 | 3 | 2006-08-29 | 2006-09-08 | 2 | 2 | 2006-08-28 | 2 | 2007-08-10 | 05 | Paint | E | SB |  |  |  |  |
| 10605 | West06 Studs & Drywall/1 | 2d | 2007-05-21 | 2007-05-22 | 10705, 10600 |  | Carpenters [96 h] | 2006-08-23 | Task | 3 | 3 | 2007-09-04 | 2006-08-14 | 3 | 2006-07-18 | 2006-08-15 | 2 | 3 | 2006-07-17 | 2 | 2007-08-31 | 06 | Stud | W | CP |  |  |  |  |
| 10610 | West06 R/I Plumbing | 2d | 2007-05-21 | 2007-05-22 | 10710, 10600 |  | Plumbers [64 h] | 2006-08-23 | Task | 1 | 3 | 2007-09-04 | 2006-08-15 | 3 | 2006-07-18 | 2006-08-16 | 2 | 1 | 2006-07-17 | 2 | 2007-09-04 | 06 | R/I PB | W | PB |  |  |  |  |
| 10615 | West06 HVAC Ductwork | 2d | 2007-05-21 | 2007-05-22 | 10715, 10600 |  | HVAC Sheet Metal [64 h] | 2006-08-23 | Task | 2 | 3 | 2007-08-24 | 2006-08-16 | 3 | 2006-07-18 | 2006-08-17 | 2 | 2 | 2006-07-17 | 2 | 2007-08-23 | 06 | HVAC | W | HV |  |  |  |  |
| 10720 | West07 R/I Electric | 2d | 2007-05-21 | 2007-05-22 | 10705 |  | Electricians [64 h] | 2006-08-23 | Task | 1 | 3 | 2007-08-31 | 2006-08-30 | 3 | 2006-07-18 | 2006-08-31 | 2 | 1 | 2006-07-17 | 2 | 2007-08-31 | 07 | R/I Elec | W | EL |  |  |  |  |
| 10725 | West07 Plumbing Test | 1d | 2007-05-21 | 2007-05-21 | 10710 |  | Plumbers [16 h] | 2006-08-22 | Task | 1 | 1 | 2007-09-04 | 2006-08-31 | 2 | 2006-07-17 | 2006-08-31 | 1 | 1 | 2006-07-17 | 1 | 2007-09-04 | 07 | PB Test | W | PB |  |  |  |  |
| 10830 | West08 Drywall/2 & Finishes | 2d | 2007-05-21 | 2007-05-22 | 10825, 10820, 10815 |  | Carpenters [96 h] | 2006-08-23 | Task | 2 | 3 | 2007-09-03 | 2006-09-01 | 3 | 2006-07-18 | 2006-09-04 | 2 | 2 | 2006-07-17 | 2 | 2007-08-31 | 08 | Drywall | W | CP |  |  |  |  |
| 10935 | West09 Electric Fixtures | 2d | 2007-05-21 | 2007-05-22 | 10930 |  | Electricians [32 h] | 2006-08-23 | Task | 2 | 3 | 2007-08-31 | 2006-09-05 | 3 | 2006-07-18 | 2006-09-06 | 2 | 2 | 2006-07-17 | 2 | 2007-08-30 | 09 | Elec Fixt | W | EL |  |  |  |  |
| 10940 | West09 Plumbing Fixtures | 2d | 2007-05-21 | 2007-05-22 | 10930 |  | Plumbers [32 h] | 2006-08-23 | Task | 2 | 3 | 2007-08-31 | 2006-09-05 | 3 | 2006-07-18 | 2006-09-06 | 2 | 2 | 2006-07-17 | 2 | 2007-08-30 | 09 | PB Fixt | W | PB |  |  |  |  |
| 10945 | West09 HVAC Fixtures | 1d | 2007-05-21 | 2007-05-21 | 10930 |  | HVAC Sheet Metal [16 h] | 2006-08-22 | Task | 1 | 1 | 2007-08-30 | 2006-09-06 | 2 | 2006-07-17 | 2006-09-06 | 1 | 1 | 2006-07-17 | 1 | 2007-08-30 | 09 | HVAC | W | HV |  |  |  |  |
| 11050 | West10 Paint & Carpeting | 2d | 2007-05-21 | 2007-05-22 | 11045, 11040, 11035 |  | Subcontract Work [96 h] | 2006-08-23 | Task | 2 | 3 | 2007-09-03 | 2006-09-07 | 3 | 2006-07-18 | 2006-09-08 | 2 | 2 | 2006-07-17 | 2 | 2007-08-31 |  | Paint | W | SB | 10 |  |  |  |
| 20120 | EastCL R/I Electric | 2d | 2007-05-21 | 2007-05-22 | 20105 |  | Electricians [64 h] | 2006-10-05 | Task | 2 | 3 | 2007-08-16 | 2006-08-30 | 3 | 2006-08-31 | 2006-08-31 | 2 | 2 | 2006-08-30 | 2 | 2007-08-15 | CL | R/I Elec | E | EL |  |  |  |  |
| 20125 | EastCL Plumbing Test | 1d | 2007-05-21 | 2007-05-21 | 20110 |  | Plumbers [16 h] | 2006-10-04 | Task | 1 | 1 | 2007-08-15 | 2006-08-31 | 2 | 2006-08-30 | 2006-08-31 | 1 | 1 | 2006-08-30 | 1 | 2007-08-15 | CL | PB Test | E | PB |  |  |  |  |
| 20230 | East02 Drywall/2 & Finishes | 2d | 2007-05-21 | 2007-05-22 | 20225, 20220, 20215 |  | Carpenters [96 h] | 2006-10-05 | Task | 3 | 3 | 2007-08-17 | 2006-09-01 | 3 | 2006-08-31 | 2006-09-04 | 2 | 3 | 2006-08-30 | 2 | 2007-08-15 | 02 | Drywall | E | CP |  |  |  |  |
| 20335 | East03 Electric Fixtures | 2d | 2007-05-21 | 2007-05-22 | 20330 |  | Electricians [32 h] | 2006-10-05 | Task | 1 | 3 | 2007-08-14 | 2006-09-05 | 3 | 2006-08-31 | 2006-09-06 | 2 | 1 | 2006-08-30 | 2 | 2007-08-14 | 03 | Elec Fixt | E | EL |  |  |  |  |
| 20340 | East03 Plumbing Fixtures | 2d | 2007-05-21 | 2007-05-22 | 20330 |  | Plumbers [32 h] | 2006-10-05 | Task | 2 | 3 | 2007-08-15 | 2006-09-05 | 3 | 2006-08-31 | 2006-09-06 | 2 | 2 | 2006-08-30 | 2 | 2007-08-14 | 03 | PB Fixt | E | PB |  |  |  |  |
| 20345 | East03 HVAC Fixtures | 1d | 2007-05-21 | 2007-05-21 | 20330 |  | HVAC Sheet Metal [16 h] | 2006-10-04 | Task | 2 | 1 | 2007-08-15 | 2006-09-06 | 2 | 2006-08-30 | 2006-09-06 | 1 | 2 | 2006-08-30 | 1 | 2007-08-14 | 03 | HVAC | E | HV |  |  |  |  |
| 20450 | East04 Paint & Carpeting | 2d | 2007-05-21 | 2007-05-22 | 20445, 20440, 20435 |  | Subcontract Work [96 h] | 2006-10-05 | Task | 2 | 3 | 2007-08-16 | 2006-09-07 | 3 | 2006-08-31 | 2006-09-08 | 2 | 2 | 2006-08-30 | 2 | 2007-08-15 | 04 | Paint | E | SB |  |  |  |  |
| 2662 | East37 Affix Window Wall Frames Floors 35-37 | 5d | 2007-05-22 | 2007-05-28 | 2660, 2635, 2630, 2625, 2620, 401 |  | Iron Workers [240 h] | 2006-05-17 | Task | 4 | 6 | 2007-06-18 | 2006-05-19 | 6 | 2006-05-25 | 2006-05-25 | 5 | 4 | 2006-05-19 | 4 | 2007-06-13 | 37 | Frame | E | IW |  | 26 |  |  |
| 10505 | West05 Studs & Drywall/1 | 2d | 2007-05-23 | 2007-05-24 | 10605, 10500 |  | Carpenters [96 h] | 2006-08-28 | Task | 2 | 3 | 2007-09-06 | 2006-08-16 | 3 | 2006-07-20 | 2006-08-17 | 2 | 2 | 2006-07-19 | 2 | 2007-09-05 | 05 | Stud | W | CP |  |  |  |  |
| 10510 | West05 R/I Plumbing | 2d | 2007-05-23 | 2007-05-24 | 10610, 10500 |  | Plumbers [64 h] | 2006-08-28 | Task | 2 | 3 | 2007-09-06 | 2006-08-17 | 3 | 2006-07-20 | 2006-08-18 | 2 | 2 | 2006-07-19 | 2 | 2007-09-05 | 05 | R/I PB | W | PB |  |  |  |  |
| 10515 | West05 HVAC Ductwork | 2d | 2007-05-23 | 2007-05-24 | 10615, 10500 |  | HVAC Sheet Metal [64 h] | 2006-08-28 | Task | 2 | 3 | 2007-08-28 | 2006-08-18 | 3 | 2006-07-20 | 2006-08-21 | 2 | 2 | 2006-07-19 | 2 | 2007-08-27 | 05 | HVAC | W | HV |  |  |  |  |
| 10620 | West06 R/I Electric | 2d | 2007-05-23 | 2007-05-24 | 10605 |  | Electricians [64 h] | 2006-08-28 | Task | 1 | 3 | 2007-09-05 | 2006-08-30 | 3 | 2006-07-20 | 2006-08-31 | 2 | 1 | 2006-07-19 | 2 | 2007-09-05 | 06 | R/I Elec | W | EL |  |  |  |  |
| 10625 | West06 Plumbing Test | 1d | 2007-05-23 | 2007-05-23 | 10610 |  | Plumbers [16 h] | 2006-08-25 | Task | 1 | 1 | 2007-09-05 | 2006-08-31 | 2 | 2006-07-19 | 2006-08-31 | 1 | 1 | 2006-07-19 | 1 | 2007-09-05 | 06 | PB Test | W | PB |  |  |  |  |
| 10730 | West07 Drywall/2 & Finishes | 2d | 2007-05-23 | 2007-05-24 | 10725, 10720, 10715 |  | Carpenters [96 h] | 2006-08-28 | Task | 2 | 3 | 2007-09-06 | 2006-09-01 | 3 | 2006-07-20 | 2006-09-04 | 2 | 2 | 2006-07-19 | 2 | 2007-09-05 | 07 | Drywall | W | CP |  |  |  |  |
| 10835 | West08 Electric Fixtures | 2d | 2007-05-23 | 2007-05-24 | 10830 |  | Electricians [32 h] | 2006-08-28 | Task | 2 | 3 | 2007-09-05 | 2006-09-05 | 3 | 2006-07-20 | 2006-09-06 | 2 | 2 | 2006-07-19 | 2 | 2007-09-04 | 08 | Elec Fixt | W | EL |  |  |  |  |
| 10840 | West08 Plumbing Fixtures | 2d | 2007-05-23 | 2007-05-24 | 10830 |  | Plumbers [32 h] | 2006-08-28 | Task | 2 | 3 | 2007-09-05 | 2006-09-05 | 3 | 2006-07-20 | 2006-09-06 | 2 | 2 | 2006-07-19 | 2 | 2007-09-04 | 08 | PB Fixt | W | PB |  |  |  |  |
| 10845 | West08 HVAC Fixtures | 1d | 2007-05-23 | 2007-05-23 | 10830 |  | HVAC Sheet Metal [16 h] | 2006-08-25 | Task | 1 | 1 | 2007-09-04 | 2006-09-06 | 2 | 2006-07-19 | 2006-09-06 | 1 | 1 | 2006-07-19 | 1 | 2007-09-04 | 08 | HVAC | W | HV |  |  |  |  |
| 10950 | West09 Paint & Carpeting | 2d | 2007-05-23 | 2007-05-24 | 10945, 10940, 10935 |  | Subcontract Work [96 h] | 2006-08-28 | Task | 2 | 3 | 2007-09-04 | 2006-09-07 | 3 | 2006-07-20 | 2006-09-08 | 2 | 2 | 2006-07-19 | 2 | 2007-09-03 | 09 | Paint | W | SB |  |  |  |  |
| 20130 | EastCL Drywall/2 & Finishes | 2d | 2007-05-23 | 2007-05-24 | 20125, 20120, 20115 |  | Carpenters [96 h] | 2006-10-10 | Task | 2 | 3 | 2007-08-20 | 2006-09-01 | 3 | 2006-09-04 | 2006-09-04 | 2 | 2 | 2006-09-01 | 2 | 2007-08-17 | CL | Drywall | E | CP |  |  |  |  |
| 20235 | East02 Electric Fixtures | 2d | 2007-05-23 | 2007-05-24 | 20230 |  | Electricians [32 h] | 2006-10-10 | Task | 2 | 3 | 2007-08-21 | 2006-09-05 | 3 | 2006-09-04 | 2006-09-06 | 2 | 2 | 2006-09-01 | 2 | 2007-08-20 | 02 | Elec Fixt | E | EL |  |  |  |  |
| 20240 | East02 Plumbing Fixtures | 2d | 2007-05-23 | 2007-05-24 | 20230 |  | Plumbers [32 h] | 2006-10-10 | Task | 1 | 3 | 2007-08-20 | 2006-09-05 | 3 | 2006-09-04 | 2006-09-06 | 2 | 1 | 2006-09-01 | 2 | 2007-08-20 | 02 | PB Fixt | E | PB |  |  |  |  |
| 20245 | East02 HVAC Fixtures | 1d | 2007-05-23 | 2007-05-23 | 20230 |  | HVAC Sheet Metal [16 h] | 2006-10-09 | Task | 1 | 1 | 2007-08-20 | 2006-09-06 | 2 | 2006-09-01 | 2006-09-06 | 1 | 1 | 2006-09-01 | 1 | 2007-08-20 | 02 | HVAC | E | HV |  |  |  |  |
| 20350 | East03 Paint & Carpeting | 2d | 2007-05-23 | 2007-05-24 | 20345, 20340, 20335 |  | Subcontract Work [96 h] | 2006-10-10 | Task | 2 | 3 | 2007-08-17 | 2006-09-07 | 3 | 2006-09-04 | 2006-09-08 | 2 | 2 | 2006-09-01 | 2 | 2007-08-16 | 03 | Paint | E | SB |  |  |  |  |
| E006 | Event 006 - Skybridge Window Frame Refit / Refab | 1d | 2007-05-23 | 2007-05-23 |  | start on or after 2007-05-23 |  |  |  | 11 |  | 2007-06-06 |  |  |  |  |  | 11 |  |  | 2007-05-23 |  |  |  |  |  | 15 | No predecessors | (Type)Finish on or after (Date)6/6/2007 9:00:00 AM |
| 10405 | West04 Studs & Drywall/1 | 2d | 2007-05-25 | 2007-05-28 | 10505, 10400 |  | Carpenters [96 h] | 2006-08-31 | Task | 1 | 3 | 2007-09-07 | 2006-08-18 | 3 | 2006-07-24 | 2006-08-21 | 2 | 1 | 2006-07-21 | 2 | 2007-09-07 | 04 | Stud | W | CP |  |  |  |  |
| 10410 | West04 R/I Plumbing | 2d | 2007-05-25 | 2007-05-28 | 10510, 10400 |  | Plumbers [64 h] | 2006-08-31 | Task | 2 | 3 | 2007-09-10 | 2006-08-21 | 3 | 2006-07-24 | 2006-08-22 | 2 | 2 | 2006-07-21 | 2 | 2007-09-07 | 04 | R/I PB | W | PB |  |  |  |  |
| 10415 | West04 HVAC Ductwork | 2d | 2007-05-25 | 2007-05-28 | 10515, 10400 |  | HVAC Sheet Metal [64 h] | 2006-08-31 | Task | 2 | 3 | 2007-08-30 | 2006-08-22 | 3 | 2006-07-24 | 2006-08-23 | 2 | 2 | 2006-07-21 | 2 | 2007-08-29 | 04 | HVAC | W | HV |  |  |  |  |
| 10520 | West05 R/I Electric | 2d | 2007-05-25 | 2007-05-28 | 10505 |  | Electricians [64 h] | 2006-08-31 | Task | 1 | 3 | 2007-09-07 | 2006-08-30 | 3 | 2006-07-24 | 2006-08-31 | 2 | 1 | 2006-07-21 | 2 | 2007-09-07 | 05 | R/I Elec | W | EL |  |  |  |  |
| 10525 | West05 Plumbing Test | 1d | 2007-05-25 | 2007-05-25 | 10510 |  | Plumbers [16 h] | 2006-08-30 | Task | 1 | 1 | 2007-09-07 | 2006-08-31 | 2 | 2006-07-21 | 2006-08-31 | 1 | 1 | 2006-07-21 | 1 | 2007-09-07 | 05 | PB Test | W | PB |  |  |  |  |
| 10630 | West06 Drywall/2 & Finishes | 2d | 2007-05-25 | 2007-05-28 | 10625, 10620, 10615 |  | Carpenters [96 h] | 2006-08-31 | Task | 2 | 3 | 2007-09-07 | 2006-09-01 | 3 | 2006-07-24 | 2006-09-04 | 2 | 2 | 2006-07-21 | 2 | 2007-09-06 | 06 | Drywall | W | CP |  |  |  |  |
| 10735 | West07 Electric Fixtures | 2d | 2007-05-25 | 2007-05-28 | 10730 |  | Electricians [32 h] | 2006-08-31 | Task | 1 | 3 | 2007-09-07 | 2006-09-05 | 3 | 2006-07-24 | 2006-09-06 | 2 | 1 | 2006-07-21 | 2 | 2007-09-07 | 07 | Elec Fixt | W | EL |  |  |  |  |
| 10740 | West07 Plumbing Fixtures | 2d | 2007-05-25 | 2007-05-28 | 10730 |  | Plumbers [32 h] | 2006-08-31 | Task | 3 | 3 | 2007-09-11 | 2006-09-05 | 3 | 2006-07-24 | 2006-09-06 | 2 | 3 | 2006-07-21 | 2 | 2007-09-07 | 07 | PB Fixt | W | PB |  |  |  |  |
| 10745 | West07 HVAC Fixtures | 1d | 2007-05-25 | 2007-05-25 | 10730 |  | HVAC Sheet Metal [16 h] | 2006-08-30 | Task | 1 | 1 | 2007-09-07 | 2006-09-06 | 2 | 2006-07-21 | 2006-09-06 | 1 | 1 | 2006-07-21 | 1 | 2007-09-07 | 07 | HVAC | W | HV |  |  |  |  |
| 10850 | West08 Paint & Carpeting | 2d | 2007-05-25 | 2007-05-28 | 10845, 10840, 10835 |  | Subcontract Work [96 h] | 2006-08-31 | Task | 2 | 3 | 2007-09-07 | 2006-09-07 | 3 | 2006-07-24 | 2006-09-08 | 2 | 2 | 2006-07-21 | 2 | 2007-09-06 | 08 | Paint | W | SB |  |  |  |  |
| 20135 | EastCL Electric Fixtures | 2d | 2007-05-25 | 2007-05-28 | 20130 |  | Electricians [32 h] | 2006-10-13 | Task | 3 | 3 | 2007-08-23 | 2006-09-05 | 3 | 2006-09-06 | 2006-09-06 | 2 | 3 | 2006-09-05 | 2 | 2007-08-21 | CL | Elec Fixt | E | EL |  |  |  |  |
| 20140 | EastCL Plumbing Fixtures | 2d | 2007-05-25 | 2007-05-28 | 20130 |  | Plumbers [32 h] | 2006-10-13 | Task | 1 | 3 | 2007-08-21 | 2006-09-05 | 3 | 2006-09-06 | 2006-09-06 | 2 | 1 | 2006-09-05 | 2 | 2007-08-21 | CL | PB Fixt | E | PB |  |  |  |  |
| 20145 | EastCL HVAC Fixtures | 1d | 2007-05-25 | 2007-05-25 | 20130 |  | HVAC Sheet Metal [16 h] | 2006-10-12 | Task | 1 | 1 | 2007-08-21 | 2006-09-06 | 2 | 2006-09-05 | 2006-09-06 | 1 | 1 | 2006-09-05 | 1 | 2007-08-21 | CL | HVAC | E | HV |  |  |  |  |
| 20250 | East02 Paint & Carpeting | 2d | 2007-05-25 | 2007-05-28 | 20245, 20240, 20235 |  | Subcontract Work [96 h] | 2006-10-13 | Task | 2 | 3 | 2007-08-23 | 2006-09-07 | 3 | 2006-09-06 | 2006-09-08 | 2 | 2 | 2006-09-05 | 2 | 2007-08-22 | 02 | Paint | E | SB |  |  |  |  |
| 2664 | East40 Affix Window Wall Frames Floors 38-40 | 5d | 2007-05-29 | 2007-06-04 | 2662, 2620, 2615, 2610, 2605, 401 |  | Iron Workers [240 h] | 2006-05-25 | Task | 5 | 6 | 2007-06-25 | 2006-05-26 | 6 | 2006-06-01 | 2006-06-01 | 5 | 5 | 2006-05-26 | 4 | 2007-06-19 | 40 | Frame | E | IW |  | 26 |  |  |
| 10305 | West03 Studs & Drywall/1 | 2d | 2007-05-29 | 2007-05-30 | 10405, 10300 |  | Carpenters [96 h] | 2006-09-05 | Task | 2 | 3 | 2007-09-11 | 2006-08-22 | 3 | 2006-07-26 | 2006-08-23 | 2 | 2 | 2006-07-25 | 2 | 2007-09-10 | 03 | Stud | W | CP |  |  |  |  |
| 10310 | West03 R/I Plumbing | 2d | 2007-05-29 | 2007-05-30 | 10410, 10300 |  | Plumbers [64 h] | 2006-09-05 | Task | 2 | 3 | 2007-09-12 | 2006-08-23 | 3 | 2006-07-26 | 2006-08-24 | 2 | 2 | 2006-07-25 | 2 | 2007-09-11 | 03 | R/I PB | W | PB |  |  |  |  |
| 10315 | West03 HVAC Ductwork | 2d | 2007-05-29 | 2007-05-30 | 10415, 10300 |  | HVAC Sheet Metal [64 h] | 2006-09-05 | Task | 3 | 3 | 2007-09-04 | 2006-08-24 | 3 | 2006-07-26 | 2006-08-25 | 2 | 3 | 2006-07-25 | 2 | 2007-08-31 | 03 | HVAC | W | HV |  |  |  |  |
| 10420 | West04 R/I Electric | 2d | 2007-05-29 | 2007-05-30 | 10405 |  | Electricians [64 h] | 2006-09-05 | Task | 2 | 3 | 2007-09-11 | 2006-08-30 | 3 | 2006-07-26 | 2006-08-31 | 2 | 2 | 2006-07-25 | 2 | 2007-09-10 | 04 | R/I Elec | W | EL |  |  |  |  |
| 10425 | West04 Plumbing Test | 1d | 2007-05-29 | 2007-05-29 | 10410 |  | Plumbers [16 h] | 2006-09-04 | Task | 1 | 1 | 2007-09-11 | 2006-08-31 | 2 | 2006-07-25 | 2006-08-31 | 1 | 1 | 2006-07-25 | 1 | 2007-09-11 | 04 | PB Test | W | PB |  |  |  |  |
| 10530 | West05 Drywall/2 & Finishes | 2d | 2007-05-29 | 2007-05-30 | 10525, 10520, 10515 |  | Carpenters [96 h] | 2006-09-05 | Task | 2 | 3 | 2007-09-11 | 2006-09-01 | 3 | 2006-07-26 | 2006-09-04 | 2 | 2 | 2006-07-25 | 2 | 2007-09-10 | 05 | Drywall | W | CP |  |  |  |  |
| 10635 | West06 Electric Fixtures | 2d | 2007-05-29 | 2007-05-30 | 10630 |  | Electricians [32 h] | 2006-09-05 | Task | 2 | 3 | 2007-09-11 | 2006-09-05 | 3 | 2006-07-26 | 2006-09-06 | 2 | 2 | 2006-07-25 | 2 | 2007-09-10 | 06 | Elec Fixt | W | EL |  |  |  |  |
| 10640 | West06 Plumbing Fixtures | 2d | 2007-05-29 | 2007-05-30 | 10630 |  | Plumbers [32 h] | 2006-09-05 | Task | 2 | 3 | 2007-09-11 | 2006-09-05 | 3 | 2006-07-26 | 2006-09-06 | 2 | 2 | 2006-07-25 | 2 | 2007-09-10 | 06 | PB Fixt | W | PB |  |  |  |  |
| 10645 | West06 HVAC Fixtures | 1d | 2007-05-29 | 2007-05-29 | 10630 |  | HVAC Sheet Metal [16 h] | 2006-09-04 | Task | 1 | 1 | 2007-09-10 | 2006-09-06 | 2 | 2006-07-25 | 2006-09-06 | 1 | 1 | 2006-07-25 | 1 | 2007-09-10 | 06 | HVAC | W | HV |  |  |  |  |
| 10750 | West07 Paint & Carpeting | 2d | 2007-05-29 | 2007-05-30 | 10745, 10740, 10735 |  | Subcontract Work [96 h] | 2006-09-05 | Task | 2 | 3 | 2007-09-13 | 2006-09-07 | 3 | 2006-07-26 | 2006-09-08 | 2 | 2 | 2006-07-25 | 2 | 2007-09-12 | 07 | Paint | W | SB |  |  |  |  |

| ID | Activity | Duration | Start | Finish | Predecessors | Constraint | Calendar | Resources | MEF | P3 Task Type | ADur | PESS | AFinish | Imported Late Start | MOD | Imported Early Finish | Imported Late Finish | MOST | ActDur | Imported Early Start | OPTD | AStart | LOC2 Floor | WTYP | LOC1 Tower | CRTY | PL-1 | Links with Lags longer than ? units | LOC3 Segment | CRSZ | Duration Risk Validation |
| --- | --- | --- | --- | --- | --- | --- | --- | --- | --- | --- | --- | --- | --- | --- | --- | --- | --- | --- | --- | --- | --- | --- | --- | --- | --- | --- | --- | --- | --- | --- | --- |
| 20150 | EastCL Paint & Carpeting | 2d | 2007-05-29 | 2007-05-30 | 20145, 20140, 20135 |  |  | Subcontract Work [96 h] | 2006-10-18 | Task | 2 | 3 | 2007-08-27 | 2006-09-07 | 3 | 2006-09-08 | 2006-09-08 | 2 | 2 | 2006-09-07 | 2 | 2007-08-24 | CL | Paint | E | SB |  |  |  |  |  |
| 10205 | West02 Studs & Drywall/1 | 2d | 2007-05-31 | 2007-06-01 | 10305, 10200 |  |  | Carpenters [96 h] | 2006-09-08 | Task | 2 | 3 | 2007-09-13 | 2006-08-24 | 3 | 2006-07-28 | 2006-08-25 | 2 | 2 | 2006-07-27 | 2 | 2007-09-12 | 02 | Stud | W | CP |  |  |  |  |  |
| 10210 | West02 R/I Plumbing | 2d | 2007-05-31 | 2007-06-01 | 10310, 10200 |  |  | Plumbers [64 h] | 2006-09-08 | Task | 2 | 3 | 2007-09-14 | 2006-08-25 | 3 | 2006-07-28 | 2006-08-28 | 2 | 2 | 2006-07-27 | 2 | 2007-09-13 | 02 | R/I PB | W | PB |  |  |  |  |  |
| 10215 | West02 HVAC Ductwork | 2d | 2007-05-31 | 2007-06-01 | 10315, 10200 |  |  | HVAC Sheet Metal [64 h] | 2006-09-08 | Task | 3 | 3 | 2007-09-07 | 2006-08-28 | 3 | 2006-07-28 | 2006-08-29 | 2 | 3 | 2006-07-27 | 2 | 2007-09-05 | 02 | HVAC | W | HV |  |  |  |  |  |
| 10320 | West03 R/I Electric | 2d | 2007-05-31 | 2007-06-01 | 10305 |  |  | Electricians [64 h] | 2006-09-08 | Task | 1 | 3 | 2007-09-12 | 2006-08-30 | 3 | 2006-07-28 | 2006-08-31 | 2 | 1 | 2006-07-27 | 2 | 2007-09-12 | 03 | R/I Elec | W | EL |  |  |  |  |  |
| 10325 | West03 Plumbing Test | 1d | 2007-05-31 | 2007-05-31 | 10310 |  |  | Plumbers [16 h] | 2006-09-07 | Task | 2 | 1 | 2007-09-14 | 2006-08-31 | 2 | 2006-07-27 | 2006-08-31 | 1 | 2 | 2006-07-27 | 1 | 2007-09-13 | 03 | PB Test | W | PB |  |  |  |  |  |
| 10430 | West04 Drywall/2 & Finishes | 2d | 2007-05-31 | 2007-06-01 | 10425, 10420, 10415 |  |  | Carpenters [96 h] | 2006-09-08 | Task | 2 | 3 | 2007-09-13 | 2006-09-01 | 3 | 2006-07-28 | 2006-09-04 | 2 | 2 | 2006-07-27 | 2 | 2007-09-12 | 04 | Drywall | W | CP |  |  |  |  |  |
| 10535 | West05 Electric Fixtures | 2d | 2007-05-31 | 2007-06-01 | 10530 |  |  | Electricians [32 h] | 2006-09-08 | Task | 2 | 3 | 2007-09-13 | 2006-09-05 | 3 | 2006-07-28 | 2006-09-06 | 2 | 2 | 2006-07-27 | 2 | 2007-09-12 | 05 | Elec Fixt | W | EL |  |  |  |  |  |
| 10540 | West05 Plumbing Fixtures | 2d | 2007-05-31 | 2007-06-01 | 10530 |  |  | Plumbers [32 h] | 2006-09-08 | Task | 2 | 3 | 2007-09-13 | 2006-09-05 | 3 | 2006-07-28 | 2006-09-06 | 2 | 2 | 2006-07-27 | 2 | 2007-09-12 | 05 | PB Fixt | W | PB |  |  |  |  |  |
| 10545 | West05 HVAC Fixtures | 1d | 2007-05-31 | 2007-05-31 | 10530 |  |  | HVAC Sheet Metal [16 h] | 2006-09-07 | Task | 1 | 1 | 2007-09-12 | 2006-09-06 | 2 | 2006-07-27 | 2006-09-06 | 1 | 1 | 2006-07-27 | 1 | 2007-09-12 | 05 | HVAC | W | HV |  |  |  |  |  |
| 10650 | West06 Paint & Carpeting | 2d | 2007-05-31 | 2007-06-01 | 10645, 10640, 10635 |  |  | Subcontract Work [96 h] | 2006-09-08 | Task | 2 | 3 | 2007-09-13 | 2006-09-07 | 3 | 2006-07-28 | 2006-09-08 | 2 | 2 | 2006-07-27 | 2 | 2007-09-12 | 06 | Paint | W | SB |  |  |  |  |  |
| 10105 | WestCL Studs & Drywall/1 | 2d | 2007-06-04 | 2007-06-05 | 10205, 10100 |  |  | Carpenters [96 h] | 2006-09-13 | Task | 2 | 3 | 2007-09-17 | 2006-08-28 | 3 | 2006-08-01 | 2006-08-29 | 2 | 2 | 2006-07-31 | 2 | 2007-09-14 | CL | Stud | W | CP |  |  |  |  |  |
| 10110 | WestCL R/I Plumbing | 2d | 2007-06-04 | 2007-06-05 | 10210, 10100 |  |  | Plumbers [64 h] | 2006-09-13 | Task | 1 | 3 | 2007-09-17 | 2006-08-29 | 3 | 2006-08-01 | 2006-08-30 | 2 | 1 | 2006-07-31 | 2 | 2007-09-17 | CL | R/I PB | W | PB |  |  |  |  |  |
| 10115 | WestCL HVAC Ductwork | 2d | 2007-06-04 | 2007-06-05 | 10215, 10100 |  |  | HVAC Sheet Metal [64 h] | 2006-09-13 | Task | 2 | 3 | 2007-09-11 | 2006-08-30 | 3 | 2006-08-01 | 2006-08-31 | 2 | 2 | 2006-07-31 | 2 | 2007-09-10 | CL | HVAC | W | HV |  |  |  |  |  |
| 10220 | West02 R/I Electric | 2d | 2007-06-04 | 2007-06-05 | 10205 |  |  | Electricians [64 h] | 2006-09-13 | Task | 3 | 3 | 2007-09-18 | 2006-08-30 | 3 | 2006-08-01 | 2006-08-31 | 2 | 3 | 2006-07-31 | 2 | 2007-09-14 | 02 | R/I Elec | W | EL |  |  |  |  |  |
| 10225 | West02 Plumbing Test | 1d | 2007-06-04 | 2007-06-04 | 10210 |  |  | Plumbers [16 h] | 2006-09-12 | Task | 1 | 1 | 2007-09-17 | 2006-08-31 | 2 | 2006-07-31 | 2006-08-31 | 1 | 1 | 2006-07-31 | 1 | 2007-09-17 | 02 | PB Test | W | PB |  |  |  |  |  |
| 10330 | West03 Drywall/2 & Finishes | 2d | 2007-06-04 | 2007-06-05 | 10325, 10320, 10315 |  |  | Carpenters [96 h] | 2006-09-13 | Task | 2 | 3 | 2007-09-18 | 2006-09-01 | 3 | 2006-08-01 | 2006-09-04 | 2 | 2 | 2006-07-31 | 2 | 2007-09-17 | 03 | Drywall | W | CP |  |  |  |  |  |
| 10435 | West04 Electric Fixtures | 2d | 2007-06-04 | 2007-06-05 | 10430 |  |  | Electricians [32 h] | 2006-09-13 | Task | 2 | 3 | 2007-09-17 | 2006-09-05 | 3 | 2006-08-01 | 2006-09-06 | 2 | 2 | 2006-07-31 | 2 | 2007-09-14 | 04 | Elec Fixt | W | EL |  |  |  |  |  |
| 10440 | West04 Plumbing Fixtures | 2d | 2007-06-04 | 2007-06-05 | 10430 |  |  | Plumbers [32 h] | 2006-09-13 | Task | 1 | 3 | 2007-09-14 | 2006-09-05 | 3 | 2006-08-01 | 2006-09-06 | 2 | 1 | 2006-07-31 | 2 | 2007-09-14 | 04 | PB Fixt | W | PB |  |  |  |  |  |
| 10445 | West04 HVAC Fixtures | 1d | 2007-06-04 | 2007-06-04 | 10430 |  |  | HVAC Sheet Metal [16 h] | 2006-09-12 | Task | 1 | 1 | 2007-09-14 | 2006-09-06 | 2 | 2006-07-31 | 2006-09-06 | 1 | 1 | 2006-07-31 | 1 | 2007-09-14 | 04 | HVAC | W | HV |  |  |  |  |  |
| 10550 | West05 Paint & Carpeting | 2d | 2007-06-04 | 2007-06-05 | 10545, 10540, 10535 |  |  | Subcontract Work [96 h] | 2006-09-13 | Task | 2 | 3 | 2007-09-17 | 2006-09-07 | 3 | 2006-08-01 | 2006-09-08 | 2 | 2 | 2006-07-31 | 2 | 2007-09-14 | 05 | Paint | W | SB |  |  |  |  |  |
| 2666 | East44 Affix Window Wall Frames Floors 41-44 | 6d | 2007-06-05 | 2007-06-12 | 2664, 2605, 2604, 2602, 2600, 2160, 401 |  |  | Iron Workers [288 h] | 2006-06-06 | Task | 5 | 8 | 2007-07-02 | 2006-06-02 | 8 | 2006-06-09 | 2006-06-09 | 6 | 5 | 2006-06-02 | 5 | 2007-06-26 | 44 | Frame | E | IW | 26 | (ID)303 (Link)FF[10] |  |  |  |
| 9950 | SiteGS Casino Commissioning | 60d | 2007-06-06 | 2007-08-28 | 1295 SS, 1295 FF, 1295 |  |  |  |  |  | 60 |  | 2007-09-20 |  |  |  |  |  | 60 |  |  | 2007-06-29 |  |  | S |  | 52 |  | GS |  |  |
| 10120 | WestCL R/I Electric | 2d | 2007-06-06 | 2007-06-07 | 10105 |  |  | Electricians [64 h] | 2006-09-18 | Task | 2 | 3 | 2007-09-19 | 2006-08-30 | 3 | 2006-08-03 | 2006-08-31 | 2 | 2 | 2006-08-02 | 2 | 2007-09-18 | CL | R/I Elec | W | EL |  |  |  |  |  |
| 10125 | WestCL Plumbing Test | 1d | 2007-06-06 | 2007-06-06 | 10110 |  |  | Plumbers [16 h] | 2006-09-15 | Task | 1 | 1 | 2007-09-18 | 2006-08-31 | 2 | 2006-08-02 | 2006-08-31 | 1 | 1 | 2006-08-02 | 1 | 2007-09-18 | CL | PB Test | W | PB |  |  |  |  |  |
| 10230 | West02 Drywall/2 & Finishes | 2d | 2007-06-06 | 2007-06-07 | 10225, 10220, 10215 |  |  | Carpenters [96 h] | 2006-09-18 | Task | 3 | 3 | 2007-09-21 | 2006-09-01 | 3 | 2006-08-03 | 2006-09-04 | 2 | 3 | 2006-08-02 | 2 | 2007-09-19 | 02 | Drywall | W | CP |  |  |  |  |  |
| 10335 | West03 Electric Fixtures | 2d | 2007-06-06 | 2007-06-07 | 10330 |  |  | Electricians [32 h] | 2006-09-18 | Task | 2 | 3 | 2007-09-20 | 2006-09-05 | 3 | 2006-08-03 | 2006-09-06 | 2 | 2 | 2006-08-02 | 2 | 2007-09-19 | 03 | Elec Fixt | W | EL |  |  |  |  |  |
| 10340 | West03 Plumbing Fixtures | 2d | 2007-06-06 | 2007-06-07 | 10330 |  |  | Plumbers [32 h] | 2006-09-18 | Task | 2 | 3 | 2007-09-20 | 2006-09-05 | 3 | 2006-08-03 | 2006-09-06 | 2 | 2 | 2006-08-02 | 2 | 2007-09-19 | 03 | PB Fixt | W | PB |  |  |  |  |  |
| 10345 | West03 HVAC Fixtures | 1d | 2007-06-06 | 2007-06-06 | 10330 |  |  | HVAC Sheet Metal [16 h] | 2006-09-15 | Task | 2 | 1 | 2007-09-20 | 2006-09-06 | 2 | 2006-08-02 | 2006-09-06 | 1 | 2 | 2006-08-02 | 1 | 2007-09-19 | 03 | HVAC | W | HV |  |  |  |  |  |
| 10450 | West04 Paint & Carpeting | 2d | 2007-06-06 | 2007-06-07 | 10445, 10440, 10435 |  |  | Subcontract Work [96 h] | 2006-09-18 | Task | 2 | 3 | 2007-09-19 | 2006-09-07 | 3 | 2006-08-03 | 2006-09-08 | 2 | 2 | 2006-08-02 | 2 | 2007-09-18 | 04 | Paint | W | SB |  |  |  |  |  |
| 10130 | WestCL Drywall/2 & Finishes | 2d | 2007-06-08 | 2007-06-11 | 10125, 10120, 10115 |  |  | Carpenters [96 h] | 2006-09-21 | Task | 3 | 3 | 2007-09-24 | 2006-09-01 | 3 | 2006-08-07 | 2006-09-04 | 2 | 3 | 2006-08-04 | 2 | 2007-09-20 | CL | Drywall | W | CP |  |  |  |  |  |
| 10235 | West02 Electric Fixtures | 2d | 2007-06-08 | 2007-06-11 | 10230 |  |  | Electricians [32 h] | 2006-09-21 | Task | 2 | 3 | 2007-09-25 | 2006-09-05 | 3 | 2006-08-07 | 2006-09-06 | 2 | 2 | 2006-08-04 | 2 | 2007-09-24 | 02 | Elec Fixt | W | EL |  |  |  |  |  |
| 10240 | West02 Plumbing Fixtures | 2d | 2007-06-08 | 2007-06-11 | 10230 |  |  | Plumbers [32 h] | 2006-09-21 | Task | 2 | 3 | 2007-09-25 | 2006-09-05 | 3 | 2006-08-07 | 2006-09-06 | 2 | 2 | 2006-08-04 | 2 | 2007-09-24 | 02 | PB Fixt | W | PB |  |  |  |  |  |
| 10245 | West02 HVAC Fixtures | 1d | 2007-06-08 | 2007-06-08 | 10230 |  |  | HVAC Sheet Metal [16 h] | 2006-09-20 | Task | 1 | 1 | 2007-09-24 | 2006-09-06 | 2 | 2006-08-04 | 2006-09-06 | 1 | 1 | 2006-08-04 | 1 | 2007-09-24 | 02 | HVAC | W | HV |  |  |  |  |  |
| 10350 | West03 Paint & Carpeting | 2d | 2007-06-08 | 2007-06-11 | 10345, 10340, 10335 |  |  | Subcontract Work [96 h] | 2006-09-21 | Task | 2 | 3 | 2007-09-24 | 2006-09-07 | 3 | 2006-08-07 | 2006-09-08 | 2 | 2 | 2006-08-04 | 2 | 2007-09-21 | 03 | Paint | W | SB |  |  |  |  |  |
| 10135 | WestCL Electric Fixtures | 2d | 2007-06-12 | 2007-06-13 | 10130 |  |  | Electricians [32 h] | 2006-09-26 | Task | 2 | 3 | 2007-09-26 | 2006-09-05 | 3 | 2006-08-09 | 2006-09-06 | 2 | 2 | 2006-08-08 | 2 | 2007-09-25 | CL | Elec Fixt | W | EL |  |  |  |  |  |
| 10140 | WestCL Plumbing Fixtures | 2d | 2007-06-12 | 2007-06-13 | 10130 |  |  | Plumbers [32 h] | 2006-09-26 | Task | 1 | 3 | 2007-09-25 | 2006-09-05 | 3 | 2006-08-09 | 2006-09-06 | 2 | 1 | 2006-08-08 | 2 | 2007-09-25 | CL | PB Fixt | W | PB |  |  |  |  |  |
| 10145 | WestCL HVAC Fixtures | 1d | 2007-06-12 | 2007-06-12 | 10130 |  |  | HVAC Sheet Metal [16 h] | 2006-09-25 | Task | 2 | 1 | 2007-09-26 | 2006-09-06 | 2 | 2006-08-08 | 2006-09-06 | 1 | 2 | 2006-08-08 | 1 | 2007-09-25 | CL | HVAC | W | HV |  |  |  |  |  |
| 10250 | West02 Paint & Carpeting | 2d | 2007-06-12 | 2007-06-13 | 10245, 10240, 10235 |  |  | Subcontract Work [96 h] | 2006-09-26 | Task | 2 | 3 | 2007-09-27 | 2006-09-07 | 3 | 2006-08-09 | 2006-09-08 | 2 | 2 | 2006-08-08 | 2 | 2007-09-26 | 02 | Paint | W | SB |  |  |  |  |  |
| 2225 | Skybridge Glass Ceiling | 10d | 2007-06-13 | 2007-06-26 | 2666, 2220, 1666, 1564 |  |  | Iron Workers [960 h] |  |  | 9 |  | 2007-07-13 |  |  |  |  |  | 9 |  |  | 2007-07-03 | 12 | Site | E | IW | 70 |  |  |  |  |
| 2240 | Skybridge Affix Window Wall Glass | 10d | 2007-06-13 | 2007-06-26 | 2666, 2235, 1666, 304 |  |  | Iron Workers [480 h] |  |  | 11 |  | 2007-09-13 |  |  |  |  |  | 11 |  |  | 2007-08-30 | 20 | Window | E | IW | 86 |  |  | 6 |  |
| 10150 | WestCL Paint & Carpeting | 2d | 2007-06-14 | 2007-06-15 | 10145, 10140, 10135 |  |  | Subcontract Work [96 h] | 2006-09-29 | Task | 1 | 3 | 2007-09-27 | 2006-09-07 | 3 | 2006-08-11 | 2006-09-08 | 2 | 1 | 2006-08-10 | 2 | 2007-09-27 | CL | Paint | W | SB |  |  |  |  |  |
| 403 | Window Wall Units - Deliver 23-44 | 15d | 2007-06-27 | 2007-07-17 | 303 |  |  |  |  |  | 12 |  | 2007-08-15 |  |  |  |  |  | 12 |  |  | 2007-07-31 | GF | Window | S |  | 10 |  |  |  | (ID)403 (Distribution)Triangle(15;15;20) |
| 2215 | Skybridge Glass Floor | 15d | 2007-06-27 | 2007-07-17 | 2225, 2210 |  |  | Iron Workers [1440 h] |  |  | 15 |  | 2007-08-03 |  |  |  |  |  | 15 |  |  | 2007-07-16 | 12 | Site | E | IW | 70 |  |  |  |  |
| 1670 | West44 Affix Window Wall Units Floors 23-44 | 12d | 2007-07-18 | 2007-08-02 | E007 FF+24d, E007, 1666, 1664, 1662, 1660, 1564, 1562, 1560, 403 |  |  | Iron Workers [576 h] | 2006-06-28 | Task | 10 | 16 | 2007-10-10 | 2006-06-12 | 16 | 2006-05-30 | 2006-06-27 | 12 | 10 | 2006-05-15 | 10 | 2007-09-07 | 44 | Window | W | IW | 87 |  |  |  |  |
| 2250 | Skybridge Layout Floor | 3d | 2007-07-18 | 2007-07-20 | 2240, 2225, 2215 |  |  | Carpenters [32 h] | 2006-06-30 | Task | 3 | 1 | 2007-09-18 | 2006-05-29 | 2 | 2006-03-20 | 2006-05-29 | 1 | 3 | 2006-03-20 | 1 | 2007-09-14 | 22 | Layout | E | CP | 86 |  |  |  | (ID)2250 (Distribution)Triangle(2;3;7) |
| 2670 | East44 Affix Window Wall Units Floors 23-44 | 12d | 2007-07-18 | 2007-08-02 | E007 FF, 2666, 2664, 2662, 2660, 2564, 2562, 2560, 403 |  |  | Iron Workers [576 h] | 2006-06-28 | Task | 12 | 16 | 2007-09-06 | 2006-06-12 | 16 | 2006-06-27 | 2006-06-27 | 12 | 12 | 2006-06-12 | 10 | 2007-08-16 | 44 | Window | E | IW | 85 |  |  |  |  |
| 2252 | Skybridge Studs & Drywall/1 | 10d | 2007-07-23 | 2007-08-03 | 2250 |  |  | Carpenters [96 h] | 2006-07-05 | Task | 11 | 3 | 2007-10-03 | 2006-06-29 | 3 | 2006-03-22 | 2006-06-30 | 2 | 11 | 2006-03-21 | 2 | 2007-09-19 | 22 | Stud | E | CP | 86 |  |  |  | (ID)2252 (Distribution)Triangle(10;10;15) |
| 2254 | Skybridge R/I Plumbing | 10d | 2007-07-23 | 2007-08-03 | 2250 |  |  | Plumbers [64 h] | 2006-07-05 | Task | 8 | 3 | 2007-09-28 | 2006-06-30 | 3 | 2006-03-22 | 2006-07-03 | 2 | 8 | 2006-03-21 | 2 | 2007-09-19 | 22 | R/I PB | E | PB | 70 |  |  |  | (ID)2254 (Distribution)Triangle(10;10;15) |
| 2256 | Skybridge HVAC Ductwork | 10d | 2007-07-23 | 2007-08-03 | 2250 |  |  | HVAC Sheet Metal [64 h] | 2006-07-05 | Task | 9 | 3 | 2007-10-01 | 2006-07-03 | 3 | 2006-03-22 | 2006-07-04 | 2 | 9 | 2006-03-21 | 2 | 2007-09-19 | 22 | HVAC | E | HV |  |  |  |  | (ID)2256 (Distribution)Triangle(10;10;15) |
| 14400 | West44 Layout Floor | 1d | 2007-08-03 | 2007-08-03 | 1670, 1545 |  |  | Carpenters [32 h] | 2006-06-13 | Task | 1 | 1 | 2007-10-11 | 2006-06-28 | 2 | 2006-02-20 | 2006-06-28 | 1 | 1 | 2006-02-20 | 1 | 2007-10-11 | 44 | Layout | W | CP | 87 |  |  |  |  |
| 24400 | East44 Layout Floor | 1d | 2007-08-03 | 2007-08-03 | 2670, 2545 |  |  | Carpenters [32 h] | 2006-06-30 | Task | 1 | 1 | 2007-09-07 | 2006-05-29 | 2 | 2006-03-20 | 2006-05-29 | 1 | 1 | 2006-03-20 | 1 | 2007-09-07 | 44 | Layout | E | CP | 85 |  |  |  |  |
| 2258 | Skybridge R/I Electric | 10d | 2007-08-06 | 2007-08-17 | 2252 |  |  | Electricians [64 h] | 2006-07-10 | Task | 10 | 3 | 2007-10-17 | 2006-08-30 | 3 | 2006-03-24 | 2006-08-31 | 2 | 10 | 2006-03-23 | 2 | 2007-10-04 | 22 | R/I Elec | E | EL | 86 |  |  |  | (ID)2258 (Distribution)Triangle(10;10;15) |
| 2260 | Skybridge Plumbing Test | 5d | 2007-08-06 | 2007-08-10 | 2254 |  |  | Plumbers [16 h] | 2006-07-07 | Task | 6 | 1 | 2007-10-08 | 2006-08-31 | 2 | 2006-03-23 | 2006-08-31 | 1 | 6 | 2006-03-23 | 1 | 2007-10-01 | 22 | PB Test | E | PB | 70 |  |  |  |  |
| 14300 | West43 Layout Floor | 1d | 2007-08-06 | 2007-08-06 | 14400, 1670, 1545 |  |  | Carpenters [32 h] | 2006-06-15 | Task | 2 | 1 | 2007-10-15 | 2006-06-30 | 2 | 2006-02-21 | 2006-06-30 | 1 | 2 | 2006-02-21 | 1 | 2007-10-12 | 43 | Layout | W | CP | 87 |  |  |  |  |
| 14405 | West44 Studs & Drywall/1 | 2d | 2007-08-06 | 2007-08-07 | 14400 |  |  | Carpenters [96 h] | 2006-06-16 | Task | 1 | 3 | 2007-10-12 | 2006-06-29 | 3 | 2006-02-22 | 2006-06-30 | 2 | 1 | 2006-02-21 | 2 | 2007-10-12 | 44 | Stud | W | CP | 87 |  |  |  |  |
| 14410 | West44 R/I Plumbing | 2d | 2007-08-06 | 2007-08-07 | 14400 |  |  | Plumbers [64 h] | 2006-06-16 | Task | 2 | 3 | 2007-10-15 | 2006-06-30 | 3 | 2006-02-22 | 2006-07-03 | 2 | 2 | 2006-02-21 | 2 | 2007-10-12 | 44 | R/I PB | W | PB |  |  |  |  |  |
| 14415 | West44 HVAC Ductwork | 2d | 2007-08-06 | 2007-08-07 | 14400 |  |  | HVAC Sheet Metal [64 h] | 2006-06-16 | Task | 3 | 3 | 2007-10-16 | 2006-07-03 | 3 | 2006-02-22 | 2006-07-04 | 2 | 3 | 2006-02-21 | 2 | 2007-10-12 | 44 | HVAC | W | HV |  |  |  |  |  |
| 24300 | East43 Layout Floor | 1d | 2007-08-06 | 2007-08-06 | 24400, 2670, 2545 |  |  | Carpenters [32 h] | 2006-07-04 | Task | 1 | 1 | 2007-09-10 | 2006-05-30 | 2 | 2006-03-21 | 2006-05-30 | 1 | 1 | 2006-03-21 | 1 | 2007-09-10 | 43 | Layout | E | CP |  |  |  |  |  |
| 24405 | East44 Studs & Drywall/1 | 2d | 2007-08-06 | 2007-08-07 | 24400 |  |  | Carpenters [96 h] | 2006-07-05 | Task | 3 | 3 | 2007-09-12 | 2006-06-29 | 3 | 2006-03-22 | 2006-06-30 | 2 | 3 | 2006-03-21 | 2 | 2007-09-10 | 44 | Stud | E | CP | 85 |  |  |  |  |
| 24410 | East44 R/I Plumbing | 2d | 2007-08-06 | 2007-08-07 | 24400 |  |  | Plumbers [64 h] | 2006-07-05 | Task | 1 | 3 | 2007-09-10 | 2006-06-30 | 3 | 2006-03-22 | 2006-07-03 | 2 | 1 | 2006-03-21 | 2 | 2007-09-10 | 44 | R/I PB | E | PB |  |  |  |  |  |
| 24415 | East44 HVAC Ductwork | 2d | 2007-08-06 | 2007-08-07 | 24400 |  |  | HVAC Sheet Metal [64 h] | 2006-07-05 | Task | 2 | 3 | 2007-09-11 | 2006-07-03 | 3 | 2006-03-22 | 2006-07-04 | 2 | 2 | 2006-03-21 | 2 | 2007-09-10 | 44 | HVAC | E | HV |  |  |  |  |  |
| E007 | Event 007 - Window Connector Design Error - Requires 2X duration to install | 1d | 2007-08-06 | 2007-08-06 |  | start on or after 2007-08-06 | Standard |  |  |  | 24 |  | 2007-09-06 |  |  |  |  |  | 24 |  |  | 2007-08-06 |  |  |  |  | 15 |  |  |  |  |
| 14200 | West42 Layout Floor | 1d | 2007-08-07 | 2007-08-07 | 14300, 1670, 1545 |  |  | Carpenters [32 h] | 2006-06-19 | Task | 1 | 1 | 2007-10-16 | 2006-07-04 | 2 | 2006-02-22 | 2006-07-04 | 1 | 1 | 2006-02-22 | 1 | 2007-10-16 | 42 | Layout | W | CP |  |  |  |  |  |
| 24200 | East42 Layout Floor | 1d | 2007-08-07 | 2007-08-07 | 24300, 2670, 2545 |  |  | Carpenters [32 h] | 2006-07-06 | Task | 1 | 1 | 2007-09-11 | 2006-05-31 | 2 | 2006-03-22 | 2006-05-31 | 1 | 1 | 2006-03-22 | 1 | 2007-09-11 | 42 | Layout | E | CP |  |  |  |  |  |
| 14100 | West41 Layout Floor | 1d | 2007-08-08 | 2007-08-08 | 14200, 1670, 1545 |  |  | Carpenters [32 h] | 2006-06-21 | Task | 1 | 1 | 2007-10-17 | 2006-07-06 | 2 | 2006-02-23 | 2006-07-06 | 1 | 1 | 2006-02-23 | 1 | 2007-10-17 | 41 | Layout | W | CP |  |  |  |  |  |
| 14305 | West43 Studs & Drywall/1 | 2d | 2007-08-08 | 2007-08-09 | 14405, 14300 |  |  | Carpenters [96 h] | 2006-06-21 | Task | 2 | 3 | 2007-10-17 | 2006-07-03 | 3 | 2006-02-24 | 2006-07-04 | 2 | 2 | 2006-02-23 | 2 | 2007-10-16 | 43 | Stud | W | CP | 87 |  |  |  |  |
| 14310 | West43 R/I Plumbing | 2d | 2007-08-08 | 2007-08-09 | 14410, 14300 |  |  | Plumbers [64 h] | 2006-06-21 | Task | 2 | 3 | 2007-10-17 | 2006-07-04 | 3 | 2006-02-24 | 2006-07-05 | 2 | 2 | 2006-02-23 | 2 | 2007-10-16 | 43 | R/I PB | W | PB |  |  |  |  |  |
| 14315 | West43 HVAC Ductwork | 2d | 2007-08-08 | 2007-08-09 | 14415, 14300 |  |  | HVAC Sheet Metal [64 h] | 2006-06-21 | Task | 2 | 3 | 2007-10-18 | 2006-07-05 | 3 | 2006-02-24 | 2006-07-06 | 2 | 2 | 2006-02-23 | 2 | 2007-10-17 | 43 | HVAC | W | HV |  |  |  |  |  |
| 14420 | West44 R/I Electric | 2d | 2007-08-08 | 2007-08-09 | 14405 |  |  | Electricians [64 h] | 2006-06-21 | Task | 3 | 3 | 2007-10-17 | 2006-08-30 | 3 | 2006-02-24 | 2006-08-31 | 2 | 3 | 2006-02-23 | 2 | 2007-10-15 | 44 | R/I Elec | W | EL |  |  |  |  |  |

| ID | Activity | Duration | Start | Finish | Predecessors | Resources | MEF | P3 Task Type | ADur | PESS | AFinish | Imported Late Start | MOD | Imported Early Finish | Imported Late Finish | MOST | ActDur | Imported Early Start | OPTD | AStart | LOC2 Floor | WTYP | LOC1 Tower | CRTY | PL-1 |
| --- | --- | --- | --- | --- | --- | --- | --- | --- | --- | --- | --- | --- | --- | --- | --- | --- | --- | --- | --- | --- | --- | --- | --- | --- | --- |
| 14425 | West44 Plumbing Test | 1d | 2007-08-08 | 2007-08-08 | 14410 | Plumbers [16 h] | 2006-06-20 | Task | 1 | 1 | 2007-10-16 | 2006-08-31 | 2 | 2006-02-23 | 2006-08-31 | 1 | 1 | 2006-02-23 | 1 | 2007-10-16 | 44 | PB Test | W | PB |  |
| 24100 | East41 Layout Floor | 1d | 2007-08-08 | 2007-08-08 | 24200, 2670, 2545 | Carpenters [32 h] | 2006-07-10 | Task | 1 | 1 | 2007-09-12 | 2006-06-01 | 2 | 2006-03-23 | 2006-06-01 | 1 | 1 | 2006-03-23 | 1 | 2007-09-12 | 41 | Layout | E | CP |  |
| 24305 | East43 Studs & Drywall/1 | 2d | 2007-08-08 | 2007-08-09 | 24405, 24300 | Carpenters [96 h] | 2006-07-10 | Task | 2 | 3 | 2007-09-14 | 2006-07-03 | 3 | 2006-03-24 | 2006-07-04 | 2 | 2 | 2006-03-23 | 2 | 2007-09-13 | 43 | Stud | E | CP | 85 |
| 24310 | East43 R/I Plumbing | 2d | 2007-08-08 | 2007-08-09 | 24410, 24300 | Plumbers [64 h] | 2006-07-10 | Task | 1 | 3 | 2007-09-11 | 2006-07-04 | 3 | 2006-03-24 | 2006-07-05 | 2 | 1 | 2006-03-23 | 2 | 2007-09-11 | 43 | R/I PB | E | PB |  |
| 24315 | East43 HVAC Ductwork | 2d | 2007-08-08 | 2007-08-09 | 24415, 24300 | HVAC Sheet Metal [64 h] | 2006-07-10 | Task | 2 | 3 | 2007-09-13 | 2006-07-05 | 3 | 2006-03-24 | 2006-07-06 | 2 | 2 | 2006-03-23 | 2 | 2007-09-12 | 43 | HVAC | E | HV |  |
| 24420 | East44 R/I Electric | 2d | 2007-08-08 | 2007-08-09 | 24405 | Electricians [64 h] | 2006-07-10 | Task | 3 | 3 | 2007-09-17 | 2006-08-30 | 3 | 2006-03-24 | 2006-08-31 | 2 | 3 | 2006-03-23 | 2 | 2007-09-13 | 44 | R/I Elec | E | EL |  |
| 24425 | East44 Plumbing Test | 1d | 2007-08-08 | 2007-08-08 | 24410 | Plumbers [16 h] | 2006-07-07 | Task | 1 | 1 | 2007-09-11 | 2006-08-31 | 2 | 2006-03-23 | 2006-08-31 | 1 | 1 | 2006-03-23 | 1 | 2007-09-11 | 44 | PB Test | E | PB |  |
| 14000 | West40 Layout Floor | 1d | 2007-08-09 | 2007-08-09 | 14100, 1670, 1545 | Carpenters [32 h] | 2006-06-23 | Task | 1 | 1 | 2007-10-18 | 2006-07-10 | 2 | 2006-02-24 | 2006-07-10 | 1 | 1 | 2006-02-24 | 1 | 2007-10-18 | 40 | Layout | W | CP |  |
| 24000 | East40 Layout Floor | 1d | 2007-08-09 | 2007-08-09 | 24100, 2670, 2545 | Carpenters [32 h] | 2006-07-12 | Task | 1 | 1 | 2007-09-13 | 2006-06-02 | 2 | 2006-03-24 | 2006-06-02 | 1 | 1 | 2006-03-24 | 1 | 2007-09-13 | 40 | Layout | E | CP |  |
| 13900 | West39 Layout Floor | 1d | 2007-08-10 | 2007-08-10 | 14000, 1670, 1545 | Carpenters [32 h] | 2006-06-27 | Task | 1 | 1 | 2007-10-19 | 2006-07-12 | 2 | 2006-02-27 | 2006-07-12 | 1 | 1 | 2006-02-27 | 1 | 2007-10-19 | 39 | Layout | W | CP |  |
| 14205 | West42 Studs & Drywall/1 | 2d | 2007-08-10 | 2007-08-13 | 14305, 14200 | Carpenters [96 h] | 2006-06-26 | Task | 2 | 3 | 2007-10-19 | 2006-07-05 | 3 | 2006-02-28 | 2006-07-06 | 2 | 2 | 2006-02-27 | 2 | 2007-10-18 | 42 | Stud | W | CP | 87 |
| 14210 | West42 R/I Plumbing | 2d | 2007-08-10 | 2007-08-13 | 14310, 14200 | Plumbers [64 h] | 2006-06-26 | Task | 2 | 3 | 2007-10-19 | 2006-07-06 | 3 | 2006-02-28 | 2006-07-07 | 2 | 2 | 2006-02-27 | 2 | 2007-10-18 | 42 | R/I PB | W | PB |  |
| 14215 | West42 HVAC Ductwork | 2d | 2007-08-10 | 2007-08-13 | 14315, 14200 | HVAC Sheet Metal [64 h] | 2006-06-26 | Task | 2 | 3 | 2007-10-22 | 2006-07-07 | 3 | 2006-02-28 | 2006-07-10 | 2 | 2 | 2006-02-27 | 2 | 2007-10-19 | 42 | HVAC | W | HV |  |
| 14320 | West43 R/I Electric | 2d | 2007-08-10 | 2007-08-13 | 14305 | Electricians [64 h] | 2006-06-26 | Task | 2 | 3 | 2007-10-19 | 2006-08-30 | 3 | 2006-02-28 | 2006-08-31 | 2 | 2 | 2006-02-27 | 2 | 2007-10-18 | 43 | R/I Elec | W | EL |  |
| 14325 | West43 Plumbing Test | 1d | 2007-08-10 | 2007-08-10 | 14310 | Plumbers [16 h] | 2006-06-23 | Task | 1 | 1 | 2007-10-18 | 2006-08-31 | 2 | 2006-02-27 | 2006-08-31 | 1 | 1 | 2006-02-27 | 1 | 2007-10-18 | 43 | PB Test | W | PB |  |
| 14430 | West44 Drywall/2 & Finishes | 2d | 2007-08-10 | 2007-08-13 | 14425, 14420, 14415 | Carpenters [96 h] | 2006-06-26 | Task | 2 | 3 | 2007-10-19 | 2006-09-01 | 3 | 2006-02-28 | 2006-09-04 | 2 | 2 | 2006-02-27 | 2 | 2007-10-18 | 44 | Drywall | W | CP |  |
| 23900 | East39 Layout Floor | 1d | 2007-08-10 | 2007-08-10 | 24000, 2670, 2545 | Carpenters [32 h] | 2006-07-14 | Task | 2 | 1 | 2007-09-17 | 2006-06-05 | 2 | 2006-03-27 | 2006-06-05 | 1 | 2 | 2006-03-27 | 1 | 2007-09-14 | 39 | Layout | E | CP |  |
| 24205 | East42 Studs & Drywall/1 | 2d | 2007-08-10 | 2007-08-13 | 24305, 24200 | Carpenters [96 h] | 2006-07-13 | Task | 2 | 3 | 2007-09-18 | 2006-07-05 | 3 | 2006-03-28 | 2006-07-06 | 2 | 2 | 2006-03-27 | 2 | 2007-09-17 | 42 | Stud | E | CP | 85 |
| 24210 | East42 R/I Plumbing | 2d | 2007-08-10 | 2007-08-13 | 24310, 24200 | Plumbers [64 h] | 2006-07-13 | Task | 3 | 3 | 2007-09-14 | 2006-07-06 | 3 | 2006-03-28 | 2006-07-07 | 2 | 3 | 2006-03-27 | 2 | 2007-09-12 | 42 | R/I PB | E | PB |  |
| 24215 | East42 HVAC Ductwork | 2d | 2007-08-10 | 2007-08-13 | 24315, 24200 | HVAC Sheet Metal [64 h] | 2006-07-13 | Task | 2 | 3 | 2007-09-17 | 2006-07-07 | 3 | 2006-03-28 | 2006-07-10 | 2 | 2 | 2006-03-27 | 2 | 2007-09-14 | 42 | HVAC | E | HV |  |
| 24320 | East43 R/I Electric | 2d | 2007-08-10 | 2007-08-13 | 24305 | Electricians [64 h] | 2006-07-13 | Task | 2 | 3 | 2007-09-18 | 2006-08-30 | 3 | 2006-03-28 | 2006-08-31 | 2 | 2 | 2006-03-27 | 2 | 2007-09-17 | 43 | R/I Elec | E | EL |  |
| 24325 | East43 Plumbing Test | 1d | 2007-08-10 | 2007-08-10 | 24310 | Plumbers [16 h] | 2006-07-12 | Task | 1 | 1 | 2007-09-12 | 2006-08-31 | 2 | 2006-03-27 | 2006-08-31 | 1 | 1 | 2006-03-27 | 1 | 2007-09-12 | 43 | PB Test | E | PB |  |
| 24430 | East44 Drywall/2 & Finishes | 2d | 2007-08-10 | 2007-08-13 | 24425, 24420, 24415 | Carpenters [96 h] | 2006-07-13 | Task | 2 | 3 | 2007-09-19 | 2006-09-01 | 3 | 2006-03-28 | 2006-09-04 | 2 | 2 | 2006-03-27 | 2 | 2007-09-18 | 44 | Drywall | E | CP |  |
| 13800 | West38 Layout Floor | 1d | 2007-08-13 | 2007-08-13 | 13900, 1670, 1545 | Carpenters [32 h] | 2006-06-29 | Task | 2 | 1 | 2007-10-23 | 2006-07-14 | 2 | 2006-02-28 | 2006-07-14 | 1 | 2 | 2006-02-28 | 1 | 2007-10-22 | 38 | Layout | W | CP |  |
| 23800 | East38 Layout Floor | 1d | 2007-08-13 | 2007-08-13 | 23900, 2670, 2545 | Carpenters [32 h] | 2006-07-18 | Task | 1 | 1 | 2007-09-18 | 2006-06-06 | 2 | 2006-03-28 | 2006-06-06 | 1 | 1 | 2006-03-28 | 1 | 2007-09-18 | 38 | Layout | E | CP |  |
| 13700 | West37 Layout Floor | 1d | 2007-08-14 | 2007-08-14 | 13800, 1670, 1545 | Carpenters [32 h] | 2006-07-03 | Task | 1 | 1 | 2007-10-24 | 2006-07-18 | 2 | 2006-03-01 | 2006-07-18 | 1 | 1 | 2006-03-01 | 1 | 2007-10-24 | 37 | Layout | W | CP |  |
| 14105 | West41 Studs & Drywall/1 | 2d | 2007-08-14 | 2007-08-15 | 14205, 14100 | Carpenters [96 h] | 2006-06-29 | Task | 2 | 3 | 2007-10-23 | 2006-07-07 | 3 | 2006-03-02 | 2006-07-10 | 2 | 2 | 2006-03-01 | 2 | 2007-10-22 | 41 | Stud | W | CP | 87 |
| 14110 | West41 R/I Plumbing | 2d | 2007-08-14 | 2007-08-15 | 14210, 14100 | Plumbers [64 h] | 2006-06-29 | Task | 2 | 3 | 2007-10-23 | 2006-07-10 | 3 | 2006-03-02 | 2006-07-11 | 2 | 2 | 2006-03-01 | 2 | 2007-10-22 | 41 | R/I PB | W | PB |  |
| 14115 | West41 HVAC Ductwork | 2d | 2007-08-14 | 2007-08-15 | 14215, 14100 | HVAC Sheet Metal [64 h] | 2006-06-29 | Task | 2 | 3 | 2007-10-24 | 2006-07-11 | 3 | 2006-03-02 | 2006-07-12 | 2 | 2 | 2006-03-01 | 2 | 2007-10-23 | 41 | HVAC | W | HV |  |
| 14220 | West42 R/I Electric | 2d | 2007-08-14 | 2007-08-15 | 14205 | Electricians [64 h] | 2006-06-29 | Task | 2 | 3 | 2007-10-23 | 2006-08-30 | 3 | 2006-03-02 | 2006-08-31 | 2 | 2 | 2006-03-01 | 2 | 2007-10-22 | 42 | R/I Elec | W | EL |  |
| 14225 | West42 Plumbing Test | 1d | 2007-08-14 | 2007-08-14 | 14210 | Plumbers [16 h] | 2006-06-28 | Task | 1 | 1 | 2007-10-22 | 2006-08-31 | 2 | 2006-03-01 | 2006-08-31 | 1 | 1 | 2006-03-01 | 1 | 2007-10-22 | 42 | PB Test | W | PB |  |
| 14330 | West43 Drywall/2 & Finishes | 2d | 2007-08-14 | 2007-08-15 | 14325, 14320, 14315 | Carpenters [96 h] | 2006-06-29 | Task | 3 | 3 | 2007-10-24 | 2006-09-01 | 3 | 2006-03-02 | 2006-09-04 | 2 | 3 | 2006-03-01 | 2 | 2007-10-22 | 43 | Drywall | W | CP |  |
| 14435 | West44 Electric Fixtures | 2d | 2007-08-14 | 2007-08-15 | 14430 | Electricians [32 h] | 2006-06-29 | Task | 2 | 3 | 2007-10-23 | 2006-09-05 | 3 | 2006-03-02 | 2006-09-06 | 2 | 2 | 2006-03-01 | 2 | 2007-10-22 | 44 | Elec Fixt | W | EL |  |
| 14440 | West44 Plumbing Fixtures | 2d | 2007-08-14 | 2007-08-15 | 14430 | Plumbers [32 h] | 2006-06-29 | Task | 2 | 3 | 2007-10-23 | 2006-09-05 | 3 | 2006-03-02 | 2006-09-06 | 2 | 2 | 2006-03-01 | 2 | 2007-10-22 | 44 | PB Fixt | W | PB |  |
| 14445 | West44 HVAC Fixtures | 1d | 2007-08-14 | 2007-08-14 | 14430 | HVAC Sheet Metal [16 h] | 2006-06-28 | Task | 1 | 1 | 2007-10-22 | 2006-09-06 | 2 | 2006-03-01 | 2006-09-06 | 1 | 1 | 2006-03-01 | 1 | 2007-10-22 | 44 | HVAC | W | HV |  |
| 23700 | East37 Layout Floor | 1d | 2007-08-14 | 2007-08-14 | 23800, 2670, 2545 | Carpenters [32 h] | 2006-07-20 | Task | 1 | 1 | 2007-09-19 | 2006-06-07 | 2 | 2006-03-29 | 2006-06-07 | 1 | 1 | 2006-03-29 | 1 | 2007-09-19 | 37 | Layout | E | CP |  |
| 24105 | East41 Studs & Drywall/1 | 2d | 2007-08-14 | 2007-08-15 | 24205, 24100 | Carpenters [96 h] | 2006-07-18 | Task | 3 | 3 | 2007-09-21 | 2006-07-07 | 3 | 2006-03-30 | 2006-07-10 | 2 | 3 | 2006-03-29 | 2 | 2007-09-19 | 41 | Stud | E | CP | 85 |
| 24110 | East41 R/I Plumbing | 2d | 2007-08-14 | 2007-08-15 | 24210, 24100 | Plumbers [64 h] | 2006-07-18 | Task | 3 | 3 | 2007-09-19 | 2006-07-10 | 3 | 2006-03-30 | 2006-07-11 | 2 | 3 | 2006-03-29 | 2 | 2007-09-17 | 41 | R/I PB | E | PB |  |
| 24115 | East41 HVAC Ductwork | 2d | 2007-08-14 | 2007-08-15 | 24215, 24100 | HVAC Sheet Metal [64 h] | 2006-07-18 | Task | 1 | 3 | 2007-09-18 | 2006-07-11 | 3 | 2006-03-30 | 2006-07-12 | 2 | 1 | 2006-03-29 | 2 | 2007-09-18 | 41 | HVAC | E | HV |  |
| 24220 | East42 R/I Electric | 2d | 2007-08-14 | 2007-08-15 | 24205 | Electricians [64 h] | 2006-07-18 | Task | 2 | 3 | 2007-09-20 | 2006-08-30 | 3 | 2006-03-30 | 2006-08-31 | 2 | 2 | 2006-03-29 | 2 | 2007-09-19 | 42 | R/I Elec | E | EL |  |
| 24225 | East42 Plumbing Test | 1d | 2007-08-14 | 2007-08-14 | 24210 | Plumbers [16 h] | 2006-07-17 | Task | 2 | 1 | 2007-09-18 | 2006-08-31 | 2 | 2006-03-29 | 2006-08-31 | 1 | 2 | 2006-03-29 | 1 | 2007-09-17 | 42 | PB Test | E | PB |  |
| 24330 | East43 Drywall/2 & Finishes | 2d | 2007-08-14 | 2007-08-15 | 24325, 24320, 24315 | Carpenters [96 h] | 2006-07-18 | Task | 2 | 3 | 2007-09-20 | 2006-09-01 | 3 | 2006-03-30 | 2006-09-04 | 2 | 2 | 2006-03-29 | 2 | 2007-09-19 | 43 | Drywall | E | CP |  |
| 24435 | East44 Electric Fixtures | 2d | 2007-08-14 | 2007-08-15 | 24430 | Electricians [32 h] | 2006-07-18 | Task | 2 | 3 | 2007-09-21 | 2006-09-05 | 3 | 2006-03-30 | 2006-09-06 | 2 | 2 | 2006-03-29 | 2 | 2007-09-20 | 44 | Elec Fixt | E | EL |  |
| 24440 | East44 Plumbing Fixtures | 2d | 2007-08-14 | 2007-08-15 | 24430 | Plumbers [32 h] | 2006-07-18 | Task | 3 | 3 | 2007-09-24 | 2006-09-05 | 3 | 2006-03-30 | 2006-09-06 | 2 | 3 | 2006-03-29 | 2 | 2007-09-20 | 44 | PB Fixt | E | PB |  |
| 24445 | East44 HVAC Fixtures | 1d | 2007-08-14 | 2007-08-14 | 24430 | HVAC Sheet Metal [16 h] | 2006-07-17 | Task | 1 | 1 | 2007-09-20 | 2006-09-06 | 2 | 2006-03-29 | 2006-09-06 | 1 | 1 | 2006-03-29 | 1 | 2007-09-20 | 44 | HVAC | E | HV |  |
| 13600 | West36 Layout Floor | 1d | 2007-08-15 | 2007-08-15 | 13700, 1670, 1545 | Carpenters [32 h] | 2006-07-05 | Task | 1 | 1 | 2007-10-25 | 2006-07-20 | 2 | 2006-03-02 | 2006-07-20 | 1 | 1 | 2006-03-02 | 1 | 2007-10-25 | 36 | Layout | W | CP |  |
| 23600 | East36 Layout Floor | 1d | 2007-08-15 | 2007-08-15 | 23700, 2670, 2545 | Carpenters [32 h] | 2006-07-24 | Task | 1 | 1 | 2007-09-20 | 2006-06-08 | 2 | 2006-03-30 | 2006-06-08 | 1 | 1 | 2006-03-30 | 1 | 2007-09-20 | 36 | Layout | E | CP |  |
| 13500 | West35 Layout Floor | 1d | 2007-08-16 | 2007-08-16 | 13600, 1670, 1545 | Carpenters [32 h] | 2006-07-07 | Task | 2 | 1 | 2007-10-29 | 2006-07-24 | 2 | 2006-03-03 | 2006-07-24 | 1 | 2 | 2006-03-03 | 1 | 2007-10-26 | 35 | Layout | W | CP |  |
| 14005 | West40 Studs & Drywall/1 | 2d | 2007-08-16 | 2007-08-17 | 14105, 14000 | Carpenters [96 h] | 2006-07-04 | Task | 3 | 3 | 2007-10-26 | 2006-07-11 | 3 | 2006-03-06 | 2006-07-12 | 2 | 3 | 2006-03-03 | 2 | 2007-10-24 | 40 | Stud | W | CP | 87 |
| 14010 | West40 R/I Plumbing | 2d | 2007-08-16 | 2007-08-17 | 14110, 14000 | Plumbers [64 h] | 2006-07-04 | Task | 2 | 3 | 2007-10-25 | 2006-07-12 | 3 | 2006-03-06 | 2006-07-13 | 2 | 2 | 2006-03-03 | 2 | 2007-10-24 | 40 | R/I PB | W | PB |  |
| 14015 | West40 HVAC Ductwork | 2d | 2007-08-16 | 2007-08-17 | 14115, 14000 | HVAC Sheet Metal [64 h] | 2006-07-04 | Task | 2 | 3 | 2007-10-26 | 2006-07-13 | 3 | 2006-03-06 | 2006-07-14 | 2 | 2 | 2006-03-03 | 2 | 2007-10-25 | 40 | HVAC | W | HV |  |
| 14120 | West41 R/I Electric | 2d | 2007-08-16 | 2007-08-17 | 14105 | Electricians [64 h] | 2006-07-04 | Task | 2 | 3 | 2007-10-25 | 2006-08-30 | 3 | 2006-03-06 | 2006-08-31 | 2 | 2 | 2006-03-03 | 2 | 2007-10-24 | 41 | R/I Elec | W | EL |  |
| 14125 | West41 Plumbing Test | 1d | 2007-08-16 | 2007-08-16 | 14110 | Plumbers [16 h] | 2006-07-03 | Task | 1 | 1 | 2007-10-24 | 2006-08-31 | 2 | 2006-03-03 | 2006-08-31 | 1 | 1 | 2006-03-03 | 1 | 2007-10-24 | 41 | PB Test | W | PB |  |
| 14230 | West42 Drywall/2 & Finishes | 2d | 2007-08-16 | 2007-08-17 | 14225, 14220, 14215 | Carpenters [96 h] | 2006-07-04 | Task | 3 | 3 | 2007-10-26 | 2006-09-01 | 3 | 2006-03-06 | 2006-09-04 | 2 | 3 | 2006-03-03 | 2 | 2007-10-24 | 42 | Drywall | W | CP |  |
| 14335 | West43 Electric Fixtures | 2d | 2007-08-16 | 2007-08-17 | 14330 | Electricians [32 h] | 2006-07-04 | Task | 2 | 3 | 2007-10-26 | 2006-09-05 | 3 | 2006-03-06 | 2006-09-06 | 2 | 2 | 2006-03-03 | 2 | 2007-10-25 | 43 | Elec Fixt | W | EL |  |
| 14340 | West43 Plumbing Fixtures | 2d | 2007-08-16 | 2007-08-17 | 14330 | Plumbers [32 h] | 2006-07-04 | Task | 3 | 3 | 2007-10-29 | 2006-09-05 | 3 | 2006-03-06 | 2006-09-06 | 2 | 3 | 2006-03-03 | 2 | 2007-10-25 | 43 | PB Fixt | W | PB |  |
| 14345 | West43 HVAC Fixtures | 1d | 2007-08-16 | 2007-08-16 | 14330 | HVAC Sheet Metal [16 h] | 2006-07-03 | Task | 1 | 1 | 2007-10-25 | 2006-09-06 | 2 | 2006-03-03 | 2006-09-06 | 1 | 1 | 2006-03-03 | 1 | 2007-10-25 | 43 | HVAC | W | HV |  |
| 14450 | West44 Paint & Carpeting | 2d | 2007-08-16 | 2007-08-17 | 14445, 14440, 14435 | Subcontract Work [96 h] | 2006-07-04 | Task | 3 | 3 | 2007-10-26 | 2006-09-07 | 3 | 2006-03-06 | 2006-09-08 | 2 | 3 | 2006-03-03 | 2 | 2007-10-24 | 44 | Paint | W | SB |  |
| 23500 | East35 Layout Floor | 1d | 2007-08-16 | 2007-08-16 | 23600, 2670, 2545 | Carpenters [32 h] | 2006-07-26 | Task | 1 | 1 | 2007-09-21 | 2006-06-09 | 2 | 2006-03-31 | 2006-06-09 | 1 | 1 | 2006-03-31 | 1 | 2007-09-21 | 35 | Layout | E | CP |  |
| 24005 | East40 Studs & Drywall/1 | 2d | 2007-08-16 | 2007-08-17 | 24105, 24000 | Carpenters [96 h] | 2006-07-21 | Task | 2 | 3 | 2007-09-25 | 2006-07-11 | 3 | 2006-04-03 | 2006-07-12 | 2 | 2 | 2006-03-31 | 2 | 2007-09-24 | 40 | Stud | E | CP | 85 |
| 24010 | East40 R/I Plumbing | 2d | 2007-08-16 | 2007-08-17 | 24110, 24000 | Plumbers [64 h] | 2006-07-21 | Task | 2 | 3 | 2007-09-21 | 2006-07-12 | 3 | 2006-04-03 | 2006-07-13 | 2 | 2 | 2006-03-31 | 2 | 2007-09-20 | 40 | R/I PB | E | PB |  |
| 24015 | East40 HVAC Ductwork | 2d | 2007-08-16 | 2007-08-17 | 24115, 24000 | HVAC Sheet Metal [64 h] | 2006-07-21 | Task | 2 | 3 | 2007-09-20 | 2006-07-13 | 3 | 2006-04-03 | 2006-07-14 | 2 | 2 | 2006-03-31 | 2 | 2007-09-19 | 40 | HVAC | E | HV |  |
| 24120 | East41 R/I Electric | 2d | 2007-08-16 | 2007-08-17 | 24105 | Electricians [64 h] | 2006-07-21 | Task | 2 | 3 | 2007-09-25 | 2006-08-30 | 3 | 2006-04-03 | 2006-08-31 | 2 | 2 | 2006-03-31 | 2 | 2007-09-24 | 41 | R/I Elec | E | EL |  |
| 24125 | East41 Plumbing Test | 1d | 2007-08-16 | 2007-08-16 | 24110 | Plumbers [16 h] | 2006-07-20 | Task | 1 | 1 | 2007-09-20 | 2006-08-31 | 2 | 2006-03-31 | 2006-08-31 | 1 | 1 | 2006-03-31 | 1 | 2007-09-20 | 41 | PB Test | E | PB |  |
| 24230 | East42 Drywall/2 & Finishes | 2d | 2007-08-16 | 2007-08-17 | 24225, 24220, 24215 | Carpenters [96 h] | 2006-07-21 | Task | 3 | 3 | 2007-09-25 | 2006-09-01 | 3 | 2006-04-03 | 2006-09-04 | 2 | 3 | 2006-03-31 | 2 | 2007-09-21 | 42 | Drywall | E | CP |  |
| 24335 | East43 Electric Fixtures | 2d | 2007-08-16 | 2007-08-17 | 24330 | Electricians [32 h] | 2006-07-21 | Task | 2 | 3 | 2007-09-24 | 2006-09-05 | 3 | 2006-04-03 | 2006-09-06 | 2 | 2 | 2006-03-31 | 2 | 2007-09-21 | 43 | Elec Fixt | E | EL |  |
| 24340 | East43 Plumbing Fixtures | 2d | 2007-08-16 | 2007-08-17 | 24330 | Plumbers [32 h] | 2006-07-21 | Task | 1 | 3 | 2007-09-21 | 2006-09-05 | 3 | 2006-04-03 | 2006-09-06 | 2 | 1 | 2006-03-31 | 2 | 2007-09-21 | 43 | PB Fixt | E | PB |  |
| 24345 | East43 HVAC Fixtures | 1d | 2007-08-16 | 2007-08-16 | 24330 | HVAC Sheet Metal [16 h] | 2006-07-20 | Task | 1 | 1 | 2007-09-21 | 2006-09-06 | 2 | 2006-03-31 | 2006-09-06 | 1 | 1 | 2006-03-31 | 1 | 2007-09-21 | 43 | HVAC | E | HV |  |
| 24450 | East44 Paint & Carpeting | 2d | 2007-08-16 | 2007-08-17 | 24445, 24440, 24435 | Subcontract Work [96 h] | 2006-07-21 | Task | 1 | 3 | 2007-09-25 | 2006-09-07 | 3 | 2006-04-03 | 2006-09-08 | 2 | 1 | 2006-03-31 | 2 | 2007-09-25 | 44 | Paint | E | SB |  |
| 13400 | West34 Layout Floor | 1d | 2007-08-17 | 2007-08-17 | 13500, 1670, 1545 | Carpenters [32 h] | 2006-07-11 | Task | 1 | 1 | 2007-10-30 | 2006-07-26 | 2 | 2006-03-06 | 2006-07-26 | 1 | 1 | 2006-03-06 | 1 | 2007-10-30 | 34 | Layout | W | CP |  |

| ID | Activity | Duration | Start | Finish | Predecessors | Resources | MEF | P3 Task Type | ADur | PESS | AFinish | Imported Late Start | MOD | Imported Early Finish | Imported Late Finish | MOST | ActDur | Imported Early Start | OPTD | AStart | LOC2 Floor | WTYP | LOC1 Tower | CRTY | PL-1 | Duration Risk Validation | LOC3 Segment |
| --- | --- | --- | --- | --- | --- | --- | --- | --- | --- | --- | --- | --- | --- | --- | --- | --- | --- | --- | --- | --- | --- | --- | --- | --- | --- | --- | --- |
| 23400 | East34 Layout Floor | 1d | 2007-08-17 | 2007-08-17 | 23500, 2670, 2545 | Carpenters [32 h] | 2006-07-28 | Task | 1 | 1 | 2007-09-24 | 2006-06-12 | 2 | 2006-04-03 | 2006-06-12 | 1 | 1 | 2006-04-03 | 1 | 2007-09-24 | 34 | Layout | E | CP |  |  |  |
| 2262 | Skybridge Drywall/2 & Finishes | 10d | 2007-08-20 | 2007-08-31 | 2260, 2258, 2256 | Carpenters [96 h] | 2006-07-13 | Task | 10 | 3 | 2007-10-31 | 2006-09-01 | 3 | 2006-03-28 | 2006-09-04 | 2 | 10 | 2006-03-27 | 2 | 2007-10-18 | 22 | Drywall | E | CP | 86 | (ID)2262 (Distribution)Triangle(10;10;15) |  |
| 13300 | West33 Layout Floor | 1d | 2007-08-20 | 2007-08-20 | 13400, 1670, 1545 | Carpenters [32 h] | 2006-07-13 | Task | 1 | 1 | 2007-10-31 | 2006-07-28 | 2 | 2006-03-07 | 2006-07-28 | 1 | 1 | 2006-03-07 | 1 | 2007-10-31 | 33 | Layout | W | CP |  |  |  |
| 13905 | West39 Studs & Drywall/1 | 2d | 2007-08-20 | 2007-08-21 | 14005, 13900 | Carpenters [96 h] | 2006-07-07 | Task | 2 | 3 | 2007-10-30 | 2006-07-13 | 3 | 2006-03-08 | 2006-07-14 | 2 | 2 | 2006-03-07 | 2 | 2007-10-29 | 39 | Stud | W | CP | 87 |  |  |
| 13910 | West39 R/I Plumbing | 2d | 2007-08-20 | 2007-08-21 | 14010, 13900 | Plumbers [64 h] | 2006-07-07 | Task | 2 | 3 | 2007-10-29 | 2006-07-14 | 3 | 2006-03-08 | 2006-07-17 | 2 | 2 | 2006-03-07 | 2 | 2007-10-26 | 39 | R/I PB | W | PB |  |  |  |
| 13915 | West39 HVAC Ductwork | 2d | 2007-08-20 | 2007-08-21 | 14015, 13900 | HVAC Sheet Metal [64 h] | 2006-07-07 | Task | 2 | 3 | 2007-10-30 | 2006-07-17 | 3 | 2006-03-08 | 2006-07-18 | 2 | 2 | 2006-03-07 | 2 | 2007-10-29 | 39 | HVAC | W | HV |  |  |  |
| 14020 | West40 R/I Electric | 2d | 2007-08-20 | 2007-08-21 | 14005 | Electricians [64 h] | 2006-07-07 | Task | 1 | 3 | 2007-10-29 | 2006-08-30 | 3 | 2006-03-08 | 2006-08-31 | 2 | 1 | 2006-03-07 | 2 | 2007-10-29 | 40 | R/I Elec | W | EL |  |  |  |
| 14025 | West40 Plumbing Test | 1d | 2007-08-20 | 2007-08-20 | 14010 | Plumbers [16 h] | 2006-07-06 | Task | 1 | 1 | 2007-10-26 | 2006-08-31 | 2 | 2006-03-07 | 2006-08-31 | 1 | 1 | 2006-03-07 | 1 | 2007-10-26 | 40 | PB Test | W | PB |  |  |  |
| 14130 | West41 Drywall/2 & Finishes | 2d | 2007-08-20 | 2007-08-21 | 14125, 14120, 14115 | Carpenters [96 h] | 2006-07-07 | Task | 2 | 3 | 2007-10-29 | 2006-09-01 | 3 | 2006-03-08 | 2006-09-04 | 2 | 2 | 2006-03-07 | 2 | 2007-10-26 | 41 | Drywall | W | CP |  |  |  |
| 14235 | West42 Electric Fixtures | 2d | 2007-08-20 | 2007-08-21 | 14230 | Electricians [32 h] | 2006-07-07 | Task | 2 | 3 | 2007-10-30 | 2006-09-05 | 3 | 2006-03-08 | 2006-09-06 | 2 | 2 | 2006-03-07 | 2 | 2007-10-29 | 42 | Elec Fixt | W | EL |  |  |  |
| 14240 | West42 Plumbing Fixtures | 2d | 2007-08-20 | 2007-08-21 | 14230 | Plumbers [32 h] | 2006-07-07 | Task | 2 | 3 | 2007-10-30 | 2006-09-05 | 3 | 2006-03-08 | 2006-09-06 | 2 | 2 | 2006-03-07 | 2 | 2007-10-29 | 42 | PB Fixt | W | PB |  |  |  |
| 14245 | West42 HVAC Fixtures | 1d | 2007-08-20 | 2007-08-20 | 14230 | HVAC Sheet Metal [16 h] | 2006-07-06 | Task | 1 | 1 | 2007-10-29 | 2006-09-06 | 2 | 2006-03-07 | 2006-09-06 | 1 | 1 | 2006-03-07 | 1 | 2007-10-29 | 42 | HVAC | W | HV |  |  |  |
| 14350 | West43 Paint & Carpeting | 2d | 2007-08-20 | 2007-08-21 | 14345, 14340, 14335 | Subcontract Work [96 h] | 2006-07-07 | Task | 2 | 3 | 2007-10-31 | 2006-09-07 | 3 | 2006-03-08 | 2006-09-08 | 2 | 2 | 2006-03-07 | 2 | 2007-10-30 | 43 | Paint | W | SB |  |  |  |
| 23300 | East33 Layout Floor | 1d | 2007-08-20 | 2007-08-20 | 23400, 2670, 2545 | Carpenters [32 h] | 2006-08-01 | Task | 1 | 1 | 2007-09-25 | 2006-06-13 | 2 | 2006-04-04 | 2006-06-13 | 1 | 1 | 2006-04-04 | 1 | 2007-09-25 | 33 | Layout | E | CP |  |  |  |
| 23905 | East39 Studs & Drywall/1 | 2d | 2007-08-20 | 2007-08-21 | 24005, 23900 | Carpenters [96 h] | 2006-07-26 | Task | 2 | 3 | 2007-09-27 | 2006-07-13 | 3 | 2006-04-05 | 2006-07-14 | 2 | 2 | 2006-04-04 | 2 | 2007-09-26 | 39 | Stud | E | CP | 85 |  |  |
| 23910 | East39 R/I Plumbing | 2d | 2007-08-20 | 2007-08-21 | 24010, 23900 | Plumbers [64 h] | 2006-07-26 | Task | 2 | 3 | 2007-09-25 | 2006-07-14 | 3 | 2006-04-05 | 2006-07-17 | 2 | 2 | 2006-04-04 | 2 | 2007-09-24 | 39 | R/I PB | E | PB |  |  |  |
| 23915 | East39 HVAC Ductwork | 2d | 2007-08-20 | 2007-08-21 | 24015, 23900 | HVAC Sheet Metal [64 h] | 2006-07-26 | Task | 2 | 3 | 2007-09-24 | 2006-07-17 | 3 | 2006-04-05 | 2006-07-18 | 2 | 2 | 2006-04-04 | 2 | 2007-09-21 | 39 | HVAC | E | HV |  |  |  |
| 24020 | East40 R/I Electric | 2d | 2007-08-20 | 2007-08-21 | 24005 | Electricians [64 h] | 2006-07-26 | Task | 2 | 3 | 2007-09-27 | 2006-08-30 | 3 | 2006-04-05 | 2006-08-31 | 2 | 2 | 2006-04-04 | 2 | 2007-09-26 | 40 | R/I Elec | E | EL |  |  |  |
| 24025 | East40 Plumbing Test | 1d | 2007-08-20 | 2007-08-20 | 24010 | Plumbers [16 h] | 2006-07-25 | Task | 1 | 1 | 2007-09-24 | 2006-08-31 | 2 | 2006-04-04 | 2006-08-31 | 1 | 1 | 2006-04-04 | 1 | 2007-09-24 | 40 | PB Test | E | PB |  |  |  |
| 24130 | East41 Drywall/2 & Finishes | 2d | 2007-08-20 | 2007-08-21 | 24125, 24120, 24115 | Carpenters [96 h] | 2006-07-26 | Task | 1 | 3 | 2007-09-26 | 2006-09-01 | 3 | 2006-04-05 | 2006-09-04 | 2 | 1 | 2006-04-04 | 2 | 2007-09-26 | 41 | Drywall | E | CP |  |  |  |
| 24235 | East42 Electric Fixtures | 2d | 2007-08-20 | 2007-08-21 | 24230 | Electricians [32 h] | 2006-07-26 | Task | 2 | 3 | 2007-09-27 | 2006-09-05 | 3 | 2006-04-05 | 2006-09-06 | 2 | 2 | 2006-04-04 | 2 | 2007-09-26 | 42 | Elec Fixt | E | EL |  |  |  |
| 24240 | East42 Plumbing Fixtures | 2d | 2007-08-20 | 2007-08-21 | 24230 | Plumbers [32 h] | 2006-07-26 | Task | 3 | 3 | 2007-09-28 | 2006-09-05 | 3 | 2006-04-05 | 2006-09-06 | 2 | 3 | 2006-04-04 | 2 | 2007-09-26 | 42 | PB Fixt | E | PB |  |  |  |
| 24245 | East42 HVAC Fixtures | 1d | 2007-08-20 | 2007-08-20 | 24230 | HVAC Sheet Metal [16 h] | 2006-07-25 | Task | 2 | 1 | 2007-09-27 | 2006-09-06 | 2 | 2006-04-04 | 2006-09-06 | 1 | 2 | 2006-04-04 | 1 | 2007-09-26 | 42 | HVAC | E | HV |  |  |  |
| 24350 | East43 Paint & Carpeting | 2d | 2007-08-20 | 2007-08-21 | 24345, 24340, 24335 | Subcontract Work [96 h] | 2006-07-26 | Task | 3 | 3 | 2007-09-27 | 2006-09-07 | 3 | 2006-04-05 | 2006-09-08 | 2 | 3 | 2006-04-04 | 2 | 2007-09-25 | 43 | Paint | E | SB |  |  |  |
| 13200 | West32 Layout Floor | 1d | 2007-08-21 | 2007-08-21 | 13300, 1670, 1545 | Carpenters [32 h] | 2006-07-17 | Task | 1 | 1 | 2007-11-01 | 2006-08-01 | 2 | 2006-03-08 | 2006-08-01 | 1 | 1 | 2006-03-08 | 1 | 2007-11-01 |  | Layout | W | CP |  |  | 32 |
| 23200 | East32 Layout Floor | 1d | 2007-08-21 | 2007-08-21 | 23300, 2670, 2545 | Carpenters [32 h] | 2006-08-03 | Task | 2 | 1 | 2007-09-27 | 2006-06-14 | 2 | 2006-04-05 | 2006-06-14 | 1 | 2 | 2006-04-05 | 1 | 2007-09-26 |  | Layout | E | CP |  |  | 32 |
| 13100 | West31 Layout Floor | 1d | 2007-08-22 | 2007-08-22 | 13200, 1670, 1540 | Carpenters [32 h] | 2006-07-19 | Task | 1 | 1 | 2007-11-02 | 2006-08-03 | 2 | 2006-03-09 | 2006-08-03 | 1 | 1 | 2006-03-09 | 1 | 2007-11-02 | 31 | Layout | W | CP |  |  |  |
| 13805 | West38 Studs & Drywall/1 | 2d | 2007-08-22 | 2007-08-23 | 13905, 13800 | Carpenters [96 h] | 2006-07-12 | Task | 2 | 3 | 2007-11-01 | 2006-07-17 | 3 | 2006-03-10 | 2006-07-18 | 2 | 2 | 2006-03-09 | 2 | 2007-10-31 | 38 | Stud | W | CP | 87 |  |  |
| 13810 | West38 R/I Plumbing | 2d | 2007-08-22 | 2007-08-23 | 13910, 13800 | Plumbers [64 h] | 2006-07-12 | Task | 2 | 3 | 2007-10-31 | 2006-07-18 | 3 | 2006-03-10 | 2006-07-19 | 2 | 2 | 2006-03-09 | 2 | 2007-10-30 | 38 | R/I PB | W | PB |  |  |  |
| 13815 | West38 HVAC Ductwork | 2d | 2007-08-22 | 2007-08-23 | 13915, 13800 | HVAC Sheet Metal [64 h] | 2006-07-12 | Task | 2 | 3 | 2007-11-01 | 2006-07-19 | 3 | 2006-03-10 | 2006-07-20 | 2 | 2 | 2006-03-09 | 2 | 2007-10-31 | 38 | HVAC | W | HV |  |  |  |
| 13920 | West39 R/I Electric | 2d | 2007-08-22 | 2007-08-23 | 13905 | Electricians [64 h] | 2006-07-12 | Task | 2 | 3 | 2007-11-01 | 2006-08-30 | 3 | 2006-03-10 | 2006-08-31 | 2 | 2 | 2006-03-09 | 2 | 2007-10-31 | 39 | R/I Elec | W | EL |  |  |  |
| 13925 | West39 Plumbing Test | 1d | 2007-08-22 | 2007-08-22 | 13910 | Plumbers [16 h] | 2006-07-11 | Task | 1 | 1 | 2007-10-30 | 2006-08-31 | 2 | 2006-03-09 | 2006-08-31 | 1 | 1 | 2006-03-09 | 1 | 2007-10-30 | 39 | PB Test | W | PB |  |  |  |
| 14030 | West40 Drywall/2 & Finishes | 2d | 2007-08-22 | 2007-08-23 | 14025, 14020, 14015 | Carpenters [96 h] | 2006-07-12 | Task | 2 | 3 | 2007-10-31 | 2006-09-01 | 3 | 2006-03-10 | 2006-09-04 | 2 | 2 | 2006-03-09 | 2 | 2007-10-30 | 40 | Drywall | W | CP |  |  |  |
| 14135 | West41 Electric Fixtures | 2d | 2007-08-22 | 2007-08-23 | 14130 | Electricians [32 h] | 2006-07-12 | Task | 2 | 3 | 2007-10-31 | 2006-09-05 | 3 | 2006-03-10 | 2006-09-06 | 2 | 2 | 2006-03-09 | 2 | 2007-10-30 | 41 | Elec Fixt | W | EL |  |  |  |
| 14140 | West41 Plumbing Fixtures | 2d | 2007-08-22 | 2007-08-23 | 14130 | Plumbers [32 h] | 2006-07-12 | Task | 3 | 3 | 2007-11-01 | 2006-09-05 | 3 | 2006-03-10 | 2006-09-06 | 2 | 3 | 2006-03-09 | 2 | 2007-10-30 | 41 | PB Fixt | W | PB |  |  |  |
| 14145 | West41 HVAC Fixtures | 1d | 2007-08-22 | 2007-08-22 | 14130 | HVAC Sheet Metal [16 h] | 2006-07-11 | Task | 1 | 1 | 2007-10-30 | 2006-09-06 | 2 | 2006-03-09 | 2006-09-06 | 1 | 1 | 2006-03-09 | 1 | 2007-10-30 | 41 | HVAC | W | HV |  |  |  |
| 14250 | West42 Paint & Carpeting | 2d | 2007-08-22 | 2007-08-23 | 14245, 14240, 14235 | Subcontract Work [96 h] | 2006-07-12 | Task | 2 | 3 | 2007-11-01 | 2006-09-07 | 3 | 2006-03-10 | 2006-09-08 | 2 | 2 | 2006-03-09 | 2 | 2007-10-31 | 42 | Paint | W | SB |  |  |  |
| 23100 | East31 Layout Floor | 1d | 2007-08-22 | 2007-08-22 | 23200, 2670, 2540 | Carpenters [32 h] | 2006-08-07 | Task | 1 | 1 | 2007-09-28 | 2006-06-15 | 2 | 2006-04-06 | 2006-06-15 | 1 | 1 | 2006-04-06 | 1 | 2007-09-28 | 31 | Layout | E | CP |  |  |  |
| 23805 | East38 Studs & Drywall/1 | 2d | 2007-08-22 | 2007-08-23 | 23905, 23800 | Carpenters [96 h] | 2006-07-31 | Task | 2 | 3 | 2007-10-01 | 2006-07-17 | 3 | 2006-04-07 | 2006-07-18 | 2 | 2 | 2006-04-06 | 2 | 2007-09-28 | 38 | Stud | E | CP | 85 |  |  |
| 23810 | East38 R/I Plumbing | 2d | 2007-08-22 | 2007-08-23 | 23910, 23800 | Plumbers [64 h] | 2006-07-31 | Task | 2 | 3 | 2007-09-27 | 2006-07-18 | 3 | 2006-04-07 | 2006-07-19 | 2 | 2 | 2006-04-06 | 2 | 2007-09-26 | 38 | R/I PB | E | PB |  |  |  |
| 23815 | East38 HVAC Ductwork | 2d | 2007-08-22 | 2007-08-23 | 23915, 23800 | HVAC Sheet Metal [64 h] | 2006-07-31 | Task | 2 | 3 | 2007-09-26 | 2006-07-19 | 3 | 2006-04-07 | 2006-07-20 | 2 | 2 | 2006-04-06 | 2 | 2007-09-25 | 38 | HVAC | E | HV |  |  |  |
| 23920 | East39 R/I Electric | 2d | 2007-08-22 | 2007-08-23 | 23905 | Electricians [64 h] | 2006-07-31 | Task | 2 | 3 | 2007-10-01 | 2006-08-30 | 3 | 2006-04-07 | 2006-08-31 | 2 | 2 | 2006-04-06 | 2 | 2007-09-28 | 39 | R/I Elec | E | EL |  |  |  |
| 23925 | East39 Plumbing Test | 1d | 2007-08-22 | 2007-08-22 | 23910 | Plumbers [16 h] | 2006-07-28 | Task | 1 | 1 | 2007-09-26 | 2006-08-31 | 2 | 2006-04-06 | 2006-08-31 | 1 | 1 | 2006-04-06 | 1 | 2007-09-26 | 39 | PB Test | E | PB |  |  |  |
| 24030 | East40 Drywall/2 & Finishes | 2d | 2007-08-22 | 2007-08-23 | 24025, 24020, 24015 | Carpenters [96 h] | 2006-07-31 | Task | 2 | 3 | 2007-10-01 | 2006-09-01 | 3 | 2006-04-07 | 2006-09-04 | 2 | 2 | 2006-04-06 | 2 | 2007-09-28 | 40 | Drywall | E | CP |  |  |  |
| 24135 | East41 Electric Fixtures | 2d | 2007-08-22 | 2007-08-23 | 24130 | Electricians [32 h] | 2006-07-31 | Task | 2 | 3 | 2007-09-28 | 2006-09-05 | 3 | 2006-04-07 | 2006-09-06 | 2 | 2 | 2006-04-06 | 2 | 2007-09-27 | 41 | Elec Fixt | E | EL |  |  |  |
| 24140 | East41 Plumbing Fixtures | 2d | 2007-08-22 | 2007-08-23 | 24130 | Plumbers [32 h] | 2006-07-31 | Task | 1 | 3 | 2007-09-27 | 2006-09-05 | 3 | 2006-04-07 | 2006-09-06 | 2 | 1 | 2006-04-06 | 2 | 2007-09-27 | 41 | PB Fixt | E | PB |  |  |  |
| 24145 | East41 HVAC Fixtures | 1d | 2007-08-22 | 2007-08-22 | 24130 | HVAC Sheet Metal [16 h] | 2006-07-28 | Task | 1 | 1 | 2007-09-27 | 2006-09-06 | 2 | 2006-04-06 | 2006-09-06 | 1 | 1 | 2006-04-06 | 1 | 2007-09-27 | 41 | HVAC | E | HV |  |  |  |
| 24250 | East42 Paint & Carpeting | 2d | 2007-08-22 | 2007-08-23 | 24245, 24240, 24235 | Subcontract Work [96 h] | 2006-07-31 | Task | 2 | 3 | 2007-10-02 | 2006-09-07 | 3 | 2006-04-07 | 2006-09-08 | 2 | 2 | 2006-04-06 | 2 | 2007-10-01 | 42 | Paint | E | SB |  |  |  |
| 13000 | West30 Layout Floor | 1d | 2007-08-23 | 2007-08-23 | 13100, 1670, 1540 | Carpenters [32 h] | 2006-07-21 | Task | 1 | 1 | 2007-11-05 | 2006-08-07 | 2 | 2006-03-10 | 2006-08-07 | 1 | 1 | 2006-03-10 | 1 | 2007-11-05 | 30 | Layout | W | CP |  |  |  |
| 23000 | East30 Layout Floor | 1d | 2007-08-23 | 2007-08-23 | 23100, 2670, 2540 | Carpenters [32 h] | 2006-08-09 | Task | 1 | 1 | 2007-10-01 | 2006-06-16 | 2 | 2006-04-07 | 2006-06-16 | 1 | 1 | 2006-04-07 | 1 | 2007-10-01 | 30 | Layout | E | CP |  |  |  |
| 12900 | West29 Layout Floor | 1d | 2007-08-24 | 2007-08-24 | 13000, 1670, 1540 | Carpenters [32 h] | 2006-07-25 | Task | 1 | 1 | 2007-11-06 | 2006-08-09 | 2 | 2006-03-13 | 2006-08-09 | 1 | 1 | 2006-03-13 | 1 | 2007-11-06 | 29 | Layout | W | CP |  |  |  |
| 13705 | West37 Studs & Drywall/1 | 2d | 2007-08-24 | 2007-08-27 | 13805, 13700 | Carpenters [96 h] | 2006-07-17 | Task | 2 | 3 | 2007-11-05 | 2006-07-19 | 3 | 2006-03-14 | 2006-07-20 | 2 | 2 | 2006-03-13 | 2 | 2007-11-02 | 37 | Stud | W | CP | 87 |  |  |
| 13710 | West37 R/I Plumbing | 2d | 2007-08-24 | 2007-08-27 | 13810, 13700 | Plumbers [64 h] | 2006-07-17 | Task | 2 | 3 | 2007-11-02 | 2006-07-20 | 3 | 2006-03-14 | 2006-07-21 | 2 | 2 | 2006-03-13 | 2 | 2007-11-01 | 37 | R/I PB | W | PB |  |  |  |
| 13715 | West37 HVAC Ductwork | 2d | 2007-08-24 | 2007-08-27 | 13815, 13700 | HVAC Sheet Metal [64 h] | 2006-07-17 | Task | 2 | 3 | 2007-11-05 | 2006-07-21 | 3 | 2006-03-14 | 2006-07-24 | 2 | 2 | 2006-03-13 | 2 | 2007-11-02 | 37 | HVAC | W | HV |  |  |  |
| 13820 | West38 R/I Electric | 2d | 2007-08-24 | 2007-08-27 | 13805 | Electricians [64 h] | 2006-07-17 | Task | 3 | 3 | 2007-11-06 | 2006-08-30 | 3 | 2006-03-14 | 2006-08-31 | 2 | 3 | 2006-03-13 | 2 | 2007-11-02 | 38 | R/I Elec | W | EL |  |  |  |
| 13825 | West38 Plumbing Test | 1d | 2007-08-24 | 2007-08-24 | 13810 | Plumbers [16 h] | 2006-07-14 | Task | 1 | 1 | 2007-11-01 | 2006-08-31 | 2 | 2006-03-13 | 2006-08-31 | 1 | 1 | 2006-03-13 | 1 | 2007-11-01 | 38 | PB Test | W | PB |  |  |  |
| 13930 | West39 Drywall/2 & Finishes | 2d | 2007-08-24 | 2007-08-27 | 13925, 13920, 13915 | Carpenters [96 h] | 2006-07-17 | Task | 2 | 3 | 2007-11-05 | 2006-09-01 | 3 | 2006-03-14 | 2006-09-04 | 2 | 2 | 2006-03-13 | 2 | 2007-11-02 | 39 | Drywall | W | CP |  |  |  |
| 14035 | West40 Electric Fixtures | 2d | 2007-08-24 | 2007-08-27 | 14030 | Electricians [32 h] | 2006-07-17 | Task | 2 | 3 | 2007-11-02 | 2006-09-05 | 3 | 2006-03-14 | 2006-09-06 | 2 | 2 | 2006-03-13 | 2 | 2007-11-01 | 40 | Elec Fixt | W | EL |  |  |  |
| 14040 | West40 Plumbing Fixtures | 2d | 2007-08-24 | 2007-08-27 | 14030 | Plumbers [32 h] | 2006-07-17 | Task | 1 | 3 | 2007-11-01 | 2006-09-05 | 3 | 2006-03-14 | 2006-09-06 | 2 | 1 | 2006-03-13 | 2 | 2007-11-01 | 40 | PB Fixt | W | PB |  |  |  |
| 14045 | West40 HVAC Fixtures | 1d | 2007-08-24 | 2007-08-24 | 14030 | HVAC Sheet Metal [16 h] | 2006-07-14 | Task | 1 | 1 | 2007-11-01 | 2006-09-06 | 2 | 2006-03-13 | 2006-09-06 | 1 | 1 | 2006-03-13 | 1 | 2007-11-01 | 40 | HVAC | W | HV |  |  |  |
| 14150 | West41 Paint & Carpeting | 2d | 2007-08-24 | 2007-08-27 | 14145, 14140, 14135 | Subcontract Work [96 h] | 2006-07-17 | Task | 2 | 3 | 2007-11-05 | 2006-09-07 | 3 | 2006-03-14 | 2006-09-08 | 2 | 2 | 2006-03-13 | 2 | 2007-11-02 | 41 | Paint | W | SB |  |  |  |
| 22900 | East29 Layout Floor | 1d | 2007-08-24 | 2007-08-24 | 23000, 2670, 2540 | Carpenters [32 h] | 2006-08-11 | Task | 1 | 1 | 2007-10-02 | 2006-06-19 | 2 | 2006-04-10 | 2006-06-19 | 1 | 1 | 2006-04-10 | 1 | 2007-10-02 | 29 | Layout | E | CP |  |  |  |
| 23705 | East37 Studs & Drywall/1 | 2d | 2007-08-24 | 2007-08-27 | 23805, 23700 | Carpenters [96 h] | 2006-08-03 | Task | 1 | 3 | 2007-10-02 | 2006-07-19 | 3 | 2006-04-11 | 2006-07-20 | 2 | 1 | 2006-04-10 | 2 | 2007-10-02 | 37 | Stud | E | CP | 85 |  |  |
| 23710 | East37 R/I Plumbing | 2d | 2007-08-24 | 2007-08-27 | 23810, 23700 | Plumbers [64 h] | 2006-08-03 | Task | 3 | 3 | 2007-10-02 | 2006-07-20 | 3 | 2006-04-11 | 2006-07-21 | 2 | 3 | 2006-04-10 | 2 | 2007-09-28 | 37 | R/I PB | E | PB |  |  |  |
| 23715 | East37 HVAC Ductwork | 2d | 2007-08-24 | 2007-08-27 | 23815, 23700 | HVAC Sheet Metal [64 h] | 2006-08-03 | Task | 2 | 3 | 2007-09-28 | 2006-07-21 | 3 | 2006-04-11 | 2006-07-24 | 2 | 2 | 2006-04-10 | 2 | 2007-09-27 | 37 | HVAC | E | HV |  |  |  |
| 23820 | East38 R/I Electric | 2d | 2007-08-24 | 2007-08-27 | 23805 | Electricians [64 h] | 2006-08-03 | Task | 3 | 3 | 2007-10-04 | 2006-08-30 | 3 | 2006-04-11 | 2006-08-31 | 2 | 3 | 2006-04-10 | 2 | 2007-10-02 | 38 | R/I Elec | E | EL |  |  |  |
| 23825 | East38 Plumbing Test | 1d | 2007-08-24 | 2007-08-24 | 23810 | Plumbers [16 h] | 2006-08-02 | Task | 1 | 1 | 2007-09-28 | 2006-08-31 | 2 | 2006-04-10 | 2006-08-31 | 1 | 1 | 2006-04-10 | 1 | 2007-09-28 | 38 | PB Test | E | PB |  |  |  |
| 23930 | East39 Drywall/2 & Finishes | 2d | 2007-08-24 | 2007-08-27 | 23925, 23920, 23915 | Carpenters [96 h] | 2006-08-03 | Task | 2 | 3 | 2007-10-03 | 2006-09-01 | 3 | 2006-04-11 | 2006-09-04 | 2 | 2 | 2006-04-10 | 2 | 2007-10-02 | 39 | Drywall | E | CP |  |  |  |
| 24035 | East40 Electric Fixtures | 2d | 2007-08-24 | 2007-08-27 | 24030 | Electricians [32 h] | 2006-08-03 | Task | 2 | 3 | 2007-10-03 | 2006-09-05 | 3 | 2006-04-11 | 2006-09-06 | 2 | 2 | 2006-04-10 | 2 | 2007-10-02 | 40 | Elec Fixt | E | EL |  |  |  |
| 24040 | East40 Plumbing Fixtures | 2d | 2007-08-24 | 2007-08-27 | 24030 | Plumbers [32 h] | 2006-08-03 | Task | 2 | 3 | 2007-10-03 | 2006-09-05 | 3 | 2006-04-11 | 2006-09-06 | 2 | 2 | 2006-04-10 | 2 | 2007-10-02 | 40 | PB Fixt | E | PB |  |  |  |

| ID | Activity | Duration | Start | Finish | Predecessors | Resources | MEF | P3 Task Type | ADur | PESS | AFinish | Imported Late Start | MOD | Imported Early Finish | Imported Late Finish | MOST | ActDur | Imported Early Start | OPTD | AStart | LOC2 Floor | WTYP | LOC1 Tower | CRTY | PL-1 | LOC3 Segment | Duration Risk Validation |
| --- | --- | --- | --- | --- | --- | --- | --- | --- | --- | --- | --- | --- | --- | --- | --- | --- | --- | --- | --- | --- | --- | --- | --- | --- | --- | --- | --- |
| 24045 | East40 HVAC Fixtures | 1d | 2007-08-24 | 2007-08-24 | 24030 | HVAC Sheet Metal [16 h] | 2006-08-02 | Task | 1 | 1 | 2007-10-02 | 2006-09-06 | 2 | 2006-04-10 | 2006-09-06 | 1 | 1 | 2006-04-10 | 1 | 2007-10-02 | 40 | HVAC | E | HV |  |  |  |
| 24150 | East41 Paint & Carpeting | 2d | 2007-08-24 | 2007-08-27 | 24145, 24140, 24135 | Subcontract Work [96 h] | 2006-08-03 | Task | 2 | 3 | 2007-10-02 | 2006-09-07 | 3 | 2006-04-11 | 2006-09-08 | 2 | 2 | 2006-04-10 | 2 | 2007-10-01 | 41 | Paint | E | SB |  |  |  |
| 12800 | West28 Layout Floor | 1d | 2007-08-27 | 2007-08-27 | 12900, 1670, 1540 | Carpenters [32 h] | 2006-07-27 | Task | 1 | 1 | 2007-11-07 | 2006-08-11 | 2 | 2006-03-14 | 2006-08-11 | 1 | 1 | 2006-03-14 | 1 | 2007-11-07 | 28 | Layout | W | CP |  |  |  |
| 22800 | East28 Layout Floor | 1d | 2007-08-27 | 2007-08-27 | 22900, 2670, 2540 | Carpenters [32 h] | 2006-08-15 | Task | 2 | 1 | 2007-10-04 | 2006-06-20 | 2 | 2006-04-11 | 2006-06-20 | 1 | 2 | 2006-04-11 | 1 | 2007-10-03 | 28 | Layout | E | CP |  |  |  |
| 12700 | West27 Layout Floor | 1d | 2007-08-28 | 2007-08-28 | 12800, 1670, 1540 | Carpenters [32 h] | 2006-07-31 | Task | 1 | 1 | 2007-11-08 | 2006-08-15 | 2 | 2006-03-15 | 2006-08-15 | 1 | 1 | 2006-03-15 | 1 | 2007-11-08 | 27 | Layout | W | CP |  |  |  |
| 13605 | West36 Studs & Drywall/1 | 2d | 2007-08-28 | 2007-08-29 | 13705, 13600 | Carpenters [96 h] | 2006-07-20 | Task | 2 | 3 | 2007-11-07 | 2006-07-21 | 3 | 2006-03-16 | 2006-07-24 | 2 | 2 | 2006-03-15 | 2 | 2007-11-06 | 36 | Stud | W | CP | 87 |  |  |
| 13610 | West36 R/I Plumbing | 2d | 2007-08-28 | 2007-08-29 | 13710, 13600 | Plumbers [64 h] | 2006-07-20 | Task | 2 | 3 | 2007-11-06 | 2006-07-24 | 3 | 2006-03-16 | 2006-07-25 | 2 | 2 | 2006-03-15 | 2 | 2007-11-05 | 36 | R/I PB | W | PB |  |  |  |
| 13615 | West36 HVAC Ductwork | 2d | 2007-08-28 | 2007-08-29 | 13715, 13600 | HVAC Sheet Metal [64 h] | 2006-07-20 | Task | 1 | 3 | 2007-11-06 | 2006-07-25 | 3 | 2006-03-16 | 2006-07-26 | 2 | 1 | 2006-03-15 | 2 | 2007-11-06 | 36 | HVAC | W | HV |  |  |  |
| 13720 | West37 R/I Electric | 2d | 2007-08-28 | 2007-08-29 | 13705 | Electricians [64 h] | 2006-07-20 | Task | 1 | 3 | 2007-11-06 | 2006-08-30 | 3 | 2006-03-16 | 2006-08-31 | 2 | 1 | 2006-03-15 | 2 | 2007-11-06 | 37 | R/I Elec | W | EL |  |  |  |
| 13725 | West37 Plumbing Test | 1d | 2007-08-28 | 2007-08-28 | 13710 | Plumbers [16 h] | 2006-07-19 | Task | 1 | 1 | 2007-11-05 | 2006-08-31 | 2 | 2006-03-15 | 2006-08-31 | 1 | 1 | 2006-03-15 | 1 | 2007-11-05 | 37 | PB Test | W | PB |  |  |  |
| 13830 | West38 Drywall/2 & Finishes | 2d | 2007-08-28 | 2007-08-29 | 13825, 13820, 13815 | Carpenters [96 h] | 2006-07-20 | Task | 3 | 3 | 2007-11-09 | 2006-09-01 | 3 | 2006-03-16 | 2006-09-04 | 2 | 3 | 2006-03-15 | 2 | 2007-11-07 | 38 | Drywall | W | CP |  |  |  |
| 13935 | West39 Electric Fixtures | 2d | 2007-08-28 | 2007-08-29 | 13930 | Electricians [32 h] | 2006-07-20 | Task | 2 | 3 | 2007-11-07 | 2006-09-05 | 3 | 2006-03-16 | 2006-09-06 | 2 | 2 | 2006-03-15 | 2 | 2007-11-06 | 39 | Elec Fixt | W | EL |  |  |  |
| 13940 | West39 Plumbing Fixtures | 2d | 2007-08-28 | 2007-08-29 | 13930 | Plumbers [32 h] | 2006-07-20 | Task | 1 | 3 | 2007-11-06 | 2006-09-05 | 3 | 2006-03-16 | 2006-09-06 | 2 | 1 | 2006-03-15 | 2 | 2007-11-06 | 39 | PB Fixt | W | PB |  |  |  |
| 13945 | West39 HVAC Fixtures | 1d | 2007-08-28 | 2007-08-28 | 13930 | HVAC Sheet Metal [16 h] | 2006-07-19 | Task | 1 | 1 | 2007-11-06 | 2006-09-06 | 2 | 2006-03-15 | 2006-09-06 | 1 | 1 | 2006-03-15 | 1 | 2007-11-06 | 39 | HVAC | W | HV |  |  |  |
| 14050 | West40 Paint & Carpeting | 2d | 2007-08-28 | 2007-08-29 | 14045, 14040, 14035 | Subcontract Work [96 h] | 2006-07-20 | Task | 2 | 3 | 2007-11-06 | 2006-09-07 | 3 | 2006-03-16 | 2006-09-08 | 2 | 2 | 2006-03-15 | 2 | 2007-11-05 | 40 | Paint | W | SB |  |  |  |
| 22700 | East27 Layout Floor | 1d | 2007-08-28 | 2007-08-28 | 22800, 2670, 2540 | Carpenters [32 h] | 2006-08-17 | Task | 1 | 1 | 2007-10-05 | 2006-06-21 | 2 | 2006-04-12 | 2006-06-21 | 1 | 1 | 2006-04-12 | 1 | 2007-10-05 | 27 | Layout | E | CP |  |  |  |
| 23605 | East36 Studs & Drywall/1 | 2d | 2007-08-28 | 2007-08-29 | 23705, 23600 | Carpenters [96 h] | 2006-08-08 | Task | 2 | 3 | 2007-10-04 | 2006-07-21 | 3 | 2006-04-13 | 2006-07-24 | 2 | 2 | 2006-04-12 | 2 | 2007-10-03 | 36 | Stud | E | CP | 85 |  |  |
| 23610 | East36 R/I Plumbing | 2d | 2007-08-28 | 2007-08-29 | 23710, 23600 | Plumbers [64 h] | 2006-08-08 | Task | 2 | 3 | 2007-10-04 | 2006-07-24 | 3 | 2006-04-13 | 2006-07-25 | 2 | 2 | 2006-04-12 | 2 | 2007-10-03 | 36 | R/I PB | E | PB |  |  |  |
| 23615 | East36 HVAC Ductwork | 2d | 2007-08-28 | 2007-08-29 | 23715, 23600 | HVAC Sheet Metal [64 h] | 2006-08-08 | Task | 2 | 3 | 2007-10-02 | 2006-07-25 | 3 | 2006-04-13 | 2006-07-26 | 2 | 2 | 2006-04-12 | 2 | 2007-10-01 | 36 | HVAC | E | HV |  |  |  |
| 23720 | East37 R/I Electric | 2d | 2007-08-28 | 2007-08-29 | 23705 | Electricians [64 h] | 2006-08-08 | Task | 2 | 3 | 2007-10-04 | 2006-08-30 | 3 | 2006-04-13 | 2006-08-31 | 2 | 2 | 2006-04-12 | 2 | 2007-10-03 | 37 | R/I Elec | E | EL |  |  |  |
| 23725 | East37 Plumbing Test | 1d | 2007-08-28 | 2007-08-28 | 23710 | Plumbers [16 h] | 2006-08-07 | Task | 1 | 1 | 2007-10-03 | 2006-08-31 | 2 | 2006-04-12 | 2006-08-31 | 1 | 1 | 2006-04-12 | 1 | 2007-10-03 | 37 | PB Test | E | PB |  |  |  |
| 23830 | East38 Drywall/2 & Finishes | 2d | 2007-08-28 | 2007-08-29 | 23825, 23820, 23815 | Carpenters [96 h] | 2006-08-08 | Task | 1 | 3 | 2007-10-05 | 2006-09-01 | 3 | 2006-04-13 | 2006-09-04 | 2 | 1 | 2006-04-12 | 2 | 2007-10-05 | 38 | Drywall | E | CP |  |  |  |
| 23935 | East39 Electric Fixtures | 2d | 2007-08-28 | 2007-08-29 | 23930 | Electricians [32 h] | 2006-08-08 | Task | 2 | 3 | 2007-10-05 | 2006-09-05 | 3 | 2006-04-13 | 2006-09-06 | 2 | 2 | 2006-04-12 | 2 | 2007-10-04 | 39 | Elec Fixt | E | EL |  |  |  |
| 23940 | East39 Plumbing Fixtures | 2d | 2007-08-28 | 2007-08-29 | 23930 | Plumbers [32 h] | 2006-08-08 | Task | 2 | 3 | 2007-10-05 | 2006-09-05 | 3 | 2006-04-13 | 2006-09-06 | 2 | 2 | 2006-04-12 | 2 | 2007-10-04 | 39 | PB Fixt | E | PB |  |  |  |
| 23945 | East39 HVAC Fixtures | 1d | 2007-08-28 | 2007-08-28 | 23930 | HVAC Sheet Metal [16 h] | 2006-08-07 | Task | 1 | 1 | 2007-10-04 | 2006-09-06 | 2 | 2006-04-12 | 2006-09-06 | 1 | 1 | 2006-04-12 | 1 | 2007-10-04 | 39 | HVAC | E | HV |  |  |  |
| 24050 | East40 Paint & Carpeting | 2d | 2007-08-28 | 2007-08-29 | 24045, 24040, 24035 | Subcontract Work [96 h] | 2006-08-08 | Task | 2 | 3 | 2007-10-05 | 2006-09-07 | 3 | 2006-04-13 | 2006-09-08 | 2 | 2 | 2006-04-12 | 2 | 2007-10-04 | 40 | Paint | E | SB |  |  |  |
| 9955 | SiteGS Casino Practice Operations | 30d | 2007-08-29 | 2007-10-09 | 9950 |  |  |  | 30 |  | 2007-11-01 |  |  |  |  |  | 30 |  |  | 2007-09-21 |  |  | S |  | 52 | GS |  |
| 12600 | West26 Layout Floor | 1d | 2007-08-29 | 2007-08-29 | 12700, 1670, 1540 | Carpenters [32 h] | 2006-08-02 | Task | 1 | 1 | 2007-11-09 | 2006-08-17 | 2 | 2006-03-16 | 2006-08-17 | 1 | 1 | 2006-03-16 | 1 | 2007-11-09 | 26 | Layout | W | CP |  |  |  |
| 22600 | East26 Layout Floor | 1d | 2007-08-29 | 2007-08-29 | 22700, 2670, 2540 | Carpenters [32 h] | 2006-08-21 | Task | 1 | 1 | 2007-10-08 | 2006-06-22 | 2 | 2006-04-13 | 2006-06-22 | 1 | 1 | 2006-04-13 | 1 | 2007-10-08 | 26 | Layout | E | CP |  |  |  |
| 12500 | West25 Layout Floor | 1d | 2007-08-30 | 2007-08-30 | 12600, 1670, 1540 | Carpenters [32 h] | 2006-08-04 | Task | 2 | 1 | 2007-11-13 | 2006-08-21 | 2 | 2006-03-17 | 2006-08-21 | 1 | 2 | 2006-03-17 | 1 | 2007-11-12 | 25 | Layout | W | CP |  |  |  |
| 13505 | West35 Studs & Drywall/1 | 2d | 2007-08-30 | 2007-08-31 | 13605, 13500 | Carpenters [96 h] | 2006-07-25 | Task | 2 | 3 | 2007-11-09 | 2006-07-25 | 3 | 2006-03-20 | 2006-07-26 | 2 | 2 | 2006-03-17 | 2 | 2007-11-08 | 35 | Stud | W | CP | 87 |  |  |
| 13510 | West35 R/I Plumbing | 2d | 2007-08-30 | 2007-08-31 | 13610, 13500 | Plumbers [64 h] | 2006-07-25 | Task | 2 | 3 | 2007-11-08 | 2006-07-26 | 3 | 2006-03-20 | 2006-07-27 | 2 | 2 | 2006-03-17 | 2 | 2007-11-07 | 35 | R/I PB | W | PB |  |  |  |
| 13515 | West35 HVAC Ductwork | 2d | 2007-08-30 | 2007-08-31 | 13615, 13500 | HVAC Sheet Metal [64 h] | 2006-07-25 | Task | 3 | 3 | 2007-11-09 | 2006-07-27 | 3 | 2006-03-20 | 2006-07-28 | 2 | 3 | 2006-03-17 | 2 | 2007-11-07 | 35 | HVAC | W | HV |  |  |  |
| 13620 | West36 R/I Electric | 2d | 2007-08-30 | 2007-08-31 | 13605 | Electricians [64 h] | 2006-07-25 | Task | 1 | 3 | 2007-11-08 | 2006-08-30 | 3 | 2006-03-20 | 2006-08-31 | 2 | 1 | 2006-03-17 | 2 | 2007-11-08 | 36 | R/I Elec | W | EL |  |  |  |
| 13625 | West36 Plumbing Test | 1d | 2007-08-30 | 2007-08-30 | 13610 | Plumbers [16 h] | 2006-07-24 | Task | 1 | 1 | 2007-11-07 | 2006-08-31 | 2 | 2006-03-17 | 2006-08-31 | 1 | 1 | 2006-03-17 | 1 | 2007-11-07 | 36 | PB Test | W | PB |  |  |  |
| 13730 | West37 Drywall/2 & Finishes | 2d | 2007-08-30 | 2007-08-31 | 13725, 13720, 13715 | Carpenters [96 h] | 2006-07-25 | Task | 1 | 3 | 2007-11-07 | 2006-09-01 | 3 | 2006-03-20 | 2006-09-04 | 2 | 1 | 2006-03-17 | 2 | 2007-11-07 | 37 | Drywall | W | CP |  |  |  |
| 13835 | West38 Electric Fixtures | 2d | 2007-08-30 | 2007-08-31 | 13830 | Electricians [32 h] | 2006-07-25 | Task | 1 | 3 | 2007-11-12 | 2006-09-05 | 3 | 2006-03-20 | 2006-09-06 | 2 | 1 | 2006-03-17 | 2 | 2007-11-12 | 38 | Elec Fixt | W | EL |  |  |  |
| 13840 | West38 Plumbing Fixtures | 2d | 2007-08-30 | 2007-08-31 | 13830 | Plumbers [32 h] | 2006-07-25 | Task | 2 | 3 | 2007-11-13 | 2006-09-05 | 3 | 2006-03-20 | 2006-09-06 | 2 | 2 | 2006-03-17 | 2 | 2007-11-12 | 38 | PB Fixt | W | PB |  |  |  |
| 13845 | West38 HVAC Fixtures | 1d | 2007-08-30 | 2007-08-30 | 13830 | HVAC Sheet Metal [16 h] | 2006-07-24 | Task | 2 | 1 | 2007-11-13 | 2006-09-06 | 2 | 2006-03-17 | 2006-09-06 | 1 | 2 | 2006-03-17 | 1 | 2007-11-12 | 38 | HVAC | W | HV |  |  |  |
| 13950 | West39 Paint & Carpeting | 2d | 2007-08-30 | 2007-08-31 | 13945, 13940, 13935 | Subcontract Work [96 h] | 2006-07-25 | Task | 2 | 3 | 2007-11-09 | 2006-09-07 | 3 | 2006-03-20 | 2006-09-08 | 2 | 2 | 2006-03-17 | 2 | 2007-11-08 | 39 | Paint | W | SB |  |  |  |
| 22500 | East25 Layout Floor | 1d | 2007-08-30 | 2007-08-30 | 22600, 2670, 2540 | Carpenters [32 h] | 2006-08-23 | Task | 1 | 1 | 2007-10-09 | 2006-06-23 | 2 | 2006-04-14 | 2006-06-23 | 1 | 1 | 2006-04-14 | 1 | 2007-10-09 | 25 | Layout | E | CP |  |  |  |
| 23505 | East35 Studs & Drywall/1 | 2d | 2007-08-30 | 2007-08-31 | 23605, 23500 | Carpenters [96 h] | 2006-08-11 | Task | 2 | 3 | 2007-10-08 | 2006-07-25 | 3 | 2006-04-17 | 2006-07-26 | 2 | 2 | 2006-04-14 | 2 | 2007-10-05 | 35 | Stud | E | CP | 85 |  |  |
| 23510 | East35 R/I Plumbing | 2d | 2007-08-30 | 2007-08-31 | 23610, 23500 | Plumbers [64 h] | 2006-08-11 | Task | 2 | 3 | 2007-10-08 | 2006-07-26 | 3 | 2006-04-17 | 2006-07-27 | 2 | 2 | 2006-04-14 | 2 | 2007-10-05 | 35 | R/I PB | E | PB |  |  |  |
| 23515 | East35 HVAC Ductwork | 2d | 2007-08-30 | 2007-08-31 | 23615, 23500 | HVAC Sheet Metal [64 h] | 2006-08-11 | Task | 3 | 3 | 2007-10-05 | 2006-07-27 | 3 | 2006-04-17 | 2006-07-28 | 2 | 3 | 2006-04-14 | 2 | 2007-10-03 | 35 | HVAC | E | HV |  |  |  |
| 23620 | East36 R/I Electric | 2d | 2007-08-30 | 2007-08-31 | 23605 | Electricians [64 h] | 2006-08-11 | Task | 2 | 3 | 2007-10-08 | 2006-08-30 | 3 | 2006-04-17 | 2006-08-31 | 2 | 2 | 2006-04-14 | 2 | 2007-10-05 | 36 | R/I Elec | E | EL |  |  |  |
| 23625 | East36 Plumbing Test | 1d | 2007-08-30 | 2007-08-30 | 23610 | Plumbers [16 h] | 2006-08-10 | Task | 1 | 1 | 2007-10-05 | 2006-08-31 | 2 | 2006-04-14 | 2006-08-31 | 1 | 1 | 2006-04-14 | 1 | 2007-10-05 | 36 | PB Test | E | PB |  |  |  |
| 23730 | East37 Drywall/2 & Finishes | 2d | 2007-08-30 | 2007-08-31 | 23725, 23720, 23715 | Carpenters [96 h] | 2006-08-11 | Task | 2 | 3 | 2007-10-08 | 2006-09-01 | 3 | 2006-04-17 | 2006-09-04 | 2 | 2 | 2006-04-14 | 2 | 2007-10-05 | 37 | Drywall | E | CP |  |  |  |
| 23835 | East38 Electric Fixtures | 2d | 2007-08-30 | 2007-08-31 | 23830 | Electricians [32 h] | 2006-08-11 | Task | 2 | 3 | 2007-10-09 | 2006-09-05 | 3 | 2006-04-17 | 2006-09-06 | 2 | 2 | 2006-04-14 | 2 | 2007-10-08 | 38 | Elec Fixt | E | EL |  |  |  |
| 23840 | East38 Plumbing Fixtures | 2d | 2007-08-30 | 2007-08-31 | 23830 | Plumbers [32 h] | 2006-08-11 | Task | 2 | 3 | 2007-10-09 | 2006-09-05 | 3 | 2006-04-17 | 2006-09-06 | 2 | 2 | 2006-04-14 | 2 | 2007-10-08 | 38 | PB Fixt | E | PB |  |  |  |
| 23845 | East38 HVAC Fixtures | 1d | 2007-08-30 | 2007-08-30 | 23830 | HVAC Sheet Metal [16 h] | 2006-08-10 | Task | 1 | 1 | 2007-10-08 | 2006-09-06 | 2 | 2006-04-14 | 2006-09-06 | 1 | 1 | 2006-04-14 | 1 | 2007-10-08 | 38 | HVAC | E | HV |  |  |  |
| 23950 | East39 Paint & Carpeting | 2d | 2007-08-30 | 2007-08-31 | 23945, 23940, 23935 | Subcontract Work [96 h] | 2006-08-11 | Task | 1 | 3 | 2007-10-08 | 2006-09-07 | 3 | 2006-04-17 | 2006-09-08 | 2 | 1 | 2006-04-14 | 2 | 2007-10-08 | 39 | Paint | E | SB |  |  |  |
| 12400 | West24 Layout Floor | 1d | 2007-08-31 | 2007-08-31 | 12500, 1670, 1540 | Carpenters [32 h] | 2006-08-08 | Task | 1 | 1 | 2007-11-14 | 2006-08-23 | 2 | 2006-03-20 | 2006-08-23 | 1 | 1 | 2006-03-20 | 1 | 2007-11-14 | 24 | Layout | W | CP |  |  |  |
| 22400 | East24 Layout Floor | 1d | 2007-08-31 | 2007-08-31 | 22500, 2670, 2540 | Carpenters [32 h] | 2006-08-25 | Task | 1 | 1 | 2007-10-10 | 2006-06-26 | 2 | 2006-04-17 | 2006-06-26 | 1 | 1 | 2006-04-17 | 1 | 2007-10-10 | 24 | Layout | E | CP |  |  |  |
| 2264 | Skybridge Electric Fixtures | 10d | 2007-09-03 | 2007-09-14 | 2262 | Electricians [32 h] | 2006-07-18 | Task | 9 | 3 | 2007-11-13 | 2006-09-05 | 3 | 2006-03-30 | 2006-09-06 | 2 | 9 | 2006-03-29 | 2 | 2007-11-01 | 22 | Elec Fixt | E | EL | 86 |  | (ID)2264 (Distribution)Triangle(10;10;15) |
| 2266 | Skybridge Plumbing Fixtures | 10d | 2007-09-03 | 2007-09-14 | 2262 | Plumbers [32 h] | 2006-07-18 | Task | 9 | 3 | 2007-11-13 | 2006-09-05 | 3 | 2006-03-30 | 2006-09-06 | 2 | 9 | 2006-03-29 | 2 | 2007-11-01 | 22 | PB Fixt | E | PB | 86 |  | (ID)2266 (Distribution)Triangle(10;10;15) |
| 2268 | Skybridge HVAC Fixtures | 5d | 2007-09-03 | 2007-09-07 | 2262 | HVAC Sheet Metal [16 h] | 2006-07-17 | Task | 6 | 1 | 2007-11-08 | 2006-09-06 | 2 | 2006-03-29 | 2006-09-06 | 1 | 6 | 2006-03-29 | 1 | 2007-11-01 | 22 | HVAC Fixt | E | HV | 86 |  |  |
| 12300 | West23 Layout Floor | 1d | 2007-09-03 | 2007-09-03 | 12400, 1670, 1540 | Carpenters [32 h] | 2006-08-10 | Task | 1 | 1 | 2007-11-15 | 2006-08-25 | 2 | 2006-03-21 | 2006-08-25 | 1 | 1 | 2006-03-21 | 1 | 2007-11-15 |  | Layout | W | CP |  | 23 |  |
| 13405 | West34 Studs & Drywall/1 | 2d | 2007-09-03 | 2007-09-04 | 13505, 13400 | Carpenters [96 h] | 2006-07-28 | Task | 3 | 3 | 2007-11-14 | 2006-07-27 | 3 | 2006-03-22 | 2006-07-28 | 2 | 3 | 2006-03-21 | 2 | 2007-11-12 | 34 | Stud | W | CP | 87 |  |  |
| 13410 | West34 R/I Plumbing | 2d | 2007-09-03 | 2007-09-04 | 13510, 13400 | Plumbers [64 h] | 2006-07-28 | Task | 1 | 3 | 2007-11-09 | 2006-07-28 | 3 | 2006-03-22 | 2006-07-31 | 2 | 1 | 2006-03-21 | 2 | 2007-11-09 | 34 | R/I PB | W | PB |  |  |  |
| 13415 | West34 HVAC Ductwork | 2d | 2007-09-03 | 2007-09-04 | 13515, 13400 | HVAC Sheet Metal [64 h] | 2006-07-28 | Task | 1 | 3 | 2007-11-12 | 2006-07-31 | 3 | 2006-03-22 | 2006-08-01 | 2 | 1 | 2006-03-21 | 2 | 2007-11-12 | 34 | HVAC | W | HV |  |  |  |
| 13520 | West35 R/I Electric | 2d | 2007-09-03 | 2007-09-04 | 13505 | Electricians [64 h] | 2006-07-28 | Task | 1 | 3 | 2007-11-12 | 2006-08-30 | 3 | 2006-03-22 | 2006-08-31 | 2 | 1 | 2006-03-21 | 2 | 2007-11-12 | 35 | R/I Elec | W | EL |  |  |  |
| 13525 | West35 Plumbing Test | 1d | 2007-09-03 | 2007-09-03 | 13510 | Plumbers [16 h] | 2006-07-27 | Task | 1 | 1 | 2007-11-09 | 2006-08-31 | 2 | 2006-03-21 | 2006-08-31 | 1 | 1 | 2006-03-21 | 1 | 2007-11-09 | 35 | PB Test | W | PB |  |  |  |
| 13630 | West36 Drywall/2 & Finishes | 2d | 2007-09-03 | 2007-09-04 | 13625, 13620, 13615 | Carpenters [96 h] | 2006-07-28 | Task | 3 | 3 | 2007-11-13 | 2006-09-01 | 3 | 2006-03-22 | 2006-09-04 | 2 | 3 | 2006-03-21 | 2 | 2007-11-09 | 36 | Drywall | W | CP |  |  |  |
| 13735 | West37 Electric Fixtures | 2d | 2007-09-03 | 2007-09-04 | 13730 | Electricians [32 h] | 2006-07-28 | Task | 2 | 3 | 2007-11-09 | 2006-09-05 | 3 | 2006-03-22 | 2006-09-06 | 2 | 2 | 2006-03-21 | 2 | 2007-11-08 | 37 | Elec Fixt | W | EL |  |  |  |
| 13740 | West37 Plumbing Fixtures | 2d | 2007-09-03 | 2007-09-04 | 13730 | Plumbers [32 h] | 2006-07-28 | Task | 2 | 3 | 2007-11-09 | 2006-09-05 | 3 | 2006-03-22 | 2006-09-06 | 2 | 2 | 2006-03-21 | 2 | 2007-11-08 | 37 | PB Fixt | W | PB |  |  |  |
| 13745 | West37 HVAC Fixtures | 1d | 2007-09-03 | 2007-09-03 | 13730 | HVAC Sheet Metal [16 h] | 2006-07-27 | Task | 1 | 1 | 2007-11-08 | 2006-09-06 | 2 | 2006-03-21 | 2006-09-06 | 1 | 1 | 2006-03-21 | 1 | 2007-11-08 | 37 | HVAC | W | HV |  |  |  |
| 13850 | West38 Paint & Carpeting | 2d | 2007-09-03 | 2007-09-04 | 13845, 13840, 13835 | Subcontract Work [96 h] | 2006-07-28 | Task | 3 | 3 | 2007-11-16 | 2006-09-07 | 3 | 2006-03-22 | 2006-09-08 | 2 | 3 | 2006-03-21 | 2 | 2007-11-14 | 38 | Paint | W | SB |  |  |  |
| 22300 | East23 Layout Floor | 1d | 2007-09-03 | 2007-09-03 | 22400, 2670, 2540 | Carpenters [32 h] | 2006-08-29 | Task | 1 | 1 | 2007-10-11 | 2006-06-27 | 2 | 2006-04-18 | 2006-06-27 | 1 | 1 | 2006-04-18 | 1 | 2007-10-11 |  | Layout | E | CP |  | 23 |  |
| 23405 | East34 Studs & Drywall/1 | 2d | 2007-09-03 | 2007-09-04 | 23505, 23400 | Carpenters [96 h] | 2006-08-16 | Task | 2 | 3 | 2007-10-10 | 2006-07-27 | 3 | 2006-04-19 | 2006-07-28 | 2 | 2 | 2006-04-18 | 2 | 2007-10-09 | 34 | Stud | E | CP | 85 |  |  |
| 23410 | East34 R/I Plumbing | 2d | 2007-09-03 | 2007-09-04 | 23510, 23400 | Plumbers [64 h] | 2006-08-16 | Task | 2 | 3 | 2007-10-10 | 2006-07-28 | 3 | 2006-04-19 | 2006-07-31 | 2 | 2 | 2006-04-18 | 2 | 2007-10-09 | 34 | R/I PB | E | PB |  |  |  |

| ID | Activity | Duration | Start | Finish | Predecessors | Resources | MEF | P3 Task Type | ADur | PESS | AFinish | Imported Late Start | MOD | Imported Early Finish | Imported Late Finish | MOST | ActDur | Imported Early Start | OPTD | AStart | LOC2 Floor | WTYP | LOC1 Tower | CRTY | PL-1 | LOC3 Segment |
| --- | --- | --- | --- | --- | --- | --- | --- | --- | --- | --- | --- | --- | --- | --- | --- | --- | --- | --- | --- | --- | --- | --- | --- | --- | --- | --- |
| 23415 | East34 HVAC Ductwork | 2d | 2007-09-03 | 2007-09-04 | 23515, 23400 | HVAC Sheet Metal [64 h] | 2006-08-16 | Task | 3 | 3 | 2007-10-10 | 2006-07-31 | 3 | 2006-04-19 | 2006-08-01 | 2 | 3 | 2006-04-18 | 2 | 2007-10-08 | 34 | HVAC | E | HV |  |  |
| 23520 | East35 R/I Electric | 2d | 2007-09-03 | 2007-09-04 | 23505 | Electricians [64 h] | 2006-08-16 | Task | 1 | 3 | 2007-10-09 | 2006-08-30 | 3 | 2006-04-19 | 2006-08-31 | 2 | 1 | 2006-04-18 | 2 | 2007-10-09 | 35 | R/I Elec | E | EL |  |  |
| 23525 | East35 Plumbing Test | 1d | 2007-09-03 | 2007-09-03 | 23510 | Plumbers [16 h] | 2006-08-15 | Task | 1 | 1 | 2007-10-09 | 2006-08-31 | 2 | 2006-04-18 | 2006-08-31 | 1 | 1 | 2006-04-18 | 1 | 2007-10-09 | 35 | PB Test | E | PB |  |  |
| 23630 | East36 Drywall/2 & Finishes | 2d | 2007-09-03 | 2007-09-04 | 23625, 23620, 23615 | Carpenters [96 h] | 2006-08-16 | Task | 1 | 3 | 2007-10-09 | 2006-09-01 | 3 | 2006-04-19 | 2006-09-04 | 2 | 1 | 2006-04-18 | 2 | 2007-10-09 | 36 | Drywall | E | CP |  |  |
| 23735 | East37 Electric Fixtures | 2d | 2007-09-03 | 2007-09-04 | 23730 | Electricians [32 h] | 2006-08-16 | Task | 2 | 3 | 2007-10-10 | 2006-09-05 | 3 | 2006-04-19 | 2006-09-06 | 2 | 2 | 2006-04-18 | 2 | 2007-10-09 | 37 | Elec Fixt | E | EL |  |  |
| 23740 | East37 Plumbing Fixtures | 2d | 2007-09-03 | 2007-09-04 | 23730 | Plumbers [32 h] | 2006-08-16 | Task | 2 | 3 | 2007-10-10 | 2006-09-05 | 3 | 2006-04-19 | 2006-09-06 | 2 | 2 | 2006-04-18 | 2 | 2007-10-09 | 37 | PB Fixt | E | PB |  |  |
| 23745 | East37 HVAC Fixtures | 1d | 2007-09-03 | 2007-09-03 | 23730 | HVAC Sheet Metal [16 h] | 2006-08-15 | Task | 1 | 1 | 2007-10-09 | 2006-09-06 | 2 | 2006-04-18 | 2006-09-06 | 1 | 1 | 2006-04-18 | 1 | 2007-10-09 | 37 | HVAC | E | HV |  |  |
| 23850 | East38 Paint & Carpeting | 2d | 2007-09-03 | 2007-09-04 | 23845, 23840, 23835 | Subcontract Work [96 h] | 2006-08-16 | Task | 1 | 3 | 2007-10-10 | 2006-09-07 | 3 | 2006-04-19 | 2006-09-08 | 2 | 1 | 2006-04-18 | 2 | 2007-10-10 | 38 | Paint | E | SB |  |  |
| 13305 | West33 Studs & Drywall/1 | 2d | 2007-09-05 | 2007-09-06 | 13405, 13300 | Carpenters [96 h] | 2006-08-02 | Task | 3 | 3 | 2007-11-19 | 2006-07-31 | 3 | 2006-03-24 | 2006-08-01 | 2 | 3 | 2006-03-23 | 2 | 2007-11-15 | 33 | Stud | W | CP | 87 |  |
| 13310 | West33 R/I Plumbing | 2d | 2007-09-05 | 2007-09-06 | 13410, 13300 | Plumbers [64 h] | 2006-08-02 | Task | 2 | 3 | 2007-11-13 | 2006-08-01 | 3 | 2006-03-24 | 2006-08-02 | 2 | 2 | 2006-03-23 | 2 | 2007-11-12 | 33 | R/I PB | W | PB |  |  |
| 13315 | West33 HVAC Ductwork | 2d | 2007-09-05 | 2007-09-06 | 13415, 13300 | HVAC Sheet Metal [64 h] | 2006-08-02 | Task | 2 | 3 | 2007-11-14 | 2006-08-02 | 3 | 2006-03-24 | 2006-08-03 | 2 | 2 | 2006-03-23 | 2 | 2007-11-13 | 33 | HVAC | W | HV |  |  |
| 13420 | West34 R/I Electric | 2d | 2007-09-05 | 2007-09-06 | 13405 | Electricians [64 h] | 2006-08-02 | Task | 3 | 3 | 2007-11-19 | 2006-08-30 | 3 | 2006-03-24 | 2006-08-31 | 2 | 3 | 2006-03-23 | 2 | 2007-11-15 | 34 | R/I Elec | W | EL |  |  |
| 13425 | West34 Plumbing Test | 1d | 2007-09-05 | 2007-09-05 | 13410 | Plumbers [16 h] | 2006-08-01 | Task | 1 | 1 | 2007-11-12 | 2006-08-31 | 2 | 2006-03-23 | 2006-08-31 | 1 | 1 | 2006-03-23 | 1 | 2007-11-12 | 34 | PB Test | W | PB |  |  |
| 13530 | West35 Drywall/2 & Finishes | 2d | 2007-09-05 | 2007-09-06 | 13525, 13520, 13515 | Carpenters [96 h] | 2006-08-02 | Task | 2 | 3 | 2007-11-14 | 2006-09-01 | 3 | 2006-03-24 | 2006-09-04 | 2 | 2 | 2006-03-23 | 2 | 2007-11-13 | 35 | Drywall | W | CP |  |  |
| 13635 | West36 Electric Fixtures | 2d | 2007-09-05 | 2007-09-06 | 13630 | Electricians [32 h] | 2006-08-02 | Task | 1 | 3 | 2007-11-14 | 2006-09-05 | 3 | 2006-03-24 | 2006-09-06 | 2 | 1 | 2006-03-23 | 2 | 2007-11-14 | 36 | Elec Fixt | W | EL |  |  |
| 13640 | West36 Plumbing Fixtures | 2d | 2007-09-05 | 2007-09-06 | 13630 | Plumbers [32 h] | 2006-08-02 | Task | 2 | 3 | 2007-11-15 | 2006-09-05 | 3 | 2006-03-24 | 2006-09-06 | 2 | 2 | 2006-03-23 | 2 | 2007-11-14 | 36 | PB Fixt | W | PB |  |  |
| 13645 | West36 HVAC Fixtures | 1d | 2007-09-05 | 2007-09-05 | 13630 | HVAC Sheet Metal [16 h] | 2006-08-01 | Task | 1 | 1 | 2007-11-14 | 2006-09-06 | 2 | 2006-03-23 | 2006-09-06 | 1 | 1 | 2006-03-23 | 1 | 2007-11-14 | 36 | HVAC | W | HV |  |  |
| 13750 | West37 Paint & Carpeting | 2d | 2007-09-05 | 2007-09-06 | 13745, 13740, 13735 | Subcontract Work [96 h] | 2006-08-02 | Task | 2 | 3 | 2007-11-13 | 2006-09-07 | 3 | 2006-03-24 | 2006-09-08 | 2 | 2 | 2006-03-23 | 2 | 2007-11-12 | 37 | Paint | W | SB |  |  |
| 23305 | East33 Studs & Drywall/1 | 2d | 2007-09-05 | 2007-09-06 | 23405, 23300 | Carpenters [96 h] | 2006-08-21 | Task | 1 | 3 | 2007-10-11 | 2006-07-31 | 3 | 2006-04-21 | 2006-08-01 | 2 | 1 | 2006-04-20 | 2 | 2007-10-11 | 33 | Stud | E | CP | 85 |  |
| 23310 | East33 R/I Plumbing | 2d | 2007-09-05 | 2007-09-06 | 23410, 23300 | Plumbers [64 h] | 2006-08-21 | Task | 3 | 3 | 2007-10-15 | 2006-08-01 | 3 | 2006-04-21 | 2006-08-02 | 2 | 3 | 2006-04-20 | 2 | 2007-10-11 | 33 | R/I PB | E | PB |  |  |
| 23315 | East33 HVAC Ductwork | 2d | 2007-09-05 | 2007-09-06 | 23415, 23300 | HVAC Sheet Metal [64 h] | 2006-08-21 | Task | 3 | 3 | 2007-10-15 | 2006-08-02 | 3 | 2006-04-21 | 2006-08-03 | 2 | 3 | 2006-04-20 | 2 | 2007-10-11 | 33 | HVAC | E | HV |  |  |
| 23420 | East34 R/I Electric | 2d | 2007-09-05 | 2007-09-06 | 23405 | Electricians [64 h] | 2006-08-21 | Task | 2 | 3 | 2007-10-12 | 2006-08-30 | 3 | 2006-04-21 | 2006-08-31 | 2 | 2 | 2006-04-20 | 2 | 2007-10-11 | 34 | R/I Elec | E | EL |  |  |
| 23425 | East34 Plumbing Test | 1d | 2007-09-05 | 2007-09-05 | 23410 | Plumbers [16 h] | 2006-08-18 | Task | 1 | 1 | 2007-10-11 | 2006-08-31 | 2 | 2006-04-20 | 2006-08-31 | 1 | 1 | 2006-04-20 | 1 | 2007-10-11 | 34 | PB Test | E | PB |  |  |
| 23530 | East35 Drywall/2 & Finishes | 2d | 2007-09-05 | 2007-09-06 | 23525, 23520, 23515 | Carpenters [96 h] | 2006-08-21 | Task | 2 | 3 | 2007-10-11 | 2006-09-01 | 3 | 2006-04-21 | 2006-09-04 | 2 | 2 | 2006-04-20 | 2 | 2007-10-10 | 35 | Drywall | E | CP |  |  |
| 23635 | East36 Electric Fixtures | 2d | 2007-09-05 | 2007-09-06 | 23630 | Electricians [32 h] | 2006-08-21 | Task | 2 | 3 | 2007-10-11 | 2006-09-05 | 3 | 2006-04-21 | 2006-09-06 | 2 | 2 | 2006-04-20 | 2 | 2007-10-10 | 36 | Elec Fixt | E | EL |  |  |
| 23640 | East36 Plumbing Fixtures | 2d | 2007-09-05 | 2007-09-06 | 23630 | Plumbers [32 h] | 2006-08-21 | Task | 3 | 3 | 2007-10-12 | 2006-09-05 | 3 | 2006-04-21 | 2006-09-06 | 2 | 3 | 2006-04-20 | 2 | 2007-10-10 | 36 | PB Fixt | E | PB |  |  |
| 23645 | East36 HVAC Fixtures | 1d | 2007-09-05 | 2007-09-05 | 23630 | HVAC Sheet Metal [16 h] | 2006-08-18 | Task | 1 | 1 | 2007-10-10 | 2006-09-06 | 2 | 2006-04-20 | 2006-09-06 | 1 | 1 | 2006-04-20 | 1 | 2007-10-10 | 36 | HVAC | E | HV |  |  |
| 23750 | East37 Paint & Carpeting | 2d | 2007-09-05 | 2007-09-06 | 23745, 23740, 23735 | Subcontract Work [96 h] | 2006-08-21 | Task | 2 | 3 | 2007-10-12 | 2006-09-07 | 3 | 2006-04-21 | 2006-09-08 | 2 | 2 | 2006-04-20 | 2 | 2007-10-11 | 37 | Paint | E | SB |  |  |
| 13205 | West32 Studs & Drywall/1 | 2d | 2007-09-07 | 2007-09-10 | 13305, 13200 | Carpenters [96 h] | 2006-08-07 | Task | 2 | 3 | 2007-11-21 | 2006-08-02 | 3 | 2006-03-28 | 2006-08-03 | 2 | 2 | 2006-03-27 | 2 | 2007-11-20 |  | Stud | W | CP | 87 | 32 |
| 13210 | West32 R/I Plumbing | 2d | 2007-09-07 | 2007-09-10 | 13310, 13200 | Plumbers [64 h] | 2006-08-07 | Task | 3 | 3 | 2007-11-16 | 2006-08-03 | 3 | 2006-03-28 | 2006-08-04 | 2 | 3 | 2006-03-27 | 2 | 2007-11-14 |  | R/I PB | W | PB |  | 32 |
| 13215 | West32 HVAC Ductwork | 2d | 2007-09-07 | 2007-09-10 | 13315, 13200 | HVAC Sheet Metal [64 h] | 2006-08-07 | Task | 2 | 3 | 2007-11-16 | 2006-08-04 | 3 | 2006-03-28 | 2006-08-07 | 2 | 2 | 2006-03-27 | 2 | 2007-11-15 |  | HVAC | W | HV |  | 32 |
| 13320 | West33 R/I Electric | 2d | 2007-09-07 | 2007-09-10 | 13305 | Electricians [64 h] | 2006-08-07 | Task | 2 | 3 | 2007-11-21 | 2006-08-30 | 3 | 2006-03-28 | 2006-08-31 | 2 | 2 | 2006-03-27 | 2 | 2007-11-20 | 33 | R/I Elec | W | EL |  |  |
| 13325 | West33 Plumbing Test | 1d | 2007-09-07 | 2007-09-07 | 13310 | Plumbers [16 h] | 2006-08-04 | Task | 1 | 1 | 2007-11-14 | 2006-08-31 | 2 | 2006-03-27 | 2006-08-31 | 1 | 1 | 2006-03-27 | 1 | 2007-11-14 | 33 | PB Test | W | PB |  |  |
| 13430 | West34 Drywall/2 & Finishes | 2d | 2007-09-07 | 2007-09-10 | 13425, 13420, 13415 | Carpenters [96 h] | 2006-08-07 | Task | 2 | 3 | 2007-11-21 | 2006-09-01 | 3 | 2006-03-28 | 2006-09-04 | 2 | 2 | 2006-03-27 | 2 | 2007-11-20 | 34 | Drywall | W | CP |  |  |
| 13535 | West35 Electric Fixtures | 2d | 2007-09-07 | 2007-09-10 | 13530 | Electricians [32 h] | 2006-08-07 | Task | 2 | 3 | 2007-11-16 | 2006-09-05 | 3 | 2006-03-28 | 2006-09-06 | 2 | 2 | 2006-03-27 | 2 | 2007-11-15 | 35 | Elec Fixt | W | EL |  |  |
| 13540 | West35 Plumbing Fixtures | 2d | 2007-09-07 | 2007-09-10 | 13530 | Plumbers [32 h] | 2006-08-07 | Task | 2 | 3 | 2007-11-16 | 2006-09-05 | 3 | 2006-03-28 | 2006-09-06 | 2 | 2 | 2006-03-27 | 2 | 2007-11-15 | 35 | PB Fixt | W | PB |  |  |
| 13545 | West35 HVAC Fixtures | 1d | 2007-09-07 | 2007-09-07 | 13530 | HVAC Sheet Metal [16 h] | 2006-08-04 | Task | 2 | 1 | 2007-11-16 | 2006-09-06 | 2 | 2006-03-27 | 2006-09-06 | 1 | 2 | 2006-03-27 | 1 | 2007-11-15 | 35 | HVAC | W | HV |  |  |
| 13650 | West36 Paint & Carpeting | 2d | 2007-09-07 | 2007-09-10 | 13645, 13640, 13635 | Subcontract Work [96 h] | 2006-08-07 | Task | 2 | 3 | 2007-11-19 | 2006-09-07 | 3 | 2006-03-28 | 2006-09-08 | 2 | 2 | 2006-03-27 | 2 | 2007-11-16 | 36 | Paint | W | SB |  |  |
| 23205 | East32 Studs & Drywall/1 | 2d | 2007-09-07 | 2007-09-10 | 23305, 23200 | Carpenters [96 h] | 2006-08-24 | Task | 2 | 3 | 2007-10-15 | 2006-08-02 | 3 | 2006-04-25 | 2006-08-03 | 2 | 2 | 2006-04-24 | 2 | 2007-10-12 |  | Stud | E | CP | 85 | 32 |
| 23210 | East32 R/I Plumbing | 2d | 2007-09-07 | 2007-09-10 | 23310, 23200 | Plumbers [64 h] | 2006-08-24 | Task | 2 | 3 | 2007-10-17 | 2006-08-03 | 3 | 2006-04-25 | 2006-08-04 | 2 | 2 | 2006-04-24 | 2 | 2007-10-16 |  | R/I PB | E | PB |  | 32 |
| 23215 | East32 HVAC Ductwork | 2d | 2007-09-07 | 2007-09-10 | 23315, 23200 | HVAC Sheet Metal [64 h] | 2006-08-24 | Task | 2 | 3 | 2007-10-17 | 2006-08-04 | 3 | 2006-04-25 | 2006-08-07 | 2 | 2 | 2006-04-24 | 2 | 2007-10-16 |  | HVAC | E | HV |  | 32 |
| 23320 | East33 R/I Electric | 2d | 2007-09-07 | 2007-09-10 | 23305 | Electricians [64 h] | 2006-08-24 | Task | 1 | 3 | 2007-10-12 | 2006-08-30 | 3 | 2006-04-25 | 2006-08-31 | 2 | 1 | 2006-04-24 | 2 | 2007-10-12 | 33 | R/I Elec | E | EL |  |  |
| 23325 | East33 Plumbing Test | 1d | 2007-09-07 | 2007-09-07 | 23310 | Plumbers [16 h] | 2006-08-23 | Task | 2 | 1 | 2007-10-17 | 2006-08-31 | 2 | 2006-04-24 | 2006-08-31 | 1 | 2 | 2006-04-24 | 1 | 2007-10-16 | 33 | PB Test | E | PB |  |  |
| 23430 | East34 Drywall/2 & Finishes | 2d | 2007-09-07 | 2007-09-10 | 23425, 23420, 23415 | Carpenters [96 h] | 2006-08-24 | Task | 2 | 3 | 2007-10-16 | 2006-09-01 | 3 | 2006-04-25 | 2006-09-04 | 2 | 2 | 2006-04-24 | 2 | 2007-10-15 | 34 | Drywall | E | CP |  |  |
| 23535 | East35 Electric Fixtures | 2d | 2007-09-07 | 2007-09-10 | 23530 | Electricians [32 h] | 2006-08-24 | Task | 2 | 3 | 2007-10-15 | 2006-09-05 | 3 | 2006-04-25 | 2006-09-06 | 2 | 2 | 2006-04-24 | 2 | 2007-10-12 | 35 | Elec Fixt | E | EL |  |  |
| 23540 | East35 Plumbing Fixtures | 2d | 2007-09-07 | 2007-09-10 | 23530 | Plumbers [32 h] | 2006-08-24 | Task | 2 | 3 | 2007-10-15 | 2006-09-05 | 3 | 2006-04-25 | 2006-09-06 | 2 | 2 | 2006-04-24 | 2 | 2007-10-12 | 35 | PB Fixt | E | PB |  |  |
| 23545 | East35 HVAC Fixtures | 1d | 2007-09-07 | 2007-09-07 | 23530 | HVAC Sheet Metal [16 h] | 2006-08-23 | Task | 1 | 1 | 2007-10-12 | 2006-09-06 | 2 | 2006-04-24 | 2006-09-06 | 1 | 1 | 2006-04-24 | 1 | 2007-10-12 | 35 | HVAC | E | HV |  |  |
| 23650 | East36 Paint & Carpeting | 2d | 2007-09-07 | 2007-09-10 | 23645, 23640, 23635 | Subcontract Work [96 h] | 2006-08-24 | Task | 1 | 3 | 2007-10-15 | 2006-09-07 | 3 | 2006-04-25 | 2006-09-08 | 2 | 1 | 2006-04-24 | 2 | 2007-10-15 | 36 | Paint | E | SB |  |  |
| 13105 | West31 Studs & Drywall/1 | 2d | 2007-09-11 | 2007-09-12 | 13205, 13100 | Carpenters [96 h] | 2006-08-10 | Task | 2 | 3 | 2007-11-23 | 2006-08-04 | 3 | 2006-03-30 | 2006-08-07 | 2 | 2 | 2006-03-29 | 2 | 2007-11-22 | 31 | Stud | W | CP | 87 |  |
| 13110 | West31 R/I Plumbing | 2d | 2007-09-11 | 2007-09-12 | 13210, 13100 | Plumbers [64 h] | 2006-08-10 | Task | 2 | 3 | 2007-11-20 | 2006-08-07 | 3 | 2006-03-30 | 2006-08-08 | 2 | 2 | 2006-03-29 | 2 | 2007-11-19 | 31 | R/I PB | W | PB |  |  |
| 13115 | West31 HVAC Ductwork | 2d | 2007-09-11 | 2007-09-12 | 13215, 13100 | HVAC Sheet Metal [64 h] | 2006-08-10 | Task | 2 | 3 | 2007-11-20 | 2006-08-08 | 3 | 2006-03-30 | 2006-08-09 | 2 | 2 | 2006-03-29 | 2 | 2007-11-19 | 31 | HVAC | W | HV |  |  |
| 13220 | West32 R/I Electric | 2d | 2007-09-11 | 2007-09-12 | 13205 | Electricians [64 h] | 2006-08-10 | Task | 3 | 3 | 2007-11-26 | 2006-08-30 | 3 | 2006-03-30 | 2006-08-31 | 2 | 3 | 2006-03-29 | 2 | 2007-11-22 |  | R/I Elec | W | EL |  | 32 |
| 13225 | West32 Plumbing Test | 1d | 2007-09-11 | 2007-09-11 | 13210 | Plumbers [16 h] | 2006-08-09 | Task | 1 | 1 | 2007-11-19 | 2006-08-31 | 2 | 2006-03-29 | 2006-08-31 | 1 | 1 | 2006-03-29 | 1 | 2007-11-19 |  | PB Test | W | PB |  | 32 |
| 13330 | West33 Drywall/2 & Finishes | 2d | 2007-09-11 | 2007-09-12 | 13325, 13320, 13315 | Carpenters [96 h] | 2006-08-10 | Task | 2 | 3 | 2007-11-23 | 2006-09-01 | 3 | 2006-03-30 | 2006-09-04 | 2 | 2 | 2006-03-29 | 2 | 2007-11-22 | 33 | Drywall | W | CP |  |  |
| 13435 | West34 Electric Fixtures | 2d | 2007-09-11 | 2007-09-12 | 13430 | Electricians [32 h] | 2006-08-10 | Task | 2 | 3 | 2007-11-23 | 2006-09-05 | 3 | 2006-03-30 | 2006-09-06 | 2 | 2 | 2006-03-29 | 2 | 2007-11-22 | 34 | Elec Fixt | W | EL |  |  |
| 13440 | West34 Plumbing Fixtures | 2d | 2007-09-11 | 2007-09-12 | 13430 | Plumbers [32 h] | 2006-08-10 | Task | 2 | 3 | 2007-11-23 | 2006-09-05 | 3 | 2006-03-30 | 2006-09-06 | 2 | 2 | 2006-03-29 | 2 | 2007-11-22 | 34 | PB Fixt | W | PB |  |  |
| 13445 | West34 HVAC Fixtures | 1d | 2007-09-11 | 2007-09-11 | 13430 | HVAC Sheet Metal [16 h] | 2006-08-09 | Task | 1 | 1 | 2007-11-22 | 2006-09-06 | 2 | 2006-03-29 | 2006-09-06 | 1 | 1 | 2006-03-29 | 1 | 2007-11-22 | 34 | HVAC | W | HV |  |  |
| 13550 | West35 Paint & Carpeting | 2d | 2007-09-11 | 2007-09-12 | 13545, 13540, 13535 | Subcontract Work [96 h] | 2006-08-10 | Task | 2 | 3 | 2007-11-20 | 2006-09-07 | 3 | 2006-03-30 | 2006-09-08 | 2 | 2 | 2006-03-29 | 2 | 2007-11-19 | 35 | Paint | W | SB |  |  |
| 23105 | East31 Studs & Drywall/1 | 2d | 2007-09-11 | 2007-09-12 | 23205, 23100 | Carpenters [96 h] | 2006-08-29 | Task | 2 | 3 | 2007-10-17 | 2006-08-04 | 3 | 2006-04-27 | 2006-08-07 | 2 | 2 | 2006-04-26 | 2 | 2007-10-16 | 31 | Stud | E | CP | 85 |  |
| 23110 | East31 R/I Plumbing | 2d | 2007-09-11 | 2007-09-12 | 23210, 23100 | Plumbers [64 h] | 2006-08-29 | Task | 2 | 3 | 2007-10-19 | 2006-08-07 | 3 | 2006-04-27 | 2006-08-08 | 2 | 2 | 2006-04-26 | 2 | 2007-10-18 | 31 | R/I PB | E | PB |  |  |
| 23115 | East31 HVAC Ductwork | 2d | 2007-09-11 | 2007-09-12 | 23215, 23100 | HVAC Sheet Metal [64 h] | 2006-08-29 | Task | 2 | 3 | 2007-10-19 | 2006-08-08 | 3 | 2006-04-27 | 2006-08-09 | 2 | 2 | 2006-04-26 | 2 | 2007-10-18 | 31 | HVAC | E | HV |  |  |
| 23220 | East32 R/I Electric | 2d | 2007-09-11 | 2007-09-12 | 23205 | Electricians [64 h] | 2006-08-29 | Task | 2 | 3 | 2007-10-17 | 2006-08-30 | 3 | 2006-04-27 | 2006-08-31 | 2 | 2 | 2006-04-26 | 2 | 2007-10-16 |  | R/I Elec | E | EL |  | 32 |
| 23225 | East32 Plumbing Test | 1d | 2007-09-11 | 2007-09-11 | 23210 | Plumbers [16 h] | 2006-08-28 | Task | 2 | 1 | 2007-10-19 | 2006-08-31 | 2 | 2006-04-26 | 2006-08-31 | 1 | 2 | 2006-04-26 | 1 | 2007-10-18 |  | PB Test | E | PB |  | 32 |
| 23330 | East33 Drywall/2 & Finishes | 2d | 2007-09-11 | 2007-09-12 | 23325, 23320, 23315 | Carpenters [96 h] | 2006-08-29 | Task | 1 | 3 | 2007-10-18 | 2006-09-01 | 3 | 2006-04-27 | 2006-09-04 | 2 | 1 | 2006-04-26 | 2 | 2007-10-18 | 33 | Drywall | E | CP |  |  |
| 23435 | East34 Electric Fixtures | 2d | 2007-09-11 | 2007-09-12 | 23430 | Electricians [32 h] | 2006-08-29 | Task | 2 | 3 | 2007-10-18 | 2006-09-05 | 3 | 2006-04-27 | 2006-09-06 | 2 | 2 | 2006-04-26 | 2 | 2007-10-17 | 34 | Elec Fixt | E | EL |  |  |
| 23440 | East34 Plumbing Fixtures | 2d | 2007-09-11 | 2007-09-12 | 23430 | Plumbers [32 h] | 2006-08-29 | Task | 2 | 3 | 2007-10-18 | 2006-09-05 | 3 | 2006-04-27 | 2006-09-06 | 2 | 2 | 2006-04-26 | 2 | 2007-10-17 | 34 | PB Fixt | E | PB |  |  |
| 23445 | East34 HVAC Fixtures | 1d | 2007-09-11 | 2007-09-11 | 23430 | HVAC Sheet Metal [16 h] | 2006-08-28 | Task | 2 | 1 | 2007-10-18 | 2006-09-06 | 2 | 2006-04-26 | 2006-09-06 | 1 | 2 | 2006-04-26 | 1 | 2007-10-17 | 34 | HVAC | E | HV |  |  |
| 23550 | East35 Paint & Carpeting | 2d | 2007-09-11 | 2007-09-12 | 23545, 23540, 23535 | Subcontract Work [96 h] | 2006-08-29 | Task | 3 | 3 | 2007-10-18 | 2006-09-07 | 3 | 2006-04-27 | 2006-09-08 | 2 | 3 | 2006-04-26 | 2 | 2007-10-16 | 35 | Paint | E | SB |  |  |
| 13005 | West30 Studs & Drywall/1 | 2d | 2007-09-13 | 2007-09-14 | 13105, 13000 | Carpenters [96 h] | 2006-08-15 | Task | 1 | 3 | 2007-11-26 | 2006-08-08 | 3 | 2006-04-03 | 2006-08-09 | 2 | 1 | 2006-03-31 | 2 | 2007-11-26 | 30 | Stud | W | CP | 87 |  |
| 13010 | West30 R/I Plumbing | 2d | 2007-09-13 | 2007-09-14 | 13110, 13000 | Plumbers [64 h] | 2006-08-15 | Task | 2 | 3 | 2007-11-22 | 2006-08-09 | 3 | 2006-04-03 | 2006-08-10 | 2 | 2 | 2006-03-31 | 2 | 2007-11-21 | 30 | R/I PB | W | PB |  |  |

| ID | Activity | Duration | Start | Finish | Predecessors | Resources | MEF | P3 Task Type | ADur | PESS | AFinish | Imported Late Start | MOD | Imported Early Finish | Imported Late Finish | MOST | ActDur | Imported Early Start | OPTD | AStart | LOC2 Floor | WTYP | LOC1 Tower | CRTY | LOC3 Segment | PL-1 | Duration Risk Validation |
| --- | --- | --- | --- | --- | --- | --- | --- | --- | --- | --- | --- | --- | --- | --- | --- | --- | --- | --- | --- | --- | --- | --- | --- | --- | --- | --- | --- |
| 13015 | West30 HVAC Ductwork | 2d | 2007-09-13 | 2007-09-14 | 13115, 13000 | HVAC Sheet Metal [64 h] | 2006-08-15 | Task | 2 | 3 | 2007-11-22 | 2006-08-10 | 3 | 2006-04-03 | 2006-08-11 | 2 | 2 | 2006-03-31 | 2 | 2007-11-21 | 30 | HVAC | W | HV |  |  |  |
| 13120 | West31 R/I Electric | 2d | 2007-09-13 | 2007-09-14 | 13105 | Electricians [64 h] | 2006-08-15 | Task | 3 | 3 | 2007-11-28 | 2006-08-30 | 3 | 2006-04-03 | 2006-08-31 | 2 | 3 | 2006-03-31 | 2 | 2007-11-26 | 31 | R/I Elec | W | EL |  |  |  |
| 13125 | West31 Plumbing Test | 1d | 2007-09-13 | 2007-09-13 | 13110 | Plumbers [16 h] | 2006-08-14 | Task | 1 | 1 | 2007-11-21 | 2006-08-31 | 2 | 2006-03-31 | 2006-08-31 | 1 | 1 | 2006-03-31 | 1 | 2007-11-21 | 31 | PB Test | W | PB |  |  |  |
| 13230 | West32 Drywall/2 & Finishes | 2d | 2007-09-13 | 2007-09-14 | 13225, 13220, 13215 | Carpenters [96 h] | 2006-08-15 | Task | 3 | 3 | 2007-11-29 | 2006-09-01 | 3 | 2006-04-03 | 2006-09-04 | 2 | 3 | 2006-03-31 | 2 | 2007-11-27 |  | Drywall | W | CP | 32 |  |  |
| 13335 | West33 Electric Fixtures | 2d | 2007-09-13 | 2007-09-14 | 13330 | Electricians [32 h] | 2006-08-15 | Task | 2 | 3 | 2007-11-27 | 2006-09-05 | 3 | 2006-04-03 | 2006-09-06 | 2 | 2 | 2006-03-31 | 2 | 2007-11-26 | 33 | Elec Fixt | W | EL |  |  |  |
| 13340 | West33 Plumbing Fixtures | 2d | 2007-09-13 | 2007-09-14 | 13330 | Plumbers [32 h] | 2006-08-15 | Task | 3 | 3 | 2007-11-28 | 2006-09-05 | 3 | 2006-04-03 | 2006-09-06 | 2 | 3 | 2006-03-31 | 2 | 2007-11-26 | 33 | PB Fixt | W | PB |  |  |  |
| 13345 | West33 HVAC Fixtures | 1d | 2007-09-13 | 2007-09-13 | 13330 | HVAC Sheet Metal [16 h] | 2006-08-14 | Task | 1 | 1 | 2007-11-26 | 2006-09-06 | 2 | 2006-03-31 | 2006-09-06 | 1 | 1 | 2006-03-31 | 1 | 2007-11-26 | 33 | HVAC | W | HV |  |  |  |
| 13450 | West34 Paint & Carpeting | 2d | 2007-09-13 | 2007-09-14 | 13445, 13440, 13435 | Subcontract Work [96 h] | 2006-08-15 | Task | 2 | 3 | 2007-11-27 | 2006-09-07 | 3 | 2006-04-03 | 2006-09-08 | 2 | 2 | 2006-03-31 | 2 | 2007-11-26 | 34 | Paint | W | SB |  |  |  |
| 23005 | East30 Studs & Drywall/1 | 2d | 2007-09-13 | 2007-09-14 | 23105, 23000 | Carpenters [96 h] | 2006-09-01 | Task | 3 | 3 | 2007-10-22 | 2006-08-08 | 3 | 2006-05-01 | 2006-08-09 | 2 | 3 | 2006-04-28 | 2 | 2007-10-18 | 30 | Stud | E | CP |  | 85 |  |
| 23010 | East30 R/I Plumbing | 2d | 2007-09-13 | 2007-09-14 | 23110, 23000 | Plumbers [64 h] | 2006-09-01 | Task | 2 | 3 | 2007-10-23 | 2006-08-09 | 3 | 2006-05-01 | 2006-08-10 | 2 | 2 | 2006-04-28 | 2 | 2007-10-22 | 30 | R/I PB | E | PB |  |  |  |
| 23015 | East30 HVAC Ductwork | 2d | 2007-09-13 | 2007-09-14 | 23115, 23000 | HVAC Sheet Metal [64 h] | 2006-09-01 | Task | 2 | 3 | 2007-10-23 | 2006-08-10 | 3 | 2006-05-01 | 2006-08-11 | 2 | 2 | 2006-04-28 | 2 | 2007-10-22 | 30 | HVAC | E | HV |  |  |  |
| 23120 | East31 R/I Electric | 2d | 2007-09-13 | 2007-09-14 | 23105 | Electricians [64 h] | 2006-09-01 | Task | 2 | 3 | 2007-10-19 | 2006-08-30 | 3 | 2006-05-01 | 2006-08-31 | 2 | 2 | 2006-04-28 | 2 | 2007-10-18 | 31 | R/I Elec | E | EL |  |  |  |
| 23125 | East31 Plumbing Test | 1d | 2007-09-13 | 2007-09-13 | 23110 | Plumbers [16 h] | 2006-08-31 | Task | 2 | 1 | 2007-10-23 | 2006-08-31 | 2 | 2006-04-28 | 2006-08-31 | 1 | 2 | 2006-04-28 | 1 | 2007-10-22 | 31 | PB Test | E | PB |  |  |  |
| 23230 | East32 Drywall/2 & Finishes | 2d | 2007-09-13 | 2007-09-14 | 23225, 23220, 23215 | Carpenters [96 h] | 2006-09-01 | Task | 2 | 3 | 2007-10-23 | 2006-09-01 | 3 | 2006-05-01 | 2006-09-04 | 2 | 2 | 2006-04-28 | 2 | 2007-10-22 |  | Drywall | E | CP | 32 |  |  |
| 23335 | East33 Electric Fixtures | 2d | 2007-09-13 | 2007-09-14 | 23330 | Electricians [32 h] | 2006-09-01 | Task | 2 | 3 | 2007-10-22 | 2006-09-05 | 3 | 2006-05-01 | 2006-09-06 | 2 | 2 | 2006-04-28 | 2 | 2007-10-19 | 33 | Elec Fixt | E | EL |  |  |  |
| 23340 | East33 Plumbing Fixtures | 2d | 2007-09-13 | 2007-09-14 | 23330 | Plumbers [32 h] | 2006-09-01 | Task | 3 | 3 | 2007-10-23 | 2006-09-05 | 3 | 2006-05-01 | 2006-09-06 | 2 | 3 | 2006-04-28 | 2 | 2007-10-19 | 33 | PB Fixt | E | PB |  |  |  |
| 23345 | East33 HVAC Fixtures | 1d | 2007-09-13 | 2007-09-13 | 23330 | HVAC Sheet Metal [16 h] | 2006-08-31 | Task | 1 | 1 | 2007-10-19 | 2006-09-06 | 2 | 2006-04-28 | 2006-09-06 | 1 | 1 | 2006-04-28 | 1 | 2007-10-19 | 33 | HVAC | E | HV |  |  |  |
| 23450 | East34 Paint & Carpeting | 2d | 2007-09-13 | 2007-09-14 | 23445, 23440, 23435 | Subcontract Work [96 h] | 2006-09-01 | Task | 1 | 3 | 2007-10-19 | 2006-09-07 | 3 | 2006-05-01 | 2006-09-08 | 2 | 1 | 2006-04-28 | 2 | 2007-10-19 | 34 | Paint | E | SB |  |  |  |
| 2270 | Skybridge Paint & Carpeting | 10d | 2007-09-17 | 2007-09-28 | 2268, 2266, 2264 | Subcontract Work [96 h] | 2006-07-21 | Task | 10 | 3 | 2007-11-27 | 2006-09-07 | 3 | 2006-04-03 | 2006-09-08 | 2 | 10 | 2006-03-31 | 2 | 2007-11-14 | 22 | Paint | E | SB |  | 86 | (ID)2270 (Distribution)Triangle(10;10;15) |
| 12905 | West29 Studs & Drywall/1 | 2d | 2007-09-17 | 2007-09-18 | 13005, 12900 | Carpenters [96 h] | 2006-08-18 | Task | 2 | 3 | 2007-11-28 | 2006-08-10 | 3 | 2006-04-05 | 2006-08-11 | 2 | 2 | 2006-04-04 | 2 | 2007-11-27 | 29 | Stud | W | CP |  | 87 |  |
| 12910 | West29 R/I Plumbing | 2d | 2007-09-17 | 2007-09-18 | 13010, 12900 | Plumbers [64 h] | 2006-08-18 | Task | 2 | 3 | 2007-11-26 | 2006-08-11 | 3 | 2006-04-05 | 2006-08-14 | 2 | 2 | 2006-04-04 | 2 | 2007-11-23 | 29 | R/I PB | W | PB |  |  |  |
| 12915 | West29 HVAC Ductwork | 2d | 2007-09-17 | 2007-09-18 | 13015, 12900 | HVAC Sheet Metal [64 h] | 2006-08-18 | Task | 2 | 3 | 2007-11-26 | 2006-08-14 | 3 | 2006-04-05 | 2006-08-15 | 2 | 2 | 2006-04-04 | 2 | 2007-11-23 | 29 | HVAC | W | HV |  |  |  |
| 13020 | West30 R/I Electric | 2d | 2007-09-17 | 2007-09-18 | 13005 | Electricians [64 h] | 2006-08-18 | Task | 2 | 3 | 2007-11-28 | 2006-08-30 | 3 | 2006-04-05 | 2006-08-31 | 2 | 2 | 2006-04-04 | 2 | 2007-11-27 | 30 | R/I Elec | W | EL |  |  |  |
| 13025 | West30 Plumbing Test | 1d | 2007-09-17 | 2007-09-17 | 13010 | Plumbers [16 h] | 2006-08-17 | Task | 2 | 1 | 2007-11-26 | 2006-08-31 | 2 | 2006-04-04 | 2006-08-31 | 1 | 2 | 2006-04-04 | 1 | 2007-11-23 | 30 | PB Test | W | PB |  |  |  |
| 13130 | West31 Drywall/2 & Finishes | 2d | 2007-09-17 | 2007-09-18 | 13125, 13120, 13115 | Carpenters [96 h] | 2006-08-18 | Task | 3 | 3 | 2007-12-03 | 2006-09-01 | 3 | 2006-04-05 | 2006-09-04 | 2 | 3 | 2006-04-04 | 2 | 2007-11-29 | 31 | Drywall | W | CP |  |  |  |
| 13235 | West32 Electric Fixtures | 2d | 2007-09-17 | 2007-09-18 | 13230 | Electricians [32 h] | 2006-08-18 | Task | 3 | 3 | 2007-12-04 | 2006-09-05 | 3 | 2006-04-05 | 2006-09-06 | 2 | 3 | 2006-04-04 | 2 | 2007-11-30 |  | Elec Fixt | W | EL | 32 |  |  |
| 13240 | West32 Plumbing Fixtures | 2d | 2007-09-17 | 2007-09-18 | 13230 | Plumbers [32 h] | 2006-08-18 | Task | 2 | 3 | 2007-12-03 | 2006-09-05 | 3 | 2006-04-05 | 2006-09-06 | 2 | 2 | 2006-04-04 | 2 | 2007-11-30 |  | PB Fixt | W | PB | 32 |  |  |
| 13245 | West32 HVAC Fixtures | 1d | 2007-09-17 | 2007-09-17 | 13230 | HVAC Sheet Metal [16 h] | 2006-08-17 | Task | 1 | 1 | 2007-11-30 | 2006-09-06 | 2 | 2006-04-04 | 2006-09-06 | 1 | 1 | 2006-04-04 | 1 | 2007-11-30 |  | HVAC | W | HV | 32 |  |  |
| 13350 | West33 Paint & Carpeting | 2d | 2007-09-17 | 2007-09-18 | 13345, 13340, 13335 | Subcontract Work [96 h] | 2006-08-18 | Task | 3 | 3 | 2007-12-03 | 2006-09-07 | 3 | 2006-04-05 | 2006-09-08 | 2 | 3 | 2006-04-04 | 2 | 2007-11-29 | 33 | Paint | W | SB |  |  |  |
| 22905 | East29 Studs & Drywall/1 | 2d | 2007-09-17 | 2007-09-18 | 23005, 22900 | Carpenters [96 h] | 2006-09-06 | Task | 3 | 3 | 2007-10-25 | 2006-08-10 | 3 | 2006-05-03 | 2006-08-11 | 2 | 3 | 2006-05-02 | 2 | 2007-10-23 | 29 | Stud | E | CP |  | 85 |  |
| 22910 | East29 R/I Plumbing | 2d | 2007-09-17 | 2007-09-18 | 23010, 22900 | Plumbers [64 h] | 2006-09-06 | Task | 2 | 3 | 2007-10-25 | 2006-08-11 | 3 | 2006-05-03 | 2006-08-14 | 2 | 2 | 2006-05-02 | 2 | 2007-10-24 | 29 | R/I PB | E | PB |  |  |  |
| 22915 | East29 HVAC Ductwork | 2d | 2007-09-17 | 2007-09-18 | 23015, 22900 | HVAC Sheet Metal [64 h] | 2006-09-06 | Task | 2 | 3 | 2007-10-25 | 2006-08-14 | 3 | 2006-05-03 | 2006-08-15 | 2 | 2 | 2006-05-02 | 2 | 2007-10-24 | 29 | HVAC | E | HV |  |  |  |
| 23020 | East30 R/I Electric | 2d | 2007-09-17 | 2007-09-18 | 23005 | Electricians [64 h] | 2006-09-06 | Task | 2 | 3 | 2007-10-24 | 2006-08-30 | 3 | 2006-05-03 | 2006-08-31 | 2 | 2 | 2006-05-02 | 2 | 2007-10-23 | 30 | R/I Elec | E | EL |  |  |  |
| 23025 | East30 Plumbing Test | 1d | 2007-09-17 | 2007-09-17 | 23010 | Plumbers [16 h] | 2006-09-05 | Task | 2 | 1 | 2007-10-25 | 2006-08-31 | 2 | 2006-05-02 | 2006-08-31 | 1 | 2 | 2006-05-02 | 1 | 2007-10-24 | 30 | PB Test | E | PB |  |  |  |
| 23130 | East31 Drywall/2 & Finishes | 2d | 2007-09-17 | 2007-09-18 | 23125, 23120, 23115 | Carpenters [96 h] | 2006-09-06 | Task | 3 | 3 | 2007-10-26 | 2006-09-01 | 3 | 2006-05-03 | 2006-09-04 | 2 | 3 | 2006-05-02 | 2 | 2007-10-24 | 31 | Drywall | E | CP |  |  |  |
| 23235 | East32 Electric Fixtures | 2d | 2007-09-17 | 2007-09-18 | 23230 | Electricians [32 h] | 2006-09-06 | Task | 2 | 3 | 2007-10-25 | 2006-09-05 | 3 | 2006-05-03 | 2006-09-06 | 2 | 2 | 2006-05-02 | 2 | 2007-10-24 |  | Elec Fixt | E | EL | 32 |  |  |
| 23240 | East32 Plumbing Fixtures | 2d | 2007-09-17 | 2007-09-18 | 23230 | Plumbers [32 h] | 2006-09-06 | Task | 2 | 3 | 2007-10-25 | 2006-09-05 | 3 | 2006-05-03 | 2006-09-06 | 2 | 2 | 2006-05-02 | 2 | 2007-10-24 |  | PB Fixt | E | PB | 32 |  |  |
| 23245 | East32 HVAC Fixtures | 1d | 2007-09-17 | 2007-09-17 | 23230 | HVAC Sheet Metal [16 h] | 2006-09-05 | Task | 1 | 1 | 2007-10-24 | 2006-09-06 | 2 | 2006-05-02 | 2006-09-06 | 1 | 1 | 2006-05-02 | 1 | 2007-10-24 |  | HVAC | E | HV | 32 |  |  |
| 23350 | East33 Paint & Carpeting | 2d | 2007-09-17 | 2007-09-18 | 23345, 23340, 23335 | Subcontract Work [96 h] | 2006-09-06 | Task | 2 | 3 | 2007-10-25 | 2006-09-07 | 3 | 2006-05-03 | 2006-09-08 | 2 | 2 | 2006-05-02 | 2 | 2007-10-24 | 33 | Paint | E | SB |  |  |  |
| 12805 | West28 Studs & Drywall/1 | 2d | 2007-09-19 | 2007-09-20 | 12905, 12800 | Carpenters [96 h] | 2006-08-23 | Task | 2 | 3 | 2007-11-30 | 2006-08-14 | 3 | 2006-04-07 | 2006-08-15 | 2 | 2 | 2006-04-06 | 2 | 2007-11-29 | 28 | Stud | W | CP |  | 87 |  |
| 12810 | West28 R/I Plumbing | 2d | 2007-09-19 | 2007-09-20 | 12910, 12800 | Plumbers [64 h] | 2006-08-23 | Task | 2 | 3 | 2007-11-28 | 2006-08-15 | 3 | 2006-04-07 | 2006-08-16 | 2 | 2 | 2006-04-06 | 2 | 2007-11-27 | 28 | R/I PB | W | PB |  |  |  |
| 12815 | West28 HVAC Ductwork | 2d | 2007-09-19 | 2007-09-20 | 12915, 12800 | HVAC Sheet Metal [64 h] | 2006-08-23 | Task | 2 | 3 | 2007-11-28 | 2006-08-16 | 3 | 2006-04-07 | 2006-08-17 | 2 | 2 | 2006-04-06 | 2 | 2007-11-27 | 28 | HVAC | W | HV |  |  |  |
| 12920 | West29 R/I Electric | 2d | 2007-09-19 | 2007-09-20 | 12905 | Electricians [64 h] | 2006-08-23 | Task | 2 | 3 | 2007-11-30 | 2006-08-30 | 3 | 2006-04-07 | 2006-08-31 | 2 | 2 | 2006-04-06 | 2 | 2007-11-29 | 29 | R/I Elec | W | EL |  |  |  |
| 12925 | West29 Plumbing Test | 1d | 2007-09-19 | 2007-09-19 | 12910 | Plumbers [16 h] | 2006-08-22 | Task | 1 | 1 | 2007-11-27 | 2006-08-31 | 2 | 2006-04-06 | 2006-08-31 | 1 | 1 | 2006-04-06 | 1 | 2007-11-27 | 29 | PB Test | W | PB |  |  |  |
| 13030 | West30 Drywall/2 & Finishes | 2d | 2007-09-19 | 2007-09-20 | 13025, 13020, 13015 | Carpenters [96 h] | 2006-08-23 | Task | 2 | 3 | 2007-11-30 | 2006-09-01 | 3 | 2006-04-07 | 2006-09-04 | 2 | 2 | 2006-04-06 | 2 | 2007-11-29 | 30 | Drywall | W | CP |  |  |  |
| 13135 | West31 Electric Fixtures | 2d | 2007-09-19 | 2007-09-20 | 13130 | Electricians [32 h] | 2006-08-23 | Task | 2 | 3 | 2007-12-05 | 2006-09-05 | 3 | 2006-04-07 | 2006-09-06 | 2 | 2 | 2006-04-06 | 2 | 2007-12-04 | 31 | Elec Fixt | W | EL |  |  |  |
| 13140 | West31 Plumbing Fixtures | 2d | 2007-09-19 | 2007-09-20 | 13130 | Plumbers [32 h] | 2006-08-23 | Task | 1 | 3 | 2007-12-04 | 2006-09-05 | 3 | 2006-04-07 | 2006-09-06 | 2 | 1 | 2006-04-06 | 2 | 2007-12-04 | 31 | PB Fixt | W | PB |  |  |  |
| 13145 | West31 HVAC Fixtures | 1d | 2007-09-19 | 2007-09-19 | 13130 | HVAC Sheet Metal [16 h] | 2006-08-22 | Task | 1 | 1 | 2007-12-04 | 2006-09-06 | 2 | 2006-04-06 | 2006-09-06 | 1 | 1 | 2006-04-06 | 1 | 2007-12-04 | 31 | HVAC | W | HV |  |  |  |
| 13250 | West32 Paint & Carpeting | 2d | 2007-09-19 | 2007-09-20 | 13245, 13240, 13235 | Subcontract Work [96 h] | 2006-08-23 | Task | 2 | 3 | 2007-12-06 | 2006-09-07 | 3 | 2006-04-07 | 2006-09-08 | 2 | 2 | 2006-04-06 | 2 | 2007-12-05 |  | Paint | W | SB | 32 |  |  |
| 22805 | East28 Studs & Drywall/1 | 2d | 2007-09-19 | 2007-09-20 | 22905, 22800 | Carpenters [96 h] | 2006-09-11 | Task | 2 | 3 | 2007-10-29 | 2006-08-14 | 3 | 2006-05-05 | 2006-08-15 | 2 | 2 | 2006-05-04 | 2 | 2007-10-26 | 28 | Stud | E | CP |  | 85 |  |
| 22810 | East28 R/I Plumbing | 2d | 2007-09-19 | 2007-09-20 | 22910, 22800 | Plumbers [64 h] | 2006-09-11 | Task | 1 | 3 | 2007-10-26 | 2006-08-15 | 3 | 2006-05-05 | 2006-08-16 | 2 | 1 | 2006-05-04 | 2 | 2007-10-26 | 28 | R/I PB | E | PB |  |  |  |
| 22815 | East28 HVAC Ductwork | 2d | 2007-09-19 | 2007-09-20 | 22915, 22800 | HVAC Sheet Metal [64 h] | 2006-09-11 | Task | 1 | 3 | 2007-10-26 | 2006-08-16 | 3 | 2006-05-05 | 2006-08-17 | 2 | 1 | 2006-05-04 | 2 | 2007-10-26 | 28 | HVAC | E | HV |  |  |  |
| 22920 | East29 R/I Electric | 2d | 2007-09-19 | 2007-09-20 | 22905 | Electricians [64 h] | 2006-09-11 | Task | 2 | 3 | 2007-10-29 | 2006-08-30 | 3 | 2006-05-05 | 2006-08-31 | 2 | 2 | 2006-05-04 | 2 | 2007-10-26 | 29 | R/I Elec | E | EL |  |  |  |
| 22925 | East29 Plumbing Test | 1d | 2007-09-19 | 2007-09-19 | 22910 | Plumbers [16 h] | 2006-09-08 | Task | 1 | 1 | 2007-10-26 | 2006-08-31 | 2 | 2006-05-04 | 2006-08-31 | 1 | 1 | 2006-05-04 | 1 | 2007-10-26 | 29 | PB Test | E | PB |  |  |  |
| 23030 | East30 Drywall/2 & Finishes | 2d | 2007-09-19 | 2007-09-20 | 23025, 23020, 23015 | Carpenters [96 h] | 2006-09-11 | Task | 2 | 3 | 2007-10-29 | 2006-09-01 | 3 | 2006-05-05 | 2006-09-04 | 2 | 2 | 2006-05-04 | 2 | 2007-10-26 | 30 | Drywall | E | CP |  |  |  |
| 23135 | East31 Electric Fixtures | 2d | 2007-09-19 | 2007-09-20 | 23130 | Electricians [32 h] | 2006-09-11 | Task | 2 | 3 | 2007-10-30 | 2006-09-05 | 3 | 2006-05-05 | 2006-09-06 | 2 | 2 | 2006-05-04 | 2 | 2007-10-29 | 31 | Elec Fixt | E | EL |  |  |  |
| 23140 | East31 Plumbing Fixtures | 2d | 2007-09-19 | 2007-09-20 | 23130 | Plumbers [32 h] | 2006-09-11 | Task | 2 | 3 | 2007-10-30 | 2006-09-05 | 3 | 2006-05-05 | 2006-09-06 | 2 | 2 | 2006-05-04 | 2 | 2007-10-29 | 31 | PB Fixt | E | PB |  |  |  |
| 23145 | East31 HVAC Fixtures | 1d | 2007-09-19 | 2007-09-19 | 23130 | HVAC Sheet Metal [16 h] | 2006-09-08 | Task | 1 | 1 | 2007-10-29 | 2006-09-06 | 2 | 2006-05-04 | 2006-09-06 | 1 | 1 | 2006-05-04 | 1 | 2007-10-29 | 31 | HVAC | E | HV |  |  |  |
| 23250 | East32 Paint & Carpeting | 2d | 2007-09-19 | 2007-09-20 | 23245, 23240, 23235 | Subcontract Work [96 h] | 2006-09-11 | Task | 3 | 3 | 2007-10-30 | 2006-09-07 | 3 | 2006-05-05 | 2006-09-08 | 2 | 3 | 2006-05-04 | 2 | 2007-10-26 |  | Paint | E | SB | 32 |  |  |
| 12705 | West27 Studs & Drywall/1 | 2d | 2007-09-21 | 2007-09-24 | 12805, 12700 | Carpenters [96 h] | 2006-08-28 | Task | 2 | 3 | 2007-12-04 | 2006-08-16 | 3 | 2006-04-11 | 2006-08-17 | 2 | 2 | 2006-04-10 | 2 | 2007-12-03 | 27 | Stud | W | CP |  | 87 |  |
| 12710 | West27 R/I Plumbing | 2d | 2007-09-21 | 2007-09-24 | 12810, 12700 | Plumbers [64 h] | 2006-08-28 | Task | 3 | 3 | 2007-12-03 | 2006-08-17 | 3 | 2006-04-11 | 2006-08-18 | 2 | 3 | 2006-04-10 | 2 | 2007-11-29 | 27 | R/I PB | W | PB |  |  |  |
| 12715 | West27 HVAC Ductwork | 2d | 2007-09-21 | 2007-09-24 | 12815, 12700 | HVAC Sheet Metal [64 h] | 2006-08-28 | Task | 2 | 3 | 2007-11-30 | 2006-08-18 | 3 | 2006-04-11 | 2006-08-21 | 2 | 2 | 2006-04-10 | 2 | 2007-11-29 | 27 | HVAC | W | HV |  |  |  |
| 12820 | West28 R/I Electric | 2d | 2007-09-21 | 2007-09-24 | 12805 | Electricians [64 h] | 2006-08-28 | Task | 3 | 3 | 2007-12-05 | 2006-08-30 | 3 | 2006-04-11 | 2006-08-31 | 2 | 3 | 2006-04-10 | 2 | 2007-12-03 | 28 | R/I Elec | W | EL |  |  |  |
| 12825 | West28 Plumbing Test | 1d | 2007-09-21 | 2007-09-21 | 12810 | Plumbers [16 h] | 2006-08-25 | Task | 2 | 1 | 2007-11-30 | 2006-08-31 | 2 | 2006-04-10 | 2006-08-31 | 1 | 2 | 2006-04-10 | 1 | 2007-11-29 | 28 | PB Test | W | PB |  |  |  |
| 12930 | West29 Drywall/2 & Finishes | 2d | 2007-09-21 | 2007-09-24 | 12925, 12920, 12915 | Carpenters [96 h] | 2006-08-28 | Task | 2 | 3 | 2007-12-04 | 2006-09-01 | 3 | 2006-04-11 | 2006-09-04 | 2 | 2 | 2006-04-10 | 2 | 2007-12-03 | 29 | Drywall | W | CP |  |  |  |
| 13035 | West30 Electric Fixtures | 2d | 2007-09-21 | 2007-09-24 | 13030 | Electricians [32 h] | 2006-08-28 | Task | 2 | 3 | 2007-12-04 | 2006-09-05 | 3 | 2006-04-11 | 2006-09-06 | 2 | 2 | 2006-04-10 | 2 | 2007-12-03 | 30 | Elec Fixt | W | EL |  |  |  |
| 13040 | West30 Plumbing Fixtures | 2d | 2007-09-21 | 2007-09-24 | 13030 | Plumbers [32 h] | 2006-08-28 | Task | 2 | 3 | 2007-12-04 | 2006-09-05 | 3 | 2006-04-11 | 2006-09-06 | 2 | 2 | 2006-04-10 | 2 | 2007-12-03 | 30 | PB Fixt | W | PB |  |  |  |
| 13045 | West30 HVAC Fixtures | 1d | 2007-09-21 | 2007-09-21 | 13030 | HVAC Sheet Metal [16 h] | 2006-08-25 | Task | 1 | 1 | 2007-12-03 | 2006-09-06 | 2 | 2006-04-10 | 2006-09-06 | 1 | 1 | 2006-04-10 | 1 | 2007-12-03 | 30 | HVAC | W | HV |  |  |  |
| 13150 | West31 Paint & Carpeting | 2d | 2007-09-21 | 2007-09-24 | 13145, 13140, 13135 | Subcontract Work [96 h] | 2006-08-28 | Task | 2 | 3 | 2007-12-07 | 2006-09-07 | 3 | 2006-04-11 | 2006-09-08 | 2 | 2 | 2006-04-10 | 2 | 2007-12-06 | 31 | Paint | W | SB |  |  |  |
| 22705 | East27 Studs & Drywall/1 | 2d | 2007-09-21 | 2007-09-24 | 22805, 22700 | Carpenters [96 h] | 2006-09-14 | Task | 2 | 3 | 2007-10-31 | 2006-08-16 | 3 | 2006-05-09 | 2006-08-17 | 2 | 2 | 2006-05-08 | 2 | 2007-10-30 | 27 | Stud | E | CP |  | 85 |  |

| ID | Activity | Duration | Start | Finish | Predecessors | Resources | MEF | P3 Task Type | ADur | PESS | AFinish | Imported Late Start | MOD | Imported Early Finish | Imported Late Finish | MOST | ActDur | Imported Early Start | OPTD | AStart | LOC2 Floor | WTYP | LOC1 Tower | CRTY | PL-1 | LOC3 Segment |
| --- | --- | --- | --- | --- | --- | --- | --- | --- | --- | --- | --- | --- | --- | --- | --- | --- | --- | --- | --- | --- | --- | --- | --- | --- | --- | --- |
| 22710 | East27 R/I Plumbing | 2d | 2007-09-21 | 2007-09-24 | 22810, 22700 | Plumbers [64 h] | 2006-09-14 | Task | 3 | 3 | 2007-10-31 | 2006-08-17 | 3 | 2006-05-09 | 2006-08-18 | 2 | 3 | 2006-05-08 | 2 | 2007-10-29 | 27 | R/I PB | E | PB |  |  |
| 22715 | East27 HVAC Ductwork | 2d | 2007-09-21 | 2007-09-24 | 22815, 22700 | HVAC Sheet Metal [64 h] | 2006-09-14 | Task | 2 | 3 | 2007-10-30 | 2006-08-18 | 3 | 2006-05-09 | 2006-08-21 | 2 | 2 | 2006-05-08 | 2 | 2007-10-29 | 27 | HVAC | E | HV |  |  |
| 22820 | East28 R/I Electric | 2d | 2007-09-21 | 2007-09-24 | 22805 | Electricians [64 h] | 2006-09-14 | Task | 2 | 3 | 2007-10-31 | 2006-08-30 | 3 | 2006-05-09 | 2006-08-31 | 2 | 2 | 2006-05-08 | 2 | 2007-10-30 | 28 | R/I Elec | E | EL |  |  |
| 22825 | East28 Plumbing Test | 1d | 2007-09-21 | 2007-09-21 | 22810 | Plumbers [16 h] | 2006-09-13 | Task | 1 | 1 | 2007-10-29 | 2006-08-31 | 2 | 2006-05-08 | 2006-08-31 | 1 | 1 | 2006-05-08 | 1 | 2007-10-29 | 28 | PB Test | E | PB |  |  |
| 22930 | East29 Drywall/2 & Finishes | 2d | 2007-09-21 | 2007-09-24 | 22925, 22920, 22915 | Carpenters [96 h] | 2006-09-14 | Task | 3 | 3 | 2007-11-01 | 2006-09-01 | 3 | 2006-05-09 | 2006-09-04 | 2 | 3 | 2006-05-08 | 2 | 2007-10-30 | 29 | Drywall | E | CP |  |  |
| 23035 | East30 Electric Fixtures | 2d | 2007-09-21 | 2007-09-24 | 23030 | Electricians [32 h] | 2006-09-14 | Task | 2 | 3 | 2007-10-31 | 2006-09-05 | 3 | 2006-05-09 | 2006-09-06 | 2 | 2 | 2006-05-08 | 2 | 2007-10-30 | 30 | Elec Fixt | E | EL |  |  |
| 23040 | East30 Plumbing Fixtures | 2d | 2007-09-21 | 2007-09-24 | 23030 | Plumbers [32 h] | 2006-09-14 | Task | 1 | 3 | 2007-10-30 | 2006-09-05 | 3 | 2006-05-09 | 2006-09-06 | 2 | 1 | 2006-05-08 | 2 | 2007-10-30 | 30 | PB Fixt | E | PB |  |  |
| 23045 | East30 HVAC Fixtures | 1d | 2007-09-21 | 2007-09-21 | 23030 | HVAC Sheet Metal [16 h] | 2006-09-13 | Task | 1 | 1 | 2007-10-30 | 2006-09-06 | 2 | 2006-05-08 | 2006-09-06 | 1 | 1 | 2006-05-08 | 1 | 2007-10-30 | 30 | HVAC | E | HV |  |  |
| 23150 | East31 Paint & Carpeting | 2d | 2007-09-21 | 2007-09-24 | 23145, 23140, 23135 | Subcontract Work [96 h] | 2006-09-14 | Task | 1 | 3 | 2007-10-31 | 2006-09-07 | 3 | 2006-05-09 | 2006-09-08 | 2 | 1 | 2006-05-08 | 2 | 2007-10-31 | 31 | Paint | E | SB |  |  |
| 12605 | West26 Studs & Drywall/1 | 2d | 2007-09-25 | 2007-09-26 | 12705, 12600 | Carpenters [96 h] | 2006-08-31 | Task | 2 | 3 | 2007-12-06 | 2006-08-18 | 3 | 2006-04-13 | 2006-08-21 | 2 | 2 | 2006-04-12 | 2 | 2007-12-05 | 26 | Stud | W | CP | 87 |  |
| 12610 | West26 R/I Plumbing | 2d | 2007-09-25 | 2007-09-26 | 12710, 12600 | Plumbers [64 h] | 2006-08-31 | Task | 2 | 3 | 2007-12-05 | 2006-08-21 | 3 | 2006-04-13 | 2006-08-22 | 2 | 2 | 2006-04-12 | 2 | 2007-12-04 | 26 | R/I PB | W | PB |  |  |
| 12615 | West26 HVAC Ductwork | 2d | 2007-09-25 | 2007-09-26 | 12715, 12600 | HVAC Sheet Metal [64 h] | 2006-08-31 | Task | 2 | 3 | 2007-12-04 | 2006-08-22 | 3 | 2006-04-13 | 2006-08-23 | 2 | 2 | 2006-04-12 | 2 | 2007-12-03 | 26 | HVAC | W | HV |  |  |
| 12720 | West27 R/I Electric | 2d | 2007-09-25 | 2007-09-26 | 12705 | Electricians [64 h] | 2006-08-31 | Task | 2 | 3 | 2007-12-06 | 2006-08-30 | 3 | 2006-04-13 | 2006-08-31 | 2 | 2 | 2006-04-12 | 2 | 2007-12-05 | 27 | R/I Elec | W | EL |  |  |
| 12725 | West27 Plumbing Test | 1d | 2007-09-25 | 2007-09-25 | 12710 | Plumbers [16 h] | 2006-08-30 | Task | 1 | 1 | 2007-12-04 | 2006-08-31 | 2 | 2006-04-12 | 2006-08-31 | 1 | 1 | 2006-04-12 | 1 | 2007-12-04 | 27 | PB Test | W | PB |  |  |
| 12830 | West28 Drywall/2 & Finishes | 2d | 2007-09-25 | 2007-09-26 | 12825, 12820, 12815 | Carpenters [96 h] | 2006-08-31 | Task | 3 | 3 | 2007-12-10 | 2006-09-01 | 3 | 2006-04-13 | 2006-09-04 | 2 | 3 | 2006-04-12 | 2 | 2007-12-06 | 28 | Drywall | W | CP |  |  |
| 12935 | West29 Electric Fixtures | 2d | 2007-09-25 | 2007-09-26 | 12930 | Electricians [32 h] | 2006-08-31 | Task | 2 | 3 | 2007-12-06 | 2006-09-05 | 3 | 2006-04-13 | 2006-09-06 | 2 | 2 | 2006-04-12 | 2 | 2007-12-05 | 29 | Elec Fixt | W | EL |  |  |
| 12940 | West29 Plumbing Fixtures | 2d | 2007-09-25 | 2007-09-26 | 12930 | Plumbers [32 h] | 2006-08-31 | Task | 2 | 3 | 2007-12-06 | 2006-09-05 | 3 | 2006-04-13 | 2006-09-06 | 2 | 2 | 2006-04-12 | 2 | 2007-12-05 | 29 | PB Fixt | W | PB |  |  |
| 12945 | West29 HVAC Fixtures | 1d | 2007-09-25 | 2007-09-25 | 12930 | HVAC Sheet Metal [16 h] | 2006-08-30 | Task | 1 | 1 | 2007-12-05 | 2006-09-06 | 2 | 2006-04-12 | 2006-09-06 | 1 | 1 | 2006-04-12 | 1 | 2007-12-05 | 29 | HVAC | W | HV |  |  |
| 13050 | West30 Paint & Carpeting | 2d | 2007-09-25 | 2007-09-26 | 13045, 13040, 13035 | Subcontract Work [96 h] | 2006-08-31 | Task | 2 | 3 | 2007-12-06 | 2006-09-07 | 3 | 2006-04-13 | 2006-09-08 | 2 | 2 | 2006-04-12 | 2 | 2007-12-05 | 30 | Paint | W | SB |  |  |
| 22605 | East26 Studs & Drywall/1 | 2d | 2007-09-25 | 2007-09-26 | 22705, 22600 | Carpenters [96 h] | 2006-09-19 | Task | 1 | 3 | 2007-11-01 | 2006-08-18 | 3 | 2006-05-11 | 2006-08-21 | 2 | 1 | 2006-05-10 | 2 | 2007-11-01 | 26 | Stud | E | CP | 85 |  |
| 22610 | East26 R/I Plumbing | 2d | 2007-09-25 | 2007-09-26 | 22710, 22600 | Plumbers [64 h] | 2006-09-19 | Task | 2 | 3 | 2007-11-02 | 2006-08-21 | 3 | 2006-05-11 | 2006-08-22 | 2 | 2 | 2006-05-10 | 2 | 2007-11-01 | 26 | R/I PB | E | PB |  |  |
| 22615 | East26 HVAC Ductwork | 2d | 2007-09-25 | 2007-09-26 | 22715, 22600 | HVAC Sheet Metal [64 h] | 2006-09-19 | Task | 1 | 3 | 2007-10-31 | 2006-08-22 | 3 | 2006-05-11 | 2006-08-23 | 2 | 1 | 2006-05-10 | 2 | 2007-10-31 | 26 | HVAC | E | HV |  |  |
| 22720 | East27 R/I Electric | 2d | 2007-09-25 | 2007-09-26 | 22705 | Electricians [64 h] | 2006-09-19 | Task | 2 | 3 | 2007-11-02 | 2006-08-30 | 3 | 2006-05-11 | 2006-08-31 | 2 | 2 | 2006-05-10 | 2 | 2007-11-01 | 27 | R/I Elec | E | EL |  |  |
| 22725 | East27 Plumbing Test | 1d | 2007-09-25 | 2007-09-25 | 22710 | Plumbers [16 h] | 2006-09-18 | Task | 1 | 1 | 2007-11-01 | 2006-08-31 | 2 | 2006-05-10 | 2006-08-31 | 1 | 1 | 2006-05-10 | 1 | 2007-11-01 | 27 | PB Test | E | PB |  |  |
| 22830 | East28 Drywall/2 & Finishes | 2d | 2007-09-25 | 2007-09-26 | 22825, 22820, 22815 | Carpenters [96 h] | 2006-09-19 | Task | 1 | 3 | 2007-11-01 | 2006-09-01 | 3 | 2006-05-11 | 2006-09-04 | 2 | 1 | 2006-05-10 | 2 | 2007-11-01 | 28 | Drywall | E | CP |  |  |
| 22935 | East29 Electric Fixtures | 2d | 2007-09-25 | 2007-09-26 | 22930 | Electricians [32 h] | 2006-09-19 | Task | 2 | 3 | 2007-11-05 | 2006-09-05 | 3 | 2006-05-11 | 2006-09-06 | 2 | 2 | 2006-05-10 | 2 | 2007-11-02 | 29 | Elec Fixt | E | EL |  |  |
| 22940 | East29 Plumbing Fixtures | 2d | 2007-09-25 | 2007-09-26 | 22930 | Plumbers [32 h] | 2006-09-19 | Task | 3 | 3 | 2007-11-06 | 2006-09-05 | 3 | 2006-05-11 | 2006-09-06 | 2 | 3 | 2006-05-10 | 2 | 2007-11-02 | 29 | PB Fixt | E | PB |  |  |
| 22945 | East29 HVAC Fixtures | 1d | 2007-09-25 | 2007-09-25 | 22930 | HVAC Sheet Metal [16 h] | 2006-09-18 | Task | 1 | 1 | 2007-11-02 | 2006-09-06 | 2 | 2006-05-10 | 2006-09-06 | 1 | 1 | 2006-05-10 | 1 | 2007-11-02 | 29 | HVAC | E | HV |  |  |
| 23050 | East30 Paint & Carpeting | 2d | 2007-09-25 | 2007-09-26 | 23045, 23040, 23035 | Subcontract Work [96 h] | 2006-09-19 | Task | 2 | 3 | 2007-11-02 | 2006-09-07 | 3 | 2006-05-11 | 2006-09-08 | 2 | 2 | 2006-05-10 | 2 | 2007-11-01 | 30 | Paint | E | SB |  |  |
| 12505 | West25 Studs & Drywall/1 | 2d | 2007-09-27 | 2007-09-28 | 12605, 12500 | Carpenters [96 h] | 2006-09-05 | Task | 1 | 3 | 2007-12-07 | 2006-08-22 | 3 | 2006-04-17 | 2006-08-23 | 2 | 1 | 2006-04-14 | 2 | 2007-12-07 | 25 | Stud | W | CP | 87 |  |
| 12510 | West25 R/I Plumbing | 2d | 2007-09-27 | 2007-09-28 | 12610, 12500 | Plumbers [64 h] | 2006-09-05 | Task | 2 | 3 | 2007-12-07 | 2006-08-23 | 3 | 2006-04-17 | 2006-08-24 | 2 | 2 | 2006-04-14 | 2 | 2007-12-06 | 25 | R/I PB | W | PB |  |  |
| 12515 | West25 HVAC Ductwork | 2d | 2007-09-27 | 2007-09-28 | 12615, 12500 | HVAC Sheet Metal [64 h] | 2006-09-05 | Task | 2 | 3 | 2007-12-06 | 2006-08-24 | 3 | 2006-04-17 | 2006-08-25 | 2 | 2 | 2006-04-14 | 2 | 2007-12-05 | 25 | HVAC | W | HV |  |  |
| 12620 | West26 R/I Electric | 2d | 2007-09-27 | 2007-09-28 | 12605 | Electricians [64 h] | 2006-09-05 | Task | 3 | 3 | 2007-12-11 | 2006-08-30 | 3 | 2006-04-17 | 2006-08-31 | 2 | 3 | 2006-04-14 | 2 | 2007-12-07 | 26 | R/I Elec | W | EL |  |  |
| 12625 | West26 Plumbing Test | 1d | 2007-09-27 | 2007-09-27 | 12610 | Plumbers [16 h] | 2006-09-04 | Task | 2 | 1 | 2007-12-07 | 2006-08-31 | 2 | 2006-04-14 | 2006-08-31 | 1 | 2 | 2006-04-14 | 1 | 2007-12-06 | 26 | PB Test | W | PB |  |  |
| 12730 | West27 Drywall/2 & Finishes | 2d | 2007-09-27 | 2007-09-28 | 12725, 12720, 12715 | Carpenters [96 h] | 2006-09-05 | Task | 2 | 3 | 2007-12-10 | 2006-09-01 | 3 | 2006-04-17 | 2006-09-04 | 2 | 2 | 2006-04-14 | 2 | 2007-12-07 | 27 | Drywall | W | CP |  |  |
| 12835 | West28 Electric Fixtures | 2d | 2007-09-27 | 2007-09-28 | 12830 | Electricians [32 h] | 2006-09-05 | Task | 3 | 3 | 2007-12-13 | 2006-09-05 | 3 | 2006-04-17 | 2006-09-06 | 2 | 3 | 2006-04-14 | 2 | 2007-12-11 | 28 | Elec Fixt | W | EL |  |  |
| 12840 | West28 Plumbing Fixtures | 2d | 2007-09-27 | 2007-09-28 | 12830 | Plumbers [32 h] | 2006-09-05 | Task | 2 | 3 | 2007-12-12 | 2006-09-05 | 3 | 2006-04-17 | 2006-09-06 | 2 | 2 | 2006-04-14 | 2 | 2007-12-11 | 28 | PB Fixt | W | PB |  |  |
| 12845 | West28 HVAC Fixtures | 1d | 2007-09-27 | 2007-09-27 | 12830 | HVAC Sheet Metal [16 h] | 2006-09-04 | Task | 1 | 1 | 2007-12-11 | 2006-09-06 | 2 | 2006-04-14 | 2006-09-06 | 1 | 1 | 2006-04-14 | 1 | 2007-12-11 | 28 | HVAC | W | HV |  |  |
| 12950 | West29 Paint & Carpeting | 2d | 2007-09-27 | 2007-09-28 | 12945, 12940, 12935 | Subcontract Work [96 h] | 2006-09-05 | Task | 2 | 3 | 2007-12-10 | 2006-09-07 | 3 | 2006-04-17 | 2006-09-08 | 2 | 2 | 2006-04-14 | 2 | 2007-12-07 | 29 | Paint | W | SB |  |  |
| 22505 | East25 Studs & Drywall/1 | 2d | 2007-09-27 | 2007-09-28 | 22605, 22500 | Carpenters [96 h] | 2006-09-22 | Task | 3 | 3 | 2007-11-06 | 2006-08-22 | 3 | 2006-05-15 | 2006-08-23 | 2 | 3 | 2006-05-12 | 2 | 2007-11-02 | 25 | Stud | E | CP | 85 |  |
| 22510 | East25 R/I Plumbing | 2d | 2007-09-27 | 2007-09-28 | 22610, 22500 | Plumbers [64 h] | 2006-09-22 | Task | 2 | 3 | 2007-11-06 | 2006-08-23 | 3 | 2006-05-15 | 2006-08-24 | 2 | 2 | 2006-05-12 | 2 | 2007-11-05 | 25 | R/I PB | E | PB |  |  |
| 22515 | East25 HVAC Ductwork | 2d | 2007-09-27 | 2007-09-28 | 22615, 22500 | HVAC Sheet Metal [64 h] | 2006-09-22 | Task | 2 | 3 | 2007-11-02 | 2006-08-24 | 3 | 2006-05-15 | 2006-08-25 | 2 | 2 | 2006-05-12 | 2 | 2007-11-01 | 25 | HVAC | E | HV |  |  |
| 22620 | East26 R/I Electric | 2d | 2007-09-27 | 2007-09-28 | 22605 | Electricians [64 h] | 2006-09-22 | Task | 2 | 3 | 2007-11-05 | 2006-08-30 | 3 | 2006-05-15 | 2006-08-31 | 2 | 2 | 2006-05-12 | 2 | 2007-11-02 | 26 | R/I Elec | E | EL |  |  |
| 22625 | East26 Plumbing Test | 1d | 2007-09-27 | 2007-09-27 | 22610 | Plumbers [16 h] | 2006-09-21 | Task | 1 | 1 | 2007-11-05 | 2006-08-31 | 2 | 2006-05-12 | 2006-08-31 | 1 | 1 | 2006-05-12 | 1 | 2007-11-05 | 26 | PB Test | E | PB |  |  |
| 22730 | East27 Drywall/2 & Finishes | 2d | 2007-09-27 | 2007-09-28 | 22725, 22720, 22715 | Carpenters [96 h] | 2006-09-22 | Task | 1 | 3 | 2007-11-05 | 2006-09-01 | 3 | 2006-05-15 | 2006-09-04 | 2 | 1 | 2006-05-12 | 2 | 2007-11-05 | 27 | Drywall | E | CP |  |  |
| 22835 | East28 Electric Fixtures | 2d | 2007-09-27 | 2007-09-28 | 22830 | Electricians [32 h] | 2006-09-22 | Task | 1 | 3 | 2007-11-02 | 2006-09-05 | 3 | 2006-05-15 | 2006-09-06 | 2 | 1 | 2006-05-12 | 2 | 2007-11-02 | 28 | Elec Fixt | E | EL |  |  |
| 22840 | East28 Plumbing Fixtures | 2d | 2007-09-27 | 2007-09-28 | 22830 | Plumbers [32 h] | 2006-09-22 | Task | 2 | 3 | 2007-11-05 | 2006-09-05 | 3 | 2006-05-15 | 2006-09-06 | 2 | 2 | 2006-05-12 | 2 | 2007-11-02 | 28 | PB Fixt | E | PB |  |  |
| 22845 | East28 HVAC Fixtures | 1d | 2007-09-27 | 2007-09-27 | 22830 | HVAC Sheet Metal [16 h] | 2006-09-21 | Task | 2 | 1 | 2007-11-05 | 2006-09-06 | 2 | 2006-05-12 | 2006-09-06 | 1 | 2 | 2006-05-12 | 1 | 2007-11-02 | 28 | HVAC | E | HV |  |  |
| 22950 | East29 Paint & Carpeting | 2d | 2007-09-27 | 2007-09-28 | 22945, 22940, 22935 | Subcontract Work [96 h] | 2006-09-22 | Task | 2 | 3 | 2007-11-08 | 2006-09-07 | 3 | 2006-05-15 | 2006-09-08 | 2 | 2 | 2006-05-12 | 2 | 2007-11-07 | 29 | Paint | E | SB |  |  |
| 12405 | West24 Studs & Drywall/1 | 2d | 2007-10-01 | 2007-10-02 | 12505, 12400 | Carpenters [96 h] | 2006-09-08 | Task | 3 | 3 | 2007-12-12 | 2006-08-24 | 3 | 2006-04-19 | 2006-08-25 | 2 | 3 | 2006-04-18 | 2 | 2007-12-10 | 24 | Stud | W | CP | 87 |  |
| 12410 | West24 R/I Plumbing | 2d | 2007-10-01 | 2007-10-02 | 12510, 12400 | Plumbers [64 h] | 2006-09-08 | Task | 2 | 3 | 2007-12-11 | 2006-08-25 | 3 | 2006-04-19 | 2006-08-28 | 2 | 2 | 2006-04-18 | 2 | 2007-12-10 | 24 | R/I PB | W | PB |  |  |
| 12415 | West24 HVAC Ductwork | 2d | 2007-10-01 | 2007-10-02 | 12515, 12400 | HVAC Sheet Metal [64 h] | 2006-09-08 | Task | 2 | 3 | 2007-12-10 | 2006-08-28 | 3 | 2006-04-19 | 2006-08-29 | 2 | 2 | 2006-04-18 | 2 | 2007-12-07 | 24 | HVAC | W | HV |  |  |
| 12520 | West25 R/I Electric | 2d | 2007-10-01 | 2007-10-02 | 12505 | Electricians [64 h] | 2006-09-08 | Task | 2 | 3 | 2007-12-11 | 2006-08-30 | 3 | 2006-04-19 | 2006-08-31 | 2 | 2 | 2006-04-18 | 2 | 2007-12-10 | 25 | R/I Elec | W | EL |  |  |
| 12525 | West25 Plumbing Test | 1d | 2007-10-01 | 2007-10-01 | 12510 | Plumbers [16 h] | 2006-09-07 | Task | 2 | 1 | 2007-12-11 | 2006-08-31 | 2 | 2006-04-18 | 2006-08-31 | 1 | 2 | 2006-04-18 | 1 | 2007-12-10 | 25 | PB Test | W | PB |  |  |
| 12630 | West26 Drywall/2 & Finishes | 2d | 2007-10-01 | 2007-10-02 | 12625, 12620, 12615 | Carpenters [96 h] | 2006-09-08 | Task | 2 | 3 | 2007-12-13 | 2006-09-01 | 3 | 2006-04-19 | 2006-09-04 | 2 | 2 | 2006-04-18 | 2 | 2007-12-12 | 26 | Drywall | W | CP |  |  |
| 12735 | West27 Electric Fixtures | 2d | 2007-10-01 | 2007-10-02 | 12730 | Electricians [32 h] | 2006-09-08 | Task | 2 | 3 | 2007-12-12 | 2006-09-05 | 3 | 2006-04-19 | 2006-09-06 | 2 | 2 | 2006-04-18 | 2 | 2007-12-11 | 27 | Elec Fixt | W | EL |  |  |
| 12740 | West27 Plumbing Fixtures | 2d | 2007-10-01 | 2007-10-02 | 12730 | Plumbers [32 h] | 2006-09-08 | Task | 2 | 3 | 2007-12-12 | 2006-09-05 | 3 | 2006-04-19 | 2006-09-06 | 2 | 2 | 2006-04-18 | 2 | 2007-12-11 | 27 | PB Fixt | W | PB |  |  |
| 12745 | West27 HVAC Fixtures | 1d | 2007-10-01 | 2007-10-01 | 12730 | HVAC Sheet Metal [16 h] | 2006-09-07 | Task | 1 | 1 | 2007-12-11 | 2006-09-06 | 2 | 2006-04-18 | 2006-09-06 | 1 | 1 | 2006-04-18 | 1 | 2007-12-11 | 27 | HVAC | W | HV |  |  |
| 12850 | West28 Paint & Carpeting | 2d | 2007-10-01 | 2007-10-02 | 12845, 12840, 12835 | Subcontract Work [96 h] | 2006-09-08 | Task | 2 | 3 | 2007-12-17 | 2006-09-07 | 3 | 2006-04-19 | 2006-09-08 | 2 | 2 | 2006-04-18 | 2 | 2007-12-14 | 28 | Paint | W | SB |  |  |
| 22405 | East24 Studs & Drywall/1 | 2d | 2007-10-01 | 2007-10-02 | 22505, 22400 | Carpenters [96 h] | 2006-09-27 | Task | 2 | 3 | 2007-11-08 | 2006-08-24 | 3 | 2006-05-17 | 2006-08-25 | 2 | 2 | 2006-05-16 | 2 | 2007-11-07 | 24 | Stud | E | CP | 85 |  |
| 22410 | East24 R/I Plumbing | 2d | 2007-10-01 | 2007-10-02 | 22510, 22400 | Plumbers [64 h] | 2006-09-27 | Task | 2 | 3 | 2007-11-08 | 2006-08-25 | 3 | 2006-05-17 | 2006-08-28 | 2 | 2 | 2006-05-16 | 2 | 2007-11-07 | 24 | R/I PB | E | PB |  |  |
| 22415 | East24 HVAC Ductwork | 2d | 2007-10-01 | 2007-10-02 | 22515, 22400 | HVAC Sheet Metal [64 h] | 2006-09-27 | Task | 3 | 3 | 2007-11-07 | 2006-08-28 | 3 | 2006-05-17 | 2006-08-29 | 2 | 3 | 2006-05-16 | 2 | 2007-11-05 | 24 | HVAC | E | HV |  |  |
| 22520 | East25 R/I Electric | 2d | 2007-10-01 | 2007-10-02 | 22505 | Electricians [64 h] | 2006-09-27 | Task | 3 | 3 | 2007-11-09 | 2006-08-30 | 3 | 2006-05-17 | 2006-08-31 | 2 | 3 | 2006-05-16 | 2 | 2007-11-07 | 25 | R/I Elec | E | EL |  |  |
| 22525 | East25 Plumbing Test | 1d | 2007-10-01 | 2007-10-01 | 22510 | Plumbers [16 h] | 2006-09-26 | Task | 1 | 1 | 2007-11-07 | 2006-08-31 | 2 | 2006-05-16 | 2006-08-31 | 1 | 1 | 2006-05-16 | 1 | 2007-11-07 | 25 | PB Test | E | PB |  |  |
| 22630 | East26 Drywall/2 & Finishes | 2d | 2007-10-01 | 2007-10-02 | 22625, 22620, 22615 | Carpenters [96 h] | 2006-09-27 | Task | 3 | 3 | 2007-11-08 | 2006-09-01 | 3 | 2006-05-17 | 2006-09-04 | 2 | 3 | 2006-05-16 | 2 | 2007-11-06 | 26 | Drywall | E | CP |  |  |
| 22735 | East27 Electric Fixtures | 2d | 2007-10-01 | 2007-10-02 | 22730 | Electricians [32 h] | 2006-09-27 | Task | 2 | 3 | 2007-11-07 | 2006-09-05 | 3 | 2006-05-17 | 2006-09-06 | 2 | 2 | 2006-05-16 | 2 | 2007-11-06 | 27 | Elec Fixt | E | EL |  |  |
| 22740 | East27 Plumbing Fixtures | 2d | 2007-10-01 | 2007-10-02 | 22730 | Plumbers [32 h] | 2006-09-27 | Task | 3 | 3 | 2007-11-08 | 2006-09-05 | 3 | 2006-05-17 | 2006-09-06 | 2 | 3 | 2006-05-16 | 2 | 2007-11-06 | 27 | PB Fixt | E | PB |  |  |
| 22745 | East27 HVAC Fixtures | 1d | 2007-10-01 | 2007-10-01 | 22730 | HVAC Sheet Metal [16 h] | 2006-09-26 | Task | 1 | 1 | 2007-11-06 | 2006-09-06 | 2 | 2006-05-16 | 2006-09-06 | 1 | 1 | 2006-05-16 | 1 | 2007-11-06 | 27 | HVAC | E | HV |  |  |
| 22850 | East28 Paint & Carpeting | 2d | 2007-10-01 | 2007-10-02 | 22845, 22840, 22835 | Subcontract Work [96 h] | 2006-09-27 | Task | 2 | 3 | 2007-11-07 | 2006-09-07 | 3 | 2006-05-17 | 2006-09-08 | 2 | 2 | 2006-05-16 | 2 | 2007-11-06 | 28 | Paint | E | SB |  |  |
| 12305 | West23 Studs & Drywall/1 | 2d | 2007-10-03 | 2007-10-04 | 12405, 12300 | Carpenters [96 h] | 2006-09-13 | Task | 1 | 3 | 2007-12-13 | 2006-08-28 | 3 | 2006-04-21 | 2006-08-29 | 2 | 1 | 2006-04-20 | 2 | 2007-12-13 |  | Stud | W | CP | 87 | 23 |

| ID | Activity | Type | Duration | Start | Finish | Predecessors | Planned start | Planned finish | Constraint | Calendar | Resources | MEF | P3 Task Type | ADur | PESS | AFinish | Imported Late Start | MOD | Imported Early Finish | Imported Late Finish | MOST | ActDur | Imported Early Start | OPTD | AStart | LOC3 Segment | WTYP | LOC1 Tower | CRTY | LOC2 Floor | PL-1 | Opened Ended Tasks | Constraints |
| --- | --- | --- | --- | --- | --- | --- | --- | --- | --- | --- | --- | --- | --- | --- | --- | --- | --- | --- | --- | --- | --- | --- | --- | --- | --- | --- | --- | --- | --- | --- | --- | --- | --- |
| 12310 | West23 R/I Plumbing |  | 2d | 2007-10-03 | 2007-10-04 | 12410, 12300 |  |  |  |  | Plumbers [64 h] | 2006-09-13 | Task | 2 | 3 | 2007-12-13 | 2006-08-29 | 3 | 2006-04-21 | 2006-08-30 | 2 | 2 | 2006-04-20 | 2 | 2007-12-12 | 23 | R/I PB | W | PB |  |  |  |  |
| 12315 | West23 HVAC Ductwork |  | 2d | 2007-10-03 | 2007-10-04 | 12415, 12300 |  |  |  |  | HVAC Sheet Metal [64 h] | 2006-09-13 | Task | 1 | 3 | 2007-12-11 | 2006-08-30 | 3 | 2006-04-21 | 2006-08-31 | 2 | 1 | 2006-04-20 | 2 | 2007-12-11 | 23 | HVAC | W | HV |  |  |  |  |
| 12420 | West24 R/I Electric |  | 2d | 2007-10-03 | 2007-10-04 | 12405 |  |  |  |  | Electricians [64 h] | 2006-09-13 | Task | 1 | 3 | 2007-12-13 | 2006-08-30 | 3 | 2006-04-21 | 2006-08-31 | 2 | 1 | 2006-04-20 | 2 | 2007-12-13 |  | R/I Elec | W | EL | 24 |  |  |  |
| 12425 | West24 Plumbing Test |  | 1d | 2007-10-03 | 2007-10-03 | 12410 |  |  |  |  | Plumbers [16 h] | 2006-09-12 | Task | 1 | 1 | 2007-12-12 | 2006-08-31 | 2 | 2006-04-20 | 2006-08-31 | 1 | 1 | 2006-04-20 | 1 | 2007-12-12 |  | PB Test | W | PB | 24 |  |  |  |
| 12530 | West25 Drywall/2 & Finishes |  | 2d | 2007-10-03 | 2007-10-04 | 12525, 12520, 12515 |  |  |  |  | Carpenters [96 h] | 2006-09-13 | Task | 2 | 3 | 2007-12-13 | 2006-09-01 | 3 | 2006-04-21 | 2006-09-04 | 2 | 2 | 2006-04-20 | 2 | 2007-12-12 |  | Drywall | W | CP | 25 |  |  |  |
| 12635 | West26 Electric Fixtures |  | 2d | 2007-10-03 | 2007-10-04 | 12630 |  |  |  |  | Electricians [32 h] | 2006-09-13 | Task | 2 | 3 | 2007-12-17 | 2006-09-05 | 3 | 2006-04-21 | 2006-09-06 | 2 | 2 | 2006-04-20 | 2 | 2007-12-14 |  | Elec Fixt | W | EL | 26 |  |  |  |
| 12640 | West26 Plumbing Fixtures |  | 2d | 2007-10-03 | 2007-10-04 | 12630 |  |  |  |  | Plumbers [32 h] | 2006-09-13 | Task | 2 | 3 | 2007-12-17 | 2006-09-05 | 3 | 2006-04-21 | 2006-09-06 | 2 | 2 | 2006-04-20 | 2 | 2007-12-14 |  | PB Fixt | W | PB | 26 |  |  |  |
| 12645 | West26 HVAC Fixtures |  | 1d | 2007-10-03 | 2007-10-03 | 12630 |  |  |  |  | HVAC Sheet Metal [16 h] | 2006-09-12 | Task | 1 | 1 | 2007-12-14 | 2006-09-06 | 2 | 2006-04-20 | 2006-09-06 | 1 | 1 | 2006-04-20 | 1 | 2007-12-14 |  | HVAC | W | HV | 26 |  |  |  |
| 12750 | West27 Paint & Carpeting |  | 2d | 2007-10-03 | 2007-10-04 | 12745, 12740, 12735 |  |  |  |  | Subcontract Work [96 h] | 2006-09-13 | Task | 1 | 3 | 2007-12-13 | 2006-09-07 | 3 | 2006-04-21 | 2006-09-08 | 2 | 1 | 2006-04-20 | 2 | 2007-12-13 |  | Paint | W | SB | 27 |  |  |  |
| 22305 | East23 Studs & Drywall/1 |  | 2d | 2007-10-03 | 2007-10-04 | 22405, 22300 |  |  |  |  | Carpenters [96 h] | 2006-10-02 | Task | 2 | 3 | 2007-11-12 | 2006-08-28 | 3 | 2006-05-19 | 2006-08-29 | 2 | 2 | 2006-05-18 | 2 | 2007-11-09 | 23 | Stud | E | CP |  | 85 |  |  |
| 22310 | East23 R/I Plumbing |  | 2d | 2007-10-03 | 2007-10-04 | 22410, 22300 |  |  |  |  | Plumbers [64 h] | 2006-10-02 | Task | 3 | 3 | 2007-11-13 | 2006-08-29 | 3 | 2006-05-19 | 2006-08-30 | 2 | 3 | 2006-05-18 | 2 | 2007-11-09 | 23 | R/I PB | E | PB |  |  |  |  |
| 22315 | East23 HVAC Ductwork |  | 2d | 2007-10-03 | 2007-10-04 | 22415, 22300 |  |  |  |  | HVAC Sheet Metal [64 h] | 2006-10-02 | Task | 1 | 3 | 2007-11-08 | 2006-08-30 | 3 | 2006-05-19 | 2006-08-31 | 2 | 1 | 2006-05-18 | 2 | 2007-11-08 | 23 | HVAC | E | HV |  |  |  |  |
| 22420 | East24 R/I Electric |  | 2d | 2007-10-03 | 2007-10-04 | 22405 |  |  |  |  | Electricians [64 h] | 2006-10-02 | Task | 2 | 3 | 2007-11-12 | 2006-08-30 | 3 | 2006-05-19 | 2006-08-31 | 2 | 2 | 2006-05-18 | 2 | 2007-11-09 |  | R/I Elec | E | EL | 24 |  |  |  |
| 22425 | East24 Plumbing Test |  | 1d | 2007-10-03 | 2007-10-03 | 22410 |  |  |  |  | Plumbers [16 h] | 2006-09-29 | Task | 1 | 1 | 2007-11-09 | 2006-08-31 | 2 | 2006-05-18 | 2006-08-31 | 1 | 1 | 2006-05-18 | 1 | 2007-11-09 |  | PB Test | E | PB | 24 |  |  |  |
| 22530 | East25 Drywall/2 & Finishes |  | 2d | 2007-10-03 | 2007-10-04 | 22525, 22520, 22515 |  |  |  |  | Carpenters [96 h] | 2006-10-02 | Task | 2 | 3 | 2007-11-13 | 2006-09-01 | 3 | 2006-05-19 | 2006-09-04 | 2 | 2 | 2006-05-18 | 2 | 2007-11-12 |  | Drywall | E | CP | 25 |  |  |  |
| 22635 | East26 Electric Fixtures |  | 2d | 2007-10-03 | 2007-10-04 | 22630 |  |  |  |  | Electricians [32 h] | 2006-10-02 | Task | 2 | 3 | 2007-11-12 | 2006-09-05 | 3 | 2006-05-19 | 2006-09-06 | 2 | 2 | 2006-05-18 | 2 | 2007-11-09 |  | Elec Fixt | E | EL | 26 |  |  |  |
| 22640 | East26 Plumbing Fixtures |  | 2d | 2007-10-03 | 2007-10-04 | 22630 |  |  |  |  | Plumbers [32 h] | 2006-10-02 | Task | 2 | 3 | 2007-11-12 | 2006-09-05 | 3 | 2006-05-19 | 2006-09-06 | 2 | 2 | 2006-05-18 | 2 | 2007-11-09 |  | PB Fixt | E | PB | 26 |  |  |  |
| 22645 | East26 HVAC Fixtures |  | 1d | 2007-10-03 | 2007-10-03 | 22630 |  |  |  |  | HVAC Sheet Metal [16 h] | 2006-09-29 | Task | 1 | 1 | 2007-11-09 | 2006-09-06 | 2 | 2006-05-18 | 2006-09-06 | 1 | 1 | 2006-05-18 | 1 | 2007-11-09 |  | HVAC | E | HV | 26 |  |  |  |
| 22750 | East27 Paint & Carpeting |  | 2d | 2007-10-03 | 2007-10-04 | 22745, 22740, 22735 |  |  |  |  | Subcontract Work [96 h] | 2006-10-02 | Task | 2 | 3 | 2007-11-12 | 2006-09-07 | 3 | 2006-05-19 | 2006-09-08 | 2 | 2 | 2006-05-18 | 2 | 2007-11-09 |  | Paint | E | SB | 27 |  |  |  |
| 12320 | West23 R/I Electric |  | 2d | 2007-10-05 | 2007-10-08 | 12305 |  |  |  |  | Electricians [64 h] | 2006-09-18 | Task | 2 | 3 | 2007-12-17 | 2006-08-30 | 3 | 2006-04-25 | 2006-08-31 | 2 | 2 | 2006-04-24 | 2 | 2007-12-14 | 23 | R/I Elec | W | EL |  | 87 |  |  |
| 12325 | West23 Plumbing Test |  | 1d | 2007-10-05 | 2007-10-05 | 12310 |  |  |  |  | Plumbers [16 h] | 2006-09-15 | Task | 1 | 1 | 2007-12-14 | 2006-08-31 | 2 | 2006-04-24 | 2006-08-31 | 1 | 1 | 2006-04-24 | 1 | 2007-12-14 | 23 | PB Test | W | PB |  |  |  |  |
| 12430 | West24 Drywall/2 & Finishes |  | 2d | 2007-10-05 | 2007-10-08 | 12425, 12420, 12415 |  |  |  |  | Carpenters [96 h] | 2006-09-18 | Task | 2 | 3 | 2007-12-17 | 2006-09-01 | 3 | 2006-04-25 | 2006-09-04 | 2 | 2 | 2006-04-24 | 2 | 2007-12-14 |  | Drywall | W | CP | 24 |  |  |  |
| 12535 | West25 Electric Fixtures |  | 2d | 2007-10-05 | 2007-10-08 | 12530 |  |  |  |  | Electricians [32 h] | 2006-09-18 | Task | 1 | 3 | 2007-12-14 | 2006-09-05 | 3 | 2006-04-25 | 2006-09-06 | 2 | 1 | 2006-04-24 | 2 | 2007-12-14 |  | Elec Fixt | W | EL | 25 |  |  |  |
| 12540 | West25 Plumbing Fixtures |  | 2d | 2007-10-05 | 2007-10-08 | 12530 |  |  |  |  | Plumbers [32 h] | 2006-09-18 | Task | 1 | 3 | 2007-12-14 | 2006-09-05 | 3 | 2006-04-25 | 2006-09-06 | 2 | 1 | 2006-04-24 | 2 | 2007-12-14 |  | PB Fixt | W | PB | 25 |  |  |  |
| 12545 | West25 HVAC Fixtures |  | 1d | 2007-10-05 | 2007-10-05 | 12530 |  |  |  |  | HVAC Sheet Metal [16 h] | 2006-09-15 | Task | 1 | 1 | 2007-12-14 | 2006-09-06 | 2 | 2006-04-24 | 2006-09-06 | 1 | 1 | 2006-04-24 | 1 | 2007-12-14 |  | HVAC | W | HV | 25 |  |  |  |
| 12650 | West26 Paint & Carpeting |  | 2d | 2007-10-05 | 2007-10-08 | 12645, 12640, 12635 |  |  |  |  | Subcontract Work [96 h] | 2006-09-18 | Task | 2 | 3 | 2007-12-19 | 2006-09-07 | 3 | 2006-04-25 | 2006-09-08 | 2 | 2 | 2006-04-24 | 2 | 2007-12-18 |  | Paint | W | SB | 26 |  |  |  |
| 22320 | East23 R/I Electric |  | 2d | 2007-10-05 | 2007-10-08 | 22305 |  |  |  |  | Electricians [64 h] | 2006-10-05 | Task | 2 | 3 | 2007-11-14 | 2006-08-30 | 3 | 2006-05-23 | 2006-08-31 | 2 | 2 | 2006-05-22 | 2 | 2007-11-13 | 23 | R/I Elec | E | EL |  | 85 |  |  |
| 22325 | East23 Plumbing Test |  | 1d | 2007-10-05 | 2007-10-05 | 22310 |  |  |  |  | Plumbers [16 h] | 2006-10-04 | Task | 1 | 1 | 2007-11-14 | 2006-08-31 | 2 | 2006-05-22 | 2006-08-31 | 1 | 1 | 2006-05-22 | 1 | 2007-11-14 | 23 | PB Test | E | PB |  |  |  |  |
| 22430 | East24 Drywall/2 & Finishes |  | 2d | 2007-10-05 | 2007-10-08 | 22425, 22420, 22415 |  |  |  |  | Carpenters [96 h] | 2006-10-05 | Task | 2 | 3 | 2007-11-14 | 2006-09-01 | 3 | 2006-05-23 | 2006-09-04 | 2 | 2 | 2006-05-22 | 2 | 2007-11-13 |  | Drywall | E | CP | 24 |  |  |  |
| 22535 | East25 Electric Fixtures |  | 2d | 2007-10-05 | 2007-10-08 | 22530 |  |  |  |  | Electricians [32 h] | 2006-10-05 | Task | 2 | 3 | 2007-11-15 | 2006-09-05 | 3 | 2006-05-23 | 2006-09-06 | 2 | 2 | 2006-05-22 | 2 | 2007-11-14 |  | Elec Fixt | E | EL | 25 |  |  |  |
| 22540 | East25 Plumbing Fixtures |  | 2d | 2007-10-05 | 2007-10-08 | 22530 |  |  |  |  | Plumbers [32 h] | 2006-10-05 | Task | 2 | 3 | 2007-11-15 | 2006-09-05 | 3 | 2006-05-23 | 2006-09-06 | 2 | 2 | 2006-05-22 | 2 | 2007-11-14 |  | PB Fixt | E | PB | 25 |  |  |  |
| 22545 | East25 HVAC Fixtures |  | 1d | 2007-10-05 | 2007-10-05 | 22530 |  |  |  |  | HVAC Sheet Metal [16 h] | 2006-10-04 | Task | 2 | 1 | 2007-11-15 | 2006-09-06 | 2 | 2006-05-22 | 2006-09-06 | 1 | 2 | 2006-05-22 | 1 | 2007-11-14 |  | HVAC | E | HV | 25 |  |  |  |
| 22650 | East26 Paint & Carpeting |  | 2d | 2007-10-05 | 2007-10-08 | 22645, 22640, 22635 |  |  |  |  | Subcontract Work [96 h] | 2006-10-05 | Task | 2 | 3 | 2007-11-14 | 2006-09-07 | 3 | 2006-05-23 | 2006-09-08 | 2 | 2 | 2006-05-22 | 2 | 2007-11-13 |  | Paint | E | SB | 26 |  |  |  |
| 12330 | West23 Drywall/2 & Finishes |  | 2d | 2007-10-09 | 2007-10-10 | 12325, 12320, 12315 |  |  |  |  | Carpenters [96 h] | 2006-09-21 | Task | 2 | 3 | 2007-12-19 | 2006-09-01 | 3 | 2006-04-27 | 2006-09-04 | 2 | 2 | 2006-04-26 | 2 | 2007-12-18 | 23 | Drywall | W | CP |  | 87 |  |  |
| 12435 | West24 Electric Fixtures |  | 2d | 2007-10-09 | 2007-10-10 | 12430 |  |  |  |  | Electricians [32 h] | 2006-09-21 | Task | 2 | 3 | 2007-12-19 | 2006-09-05 | 3 | 2006-04-27 | 2006-09-06 | 2 | 2 | 2006-04-26 | 2 | 2007-12-18 |  | Elec Fixt | W | EL | 24 |  |  |  |
| 12440 | West24 Plumbing Fixtures |  | 2d | 2007-10-09 | 2007-10-10 | 12430 |  |  |  |  | Plumbers [32 h] | 2006-09-21 | Task | 2 | 3 | 2007-12-19 | 2006-09-05 | 3 | 2006-04-27 | 2006-09-06 | 2 | 2 | 2006-04-26 | 2 | 2007-12-18 |  | PB Fixt | W | PB | 24 |  |  |  |
| 12445 | West24 HVAC Fixtures |  | 1d | 2007-10-09 | 2007-10-09 | 12430 |  |  |  |  | HVAC Sheet Metal [16 h] | 2006-09-20 | Task | 1 | 1 | 2007-12-18 | 2006-09-06 | 2 | 2006-04-26 | 2006-09-06 | 1 | 1 | 2006-04-26 | 1 | 2007-12-18 |  | HVAC | W | HV | 24 |  |  |  |
| 12550 | West25 Paint & Carpeting |  | 2d | 2007-10-09 | 2007-10-10 | 12545, 12540, 12535 |  |  |  |  | Subcontract Work [96 h] | 2006-09-21 | Task | 2 | 3 | 2007-12-18 | 2006-09-07 | 3 | 2006-04-27 | 2006-09-08 | 2 | 2 | 2006-04-26 | 2 | 2007-12-17 |  | Paint | W | SB | 25 |  |  |  |
| 22330 | East23 Drywall/2 & Finishes |  | 2d | 2007-10-09 | 2007-10-10 | 22325, 22320, 22315 |  |  |  |  | Carpenters [96 h] | 2006-10-10 | Task | 2 | 3 | 2007-11-16 | 2006-09-01 | 3 | 2006-05-25 | 2006-09-04 | 2 | 2 | 2006-05-24 | 2 | 2007-11-15 | 23 | Drywall | E | CP |  | 85 |  |  |
| 22435 | East24 Electric Fixtures |  | 2d | 2007-10-09 | 2007-10-10 | 22430 |  |  |  |  | Electricians [32 h] | 2006-10-10 | Task | 2 | 3 | 2007-11-16 | 2006-09-05 | 3 | 2006-05-25 | 2006-09-06 | 2 | 2 | 2006-05-24 | 2 | 2007-11-15 |  | Elec Fixt | E | EL | 24 |  |  |  |
| 22440 | East24 Plumbing Fixtures |  | 2d | 2007-10-09 | 2007-10-10 | 22430 |  |  |  |  | Plumbers [32 h] | 2006-10-10 | Task | 2 | 3 | 2007-11-16 | 2006-09-05 | 3 | 2006-05-25 | 2006-09-06 | 2 | 2 | 2006-05-24 | 2 | 2007-11-15 |  | PB Fixt | E | PB | 24 |  |  |  |
| 22445 | East24 HVAC Fixtures |  | 1d | 2007-10-09 | 2007-10-09 | 22430 |  |  |  |  | HVAC Sheet Metal [16 h] | 2006-10-09 | Task | 1 | 1 | 2007-11-15 | 2006-09-06 | 2 | 2006-05-24 | 2006-09-06 | 1 | 1 | 2006-05-24 | 1 | 2007-11-15 |  | HVAC | E | HV | 24 |  |  |  |
| 22550 | East25 Paint & Carpeting |  | 2d | 2007-10-09 | 2007-10-10 | 22545, 22540, 22535 |  |  |  |  | Subcontract Work [96 h] | 2006-10-10 | Task | 2 | 3 | 2007-11-19 | 2006-09-07 | 3 | 2006-05-25 | 2006-09-08 | 2 | 2 | 2006-05-24 | 2 | 2007-11-16 |  | Paint | E | SB | 25 |  |  |  |
| 9975 | SiteG0 Casino Punchlist |  | 10d | 2007-10-10 | 2007-10-23 | 9955, 1235, 1225 |  |  |  |  |  |  |  | 10 |  | 2007-11-15 |  |  |  |  |  | 10 |  |  | 2007-11-02 |  |  | S |  | G0 | 02 |  |  |
| 12335 | West23 Electric Fixtures |  | 2d | 2007-10-11 | 2007-10-12 | 12330 |  |  |  |  | Electricians [32 h] | 2006-09-26 | Task | 2 | 3 | 2007-12-21 | 2006-09-05 | 3 | 2006-05-01 | 2006-09-06 | 2 | 2 | 2006-04-28 | 2 | 2007-12-20 | 23 | Elec Fixt | W | EL |  |  |  |  |
| 12340 | West23 Plumbing Fixtures |  | 2d | 2007-10-11 | 2007-10-12 | 12330 |  |  |  |  | Plumbers [32 h] | 2006-09-26 | Task | 3 | 3 | 2007-12-24 | 2006-09-05 | 3 | 2006-05-01 | 2006-09-06 | 2 | 3 | 2006-04-28 | 2 | 2007-12-20 | 23 | PB Fixt | W | PB |  | 87 |  |  |
| 12345 | West23 HVAC Fixtures |  | 1d | 2007-10-11 | 2007-10-11 | 12330 |  |  |  |  | HVAC Sheet Metal [16 h] | 2006-09-25 | Task | 1 | 1 | 2007-12-20 | 2006-09-06 | 2 | 2006-04-28 | 2006-09-06 | 1 | 1 | 2006-04-28 | 1 | 2007-12-20 | 23 | HVAC | W | HV |  |  |  |  |
| 12450 | West24 Paint & Carpeting |  | 2d | 2007-10-11 | 2007-10-12 | 12445, 12440, 12435 |  |  |  |  | Subcontract Work [96 h] | 2006-09-26 | Task | 1 | 3 | 2007-12-20 | 2006-09-07 | 3 | 2006-05-01 | 2006-09-08 | 2 | 1 | 2006-04-28 | 2 | 2007-12-20 |  | Paint | W | SB | 24 |  |  |  |
| 22335 | East23 Electric Fixtures |  | 2d | 2007-10-11 | 2007-10-12 | 22330 |  |  |  |  | Electricians [32 h] | 2006-10-13 | Task | 2 | 3 | 2007-11-20 | 2006-09-05 | 3 | 2006-05-29 | 2006-09-06 | 2 | 2 | 2006-05-26 | 2 | 2007-11-19 | 23 | Elec Fixt | E | EL |  |  |  |  |
| 22340 | East23 Plumbing Fixtures |  | 2d | 2007-10-11 | 2007-10-12 | 22330 |  |  |  |  | Plumbers [32 h] | 2006-10-13 | Task | 2 | 3 | 2007-11-20 | 2006-09-05 | 3 | 2006-05-29 | 2006-09-06 | 2 | 2 | 2006-05-26 | 2 | 2007-11-19 | 23 | PB Fixt | E | PB |  | 85 |  |  |
| 22345 | East23 HVAC Fixtures |  | 1d | 2007-10-11 | 2007-10-11 | 22330 |  |  |  |  | HVAC Sheet Metal [16 h] | 2006-10-12 | Task | 1 | 1 | 2007-11-19 | 2006-09-06 | 2 | 2006-05-26 | 2006-09-06 | 1 | 1 | 2006-05-26 | 1 | 2007-11-19 | 23 | HVAC | E | HV |  |  |  |  |
| 22450 | East24 Paint & Carpeting |  | 2d | 2007-10-11 | 2007-10-12 | 22445, 22440, 22435 |  |  |  |  | Subcontract Work [96 h] | 2006-10-13 | Task | 2 | 3 | 2007-11-20 | 2006-09-07 | 3 | 2006-05-29 | 2006-09-08 | 2 | 2 | 2006-05-26 | 2 | 2007-11-19 |  | Paint | E | SB | 24 |  |  |  |
| 12350 | West23 Paint & Carpeting |  | 2d | 2007-10-15 | 2007-10-16 | 12345, 12340, 12335 |  |  |  |  | Subcontract Work [96 h] | 2006-09-29 | Task | 1 | 3 | 2007-12-25 | 2006-09-07 | 3 | 2006-05-03 | 2006-09-08 | 2 | 1 | 2006-05-02 | 2 | 2007-12-25 | 23 | Paint | W | SB |  | 87 |  |  |
| 22350 | East23 Paint & Carpeting |  | 2d | 2007-10-15 | 2007-10-16 | 22345, 22340, 22335 |  |  |  |  | Subcontract Work [96 h] | 2006-10-18 | Task | 1 | 3 | 2007-11-21 | 2006-09-07 | 3 | 2006-05-31 | 2006-09-08 | 2 | 1 | 2006-05-30 | 2 | 2007-11-21 | 23 | Paint | E | SB |  | 85 |  |  |
| 9980 | WestG0 Residential Building Punchlist |  | 10d | 2007-10-17 | 2007-10-30 | 14450, 14350, 14250, 14150, 14050, 13950, 13850, 13750, 13650, 13550, 13450, 13350, 13250, 13150, 13050, 12950, 12850, 12750, 12650, 12550, 12450, 12350, 12250, 12150, 12050, 11950, 11850, 11750, 11650, 11550, 11450, 11350, 11250, 11150, 11050, 10950, 10850, 10750, 10650, 10550, 10450, 10350, 10250, 10150, 1165 |  |  |  |  |  | 2006-11-01 | Task | 10 | 13 | 2008-01-08 | 2006-09-11 | 10 | 2006-09-22 | 2006-09-22 | 10 | 10 | 2006-09-11 | 8 | 2007-12-26 |  |  | W |  | G0 | 03 |  |  |
| 9985 | EastG0East Residential Building Punchlist |  | 10d | 2007-10-17 | 2007-10-30 | 24450, 24350, 24250, 24150, 24050, 23950, 23850, 23750, 23650, 23550, 23450, 23350, 23250, 23150, 23050, 22950, 22850, 22750, 22650, 22550, 22450, 22350, 22250, 22150, 22050, 21950, 21850, 21750, 21650, 21550, 21450, 21350, 21250, 21150, 21050, 20950, 20850, 20750, 20650, 20550, 20450, 20350, 20250, 20150, 2165 |  |  |  |  |  |  |  | 10 |  | 2007-12-05 |  |  |  |  |  | 10 |  |  | 2007-11-22 |  |  | E |  | G0 | 04 |  |  |
| 9990 | SiteG0 Project Punchlist |  | 10d | 2007-10-17 | 2007-10-30 | 9985 SS, 9985 FF, 9980 SS, 9980 FF, 9975 SS, 9975 FF, 2270 |  |  |  |  |  |  |  | 10 |  | 2008-01-08 |  |  |  |  |  | 10 |  |  | 2007-12-26 |  |  | S |  | G0 | 05 |  |  |
| 9995 | Project Complete Milestone | milestone | 0d | 2007-10-30 | 2007-10-30 | 9990 | 2007-10-31 | 2007-10-30 | finish on or before 2007-11-01 | 7 Day |  |  |  | 0 |  | 2008-01-08 |  |  |  |  |  | 0 |  |  | 2008-01-09 |  |  |  |  |  | 06 | No successors | (Type)Finish on or before (Date)11/1/2007 9:00:00 AM |

## Activity codes

| Code | Value | Meaning |
| --- | --- | --- |
| LOC1 Tower | C | Casino & Restaurants |
| LOC1 Tower | E | East Tower |
| LOC1 Tower | S | Site |
| LOC1 Tower | W | West Tower |
| LOC2 Floor | 02 | Residential Level 02 |
| LOC2 Floor | 22 | Skylobby |
| LOC2 Floor | 43 | Penthouse Level 1 |
| LOC2 Floor | 44 | Penthouse Level 2 |
| LOC2 Floor | CL | Pool & Lobby Level |
| LOC2 Floor | G0 | Site |
| LOC2 Floor | G2 | Casino @ Level 2 |
| LOC2 Floor | G3 | Garage Level 3 |
| LOC2 Floor | G4 | Garage Level 4 |
| LOC2 Floor | G5 | Garage Level 5 |
| LOC2 Floor | GF | Fabrication |
| LOC2 Floor | RF | Roof Level |
| LOC3 Segment | 10 | 10-22 |
| LOC3 Segment | 23 | 23-31 |
| LOC3 Segment | 32 | 32-44 |
| LOC3 Segment | GS | GS-G5 |
